# 210921_Programación E&D

Schedule from MS Project, 2023-01-03 to 2025-12-19, 9 hours a day.

## Calendars

- Estándar: Mon-Fri 07:00-12:00, 13:00-17:00; Sat 07:00-10:00; Sun off. Exceptions (off unless hours are given): 2023-01-09 (Reyes Magos), 2023-03-20 (Día de San José), 2023-04-06 (Jueves Santo), 2023-04-07 (Viernes Santo), 2023-05-01 (Día del Trabajador), 2023-05-22 (Día de la Ascención), 2023-06-12 (Corpus Cristi), 2023-06-19 (Sagrado Corazón), 2023-07-03 (San Pedro y San Pablo), 2023-07-20 (Día de la Independencía), 2023-08-07 (Batalla de Boyaca), 2023-08-21 (Asunción de la Virgen), 2023-10-16 (Día de la raza), 2023-11-06 (Día de los difuntos), 2023-11-13 (Independencia de Cartagena), 2023-12-08 (Día de la Inmaculda Concepción), 2023-12-25 (Navidad), 2024-01-01 (Año Nuevo), 2024-01-08 (Reyes Magos), 2024-03-25 (San José), 2024-03-28 (Jueves Santo), 2024-03-29 (Viernes Santo), 2024-05-01 (Día del Trabajador), 2024-05-13 (Día de la Ascención), 2024-06-03 (Corpus Cristi), 2024-06-10 (Sagrado Corazón), 2024-07-01 (San Pedro y San Pablo), 2024-07-20 (Día de la Independencia), 2024-08-07 (Batalla de Boyaca), 2024-08-19 (Asunción de la Virgen), 2024-10-14 (Día de la raza), 2024-11-04 (Día de los difuntos), 2024-11-11 (Independencia de Cartagena), 2024-12-08 (Inmaculada Concepción), 2024-12-25 (Navidad), 2025-01-01 (Año Nuevo), 2025-01-06 (Reyes Magos), 2025-03-24 (San José), 2025-04-17 (Jueves Santo), 2025-04-18 (Viernes Santo), 2025-05-01 (Día del trabajador), 2025-06-02 (Día de la Ascención), 2025-06-23 (Corpus Cristi), 2025-06-30 (Sagrado Corazón - San Pedro y San Pablo), 2025-07-20 (Día de la Independencia), 2025-08-07 (Batalla de Boyaca), 2025-08-18 (Asunción de la Virgen), 2025-10-13 (Día de la raza), 2025-11-03 (Día de los difuntos), 2025-11-17 (Independencia de Cartagena), 2025-12-08 (Día de la inmaculada concepción).

## Schedule

| ID | WBS | Task | Type | Duration | Start | Finish | Predecessors | Total slack | Free slack | Constraint | % Avance Planeado | % avance planeado en costo (texto) | % Completado (décimales) | % Completado en Costo |
| --- | --- | --- | --- | --- | --- | --- | --- | --- | --- | --- | --- | --- | --- | --- |
| 1 | 1 | **CABLE SAN CRISTÓBAL, BOGOTÁ D.C. INCLUYE: ETAPA DE ESTUDIOS Y DISEÑOS DE DETALLE ELECTROMECÁNICA, ETAPA PRECONSTRUCCIÓN, ETAPA DE CONSTRUCCIÓN, INCLUYE UN MES DE ENTRENAMIENTO Y CINCO MESES DE ACOMPAÑAMIENTO** |  | 777d | 2023-01-03 | 2025-12-19 |  | 0d |  |  | 0,00% | 0,00% | 0,00% | 0,00% |
| 2 | 1.1 | SUSCRIPCIÓN DEL ACTA DE INICIO | milestone | 0d | 2023-01-03 | 2023-01-03 |  | 0d |  | start no earlier than 2023-01-03 | 0,00% | 0,00% | 0,00% | 0,00% |
| 3 | 1.2 | **ETAPA E&D - COMPONENTE ELECTROMECÁNICO** |  | 158d | 2023-01-03 | 2023-08-11 |  | 118d |  |  | 0,00% | 0,00% | 0,00% | 0,00% |
| 4 | 1.2.1 | **INICIO ETAPA E&D DE DETALLE - COMPONENTE ELECTROMECÁNICO** |  | 148d | 2023-01-03 | 2023-07-28 |  | 118d |  |  | 0,00% | 0,00% | 0,00% | 0,00% |
| 5 | 1.2.1.1 | Desarrollo E&D - Componente Electromecánico |  | 138d | 2023-01-03 | 2023-07-13 | 2 | 118d | 0d | start no earlier than 2015-09-04 | 0,00% | 0,00% | 0,00% | 0,00% |
| 6 | 1.2.1.2 | Primera revisión de la Interventoría |  | 5d | 2023-07-14 | 2023-07-21 | 5 | 118d | 0d |  | 0,00% | 0,00% | 0,00% | 0,00% |
| 7 | 1.2.1.3 | Atención de Observaciones |  | 5d | 2023-07-21 | 2023-07-28 | 6 | 118d | 0d |  | 0,00% | 0,00% | 0,00% | 0,00% |
| 8 | 1.2.1.4 | Aprobación de Interventoría | milestone | 0d | 2023-07-28 | 2023-07-28 | 7 | 118d | 0d |  | 0,00% | 0,00% | 0,00% | 0,00% |
| 9 | 1.2.1.5 | Fin Etapa E&D: Hito de Aprobación Para Pago E&D Componente Electromecánico | milestone | 0d | 2023-07-28 | 2023-07-28 | 8 | 128d | 10d | start no earlier than 2015-09-04 | 0,00% | 0,00% | 0,00% | 0,00% |
| 10 | 1.2.2 | Revisión del IDU |  | 5d | 2023-07-28 | 2023-08-03 | 8 | 118d | 0d |  | 0,00% | 0,00% | 0,00% | 0,00% |
| 11 | 1.2.3 | Atención de Observaciones |  | 5d | 2023-08-04 | 2023-08-11 | 10 | 118d | 0d |  | 0,00% | 0,00% | 0,00% | 0,00% |
| 12 | 1.2.4 | Recibo del IDU | milestone | 0d | 2023-08-11 | 2023-08-11 | 11 | 118d | 0d |  | 0,00% | 0,00% | 0,00% | 0,00% |
| 13 | 1.3 | **FABRICACIÓN Y TRANSPORTE DE COMPONENTES ELECTROMECÁNICOS** |  | 187d | 2023-08-11 | 2024-04-27 |  | 118d |  |  | 0,00% | 0,00% | 0,00% | 0,00% |
| 14 | 1.3.1 | Fabricación Componentes Electromecánicos en Europa |  | 139d | 2023-08-11 | 2024-02-21 | 9, 12 | 118d | 0d |  | 0,00% | 0,00% | 0,00% | 0,00% |
| 15 | 1.3.2 | Envió Transporte Internacional, Nacional y Nacionalización |  | 139d | 2023-10-17 | 2024-04-27 | 14SS+48d | 118d | 0d |  | 0,00% | 0,00% | 0,00% | 0,00% |
| 16 | 1.3.3 | Fabricación Hito de Aprobación Para Pago Componentes Electromecánicos en Europa | milestone | 0d | 2024-02-21 | 2024-02-21 | 14 | 166d | 48d |  | 0,00% | 0,00% | 0,00% | 0,00% |
| 17 | 1.3.4 | Transporte: Hito de Aprobación Para Pago por Nacionalización | milestone | 0d | 2024-04-27 | 2024-04-27 | 15, 16 | 118d | 75d |  | 0,00% | 0,00% | 0,00% | 0,00% |
| 18 | 1.4 | **ETAPA DE PRE-CONSTRUCCIÓN** |  | 138d | 2023-01-03 | 2023-07-13 |  | 0d |  |  | 0,00% | 0,00% | 0,00% | 0,00% |
| 19 | 1.4.1 | **ACTIVIDADES PREVIAS AL INICIO DE LA CONSTRUCCIÓN** |  | 138d | 2023-01-03 | 2023-07-13 |  | 0d |  |  | 0,00% | 0,00% | 0,00% | 0,00% |
| 20 | 1.4.1.1 | Inicio Etapa de Pre - Construcción | milestone | 0d | 2023-01-03 | 2023-01-03 | 2 | 0d |  |  | 0,00% | 0,00% | 0,00% | 0,00% |
| 21 | 1.4.1.2 | Revisión y Apropiación de Diseños |  | 90d | 2023-01-03 | 2023-05-06 | 20 | 0d |  |  | 0,00% | 0,00% | 0,00% | 0,00% |
| 22 | 1.4.1.3 | Elaborar Plan de gestión Social |  | 36d | 2023-01-03 | 2023-02-20 | 20SS | 102d |  |  | 0,00% | 0,00% | 0,00% | 0,00% |
| 23 | 1.4.1.4 | Convocatoria Reunión de Inicio de Obra |  | 24d | 2023-01-03 | 2023-02-03 | 20SS | 114d |  |  | 0,00% | 0,00% | 0,00% | 0,00% |
| 24 | 1.4.1.5 | Levantar Actas de Vecindad |  | 36d | 2023-01-03 | 2023-02-20 | 20SS | 102d |  |  | 0,00% | 0,00% | 0,00% | 0,00% |
| 25 | 1.4.1.6 | Elaborar PMT |  | 24d | 2023-04-22 | 2023-05-26 | 21FS-10d | 0d |  |  | 0,00% | 0,00% | 0,00% | 0,00% |
| 26 | 1.4.1.7 | Aprobación PMT por parte Interventoría |  | 10d | 2023-05-26 | 2023-06-08 | 25 | 0d |  |  | 0,00% | 0,00% | 0,00% | 0,00% |
| 27 | 1.4.1.8 | Aprobación PMT por parte SDM |  | 24d | 2023-06-08 | 2023-07-13 | 26 | 0d |  |  | 0,00% | 0,00% | 0,00% | 0,00% |
| 28 | 1.4.1.9 | Tratamiento Silvicultural (En el caso que se requiera) |  | 24d | 2023-01-03 | 2023-02-03 | 20SS | 114d |  |  | 0,00% | 0,00% | 0,00% | 0,00% |
| 29 | 1.4.1.10 | Campamento |  | 24d | 2023-01-03 | 2023-02-03 | 30 | 753d |  |  | 0,00% | 0,00% | 0,00% | 0,00% |
| 30 | 1.4.1.11 | Verificación, Disponibilidad y recibo de predios Estación 20 de Julio | milestone | 0d | 2023-01-03 | 2023-01-03 | 20 | 113d | 0d |  | 0,00% | 0,00% | 0,00% | 0,00% |
| 31 | 1.4.1.12 | FIN ACTIVIDADES PREVIAS AL INICIO DE LA CONSTRUCCIÓN | milestone | 0d | 2023-07-13 | 2023-07-13 | 22, 23, 24, 25, 20, 26, 27, 28, 30 | 0d |  |  | 0,00% | 0,00% | 0,00% | 0,00% |

| ID | WBS | Task | Type | Duration | Start | Finish | Predecessors | Total slack | Free slack | % Avance Planeado | % avance planeado en costo (texto) | % Completado (décimales) | % Completado en Costo |
| --- | --- | --- | --- | --- | --- | --- | --- | --- | --- | --- | --- | --- | --- |
| 32 | 1.4.1.13 | **GESTIÓN DEL ANTICIPO** |  | 50d | 2023-01-03 | 2023-03-09 |  | 88d |  | 0,00% | 0,00% | 0,00% | 0,00% |
| 33 | 1.4.1.13.1 | Presentación de documentos a la fiducia y de acta para cobro del anticipo |  | 5d | 2023-01-03 | 2023-01-10 | 2 | 88d | 0d | 0,00% | 0,00% | 0,00% | 0,00% |
| 34 | 1.4.1.13.2 | Trámites para la presentación y desembolso del anticipo |  | 45d | 2023-01-10 | 2023-03-09 | 33 | 88d | 0d | 0,00% | 0,00% | 0,00% | 0,00% |
| 35 | 1.4.1.13.3 | Desembolso de Anticipo: Hito Componente Obra Civil | milestone | 0d | 2023-03-09 | 2023-03-09 | 34 | 88d | 0d | 0,00% | 0,00% | 0,00% | 0,00% |
| 36 | 1.4.1.13.4 | Presentación de documentos a la fiducia y de acta para cobro del anticipo Electromecánico |  | 5d | 2023-01-03 | 2023-01-10 | 2 | 88d | 0d | 0,00% | 0,00% | 0,00% | 0,00% |
| 37 | 1.4.1.13.5 | Trámites para la presentación y desembolso del anticipo |  | 45d | 2023-01-10 | 2023-03-09 | 36 | 88d | 0d | 0,00% | 0,00% | 0,00% | 0,00% |
| 38 | 1.4.1.13.6 | Desembolso de Anticipo: Hito Componente Electromecánico | milestone | 0d | 2023-03-09 | 2023-03-09 | 37 | 88d | 0d | 0,00% | 0,00% | 0,00% | 0,00% |
| 39 | 1.4.1.13.7 | FIN GESTIÓN DEL ANTICIPO | milestone | 0d | 2023-03-09 | 2023-03-09 | 35, 38 | 88d |  | 0,00% | 0,00% | 0,00% | 0,00% |
| 40 | 1.4.1.14 | **TRÁMITES Y PERMISOS PARA EL INICIO DE LA CONSTRUCCIÓN** |  | 25d | 2023-01-03 | 2023-02-06 |  | 113d |  | 0,00% | 0,00% | 0,00% | 0,00% |
| 41 | 1.4.1.14.1 | Valla de obra |  | 25d | 2023-01-03 | 2023-02-06 | 30 | 113d | 0d | 0,00% | 0,00% | 0,00% | 0,00% |
| 42 | 1.4.1.14.2 | Trabajo Nocturno |  | 25d | 2023-01-03 | 2023-02-06 | 30 | 113d | 0d | 0,00% | 0,00% | 0,00% | 0,00% |
| 43 | 1.4.1.14.3 | Silviculturales |  | 25d | 2023-01-03 | 2023-02-06 | 30 | 113d | 0d | 0,00% | 0,00% | 0,00% | 0,00% |
| 44 | 1.4.1.14.4 | Coordinación E.S.P. |  | 25d | 2023-01-03 | 2023-02-06 | 30 | 113d | 0d | 0,00% | 0,00% | 0,00% | 0,00% |
| 45 | 1.4.1.14.5 | PMT |  | 25d | 2023-01-03 | 2023-02-06 | 30 | 113d | 0d | 0,00% | 0,00% | 0,00% | 0,00% |
| 46 | 1.4.1.14.6 | FIN TRÁMITES Y PERMISOS PARA EL INICIO DE LA CONSTRUCCIÓN | milestone | 0d | 2023-02-06 | 2023-02-06 | 41, 42, 43, 44, 45 | 113d |  | 0,00% | 0,00% | 0,00% | 0,00% |
| 47 | 1.4.1.15 | FIN ETAPA DE PRE-CONSTRUCCIÓN | milestone | 0d | 2023-07-13 | 2023-07-13 | 31, 46, 39 | 0d |  | 0,00% | 0,00% | 0,00% | 0,00% |
| 48 | 1.5 | **ETAPA DE CONSTRUCCIÓN** |  | 501d | 2023-07-13 | 2025-06-11 |  | 0d |  | 0,00% | 0,00% | 0,00% | 0,00% |
| 49 | 1.5.1 | INICIO ETAPA DE CONSTRUCCIÓN | milestone | 0d | 2023-07-13 | 2023-07-13 | 47 | 55d | 0d | 0,00% | 0,00% | 0,00% | 0,00% |
| 50 | 1.5.2 | **1. ESTACIÓN DE TRANSFERENCIA - 20 DE JULIO** |  | 381d | 2023-07-14 | 2024-12-26 |  | 0d |  | 0,00% | 0,00% | 0,00% | 0,00% |
| 51 | 1.5.2.1 | **PRELIMINARES DE OBRA, REPLANTEO Y LOCALIZACIÓN** |  | 8d | 2023-07-14 | 2023-07-26 |  | 0d |  | 0,00% | 0,00% | 0,00% | 0,00% |
| 52 | 1.5.2.1.1 | Replanteo General |  | 2d | 2023-07-14 | 2023-07-17 | 47 | 0d |  | 0,00% | 0,00% | 0,00% | 0,00% |
| 53 | 1.5.2.1.2 | Cerramiento y Señalización |  | 4d | 2023-07-17 | 2023-07-24 | 52 | 317d | 0d | 0,00% | 0,00% | 0,00% | 0,00% |
| 54 | 1.5.2.1.3 | Tala de Especies |  | 2d | 2023-07-24 | 2023-07-26 | 53 | 317d | 274d | 0,00% | 0,00% | 0,00% | 0,00% |
| 55 | 1.5.2.2 | **DEMOLICIONES** |  | 11d | 2023-07-17 | 2023-08-01 |  | 0d |  | 0,00% | 0,00% | 0,00% | 0,00% |
| 56 | 1.5.2.2.1 | Demolición Estructuras de Concreto para cimentación |  | 11d | 2023-07-17 | 2023-08-01 | 52 | 0d |  | 0,00% | 0,00% | 0,00% | 0,00% |

| ID | WBS | Task | Duration | Start | Finish | Predecessors | Total slack | Free slack | % Avance Planeado | % avance planeado en costo (texto) | % Completado (décimales) | % Completado en Costo |
| --- | --- | --- | --- | --- | --- | --- | --- | --- | --- | --- | --- | --- |
| 57 | 1.5.2.3 | **MOVIMIENTO DE TIERRAS PARA TANQUE** | 5d | 2023-08-02 | 2023-08-09 |  | 307d | 157d | 0,00% | 0,00% | 0,00% | 0,00% |
| 58 | 1.5.2.3.1 | Excavación Mecánica con Entibado | 5d | 2023-08-02 | 2023-08-09 | 56 | 307d | 0d | 0,00% | 0,00% | 0,00% | 0,00% |
| 59 | 1.5.2.3.2 | Transporte y Disposición Final de Escombros en Sitio Autorizado | 5d | 2023-08-02 | 2023-08-09 | 58FF | 307d | 264d | 0,00% | 0,00% | 0,00% | 0,00% |
| 60 | 1.5.2.4 | **RELLENOS** | 44d | 2023-10-20 | 2023-12-21 |  | 504d | 60d | 0,00% | 0,00% | 0,00% | 0,00% |
| 61 | 1.5.2.4.1 | Relleno en Material Granular | 44d | 2023-10-20 | 2023-12-21 | 74 | 504d | 49d | 0,00% | 0,00% | 0,00% | 0,00% |
| 62 | 1.5.2.5 | **CIMENTACIÓN PARA MASTILES DE ESTACIÓN 20 DE JULIO** | 58d | 2023-08-02 | 2023-10-20 |  | 0d |  | 0,00% | 0,00% | 0,00% | 0,00% |
| 63 | 1.5.2.5.1 | **CONSTRUCCIÓN PILOTES** | 26d | 2023-08-02 | 2023-09-07 |  | 0d |  | 0,00% | 0,00% | 0,00% | 0,00% |
| 64 | 1.5.2.5.1.1 | Excavación mecánica para pilotes | 13d | 2023-08-02 | 2023-08-19 | 56 | 0d |  | 0,00% | 0,00% | 0,00% | 0,00% |
| 65 | 1.5.2.5.1.2 | Transporte y Disposición Final de Escombros en Sitio Autorizado | 13d | 2023-08-22 | 2023-09-07 | 64 | 286d | 0d | 0,00% | 0,00% | 0,00% | 0,00% |
| 66 | 1.5.2.5.1.3 | Acero de Refuerzo | 13d | 2023-08-03 | 2023-08-22 | 64SS+1d | 117d | 0d | 0,00% | 0,00% | 0,00% | 0,00% |
| 67 | 1.5.2.5.1.4 | Concreto | 13d | 2023-08-03 | 2023-08-22 | 66SS | 117d | 0d | 0,00% | 0,00% | 0,00% | 0,00% |
| 68 | 1.5.2.5.1.5 | Descabece de Pilotes | 7d | 2023-08-15 | 2023-08-24 | 67SS+8d | 296d | 253d | 0,00% | 0,00% | 0,00% | 0,00% |
| 69 | 1.5.2.5.2 | **CONSTRUCCIÓN DADOS DE CIMENTACIÓN** | 14d | 2023-08-23 | 2023-09-09 |  | 117d |  | 0,00% | 0,00% | 0,00% | 0,00% |
| 70 | 1.5.2.5.2.1 | Excavación mecánica para dados | 7d | 2023-08-23 | 2023-08-31 | 67 | 117d | 0d | 0,00% | 0,00% | 0,00% | 0,00% |
| 71 | 1.5.2.5.2.2 | Transporte y Disposición Final de Escombros en Sitio Autorizado | 7d | 2023-08-23 | 2023-08-31 | 70SS | 605d |  | 0,00% | 0,00% | 0,00% | 0,00% |
| 72 | 1.5.2.5.2.3 | Acero de Refuerzo | 10d | 2023-08-25 | 2023-09-07 | 70SS+2d | 117d | 0d | 0,00% | 0,00% | 0,00% | 0,00% |
| 73 | 1.5.2.5.2.4 | Concreto | 10d | 2023-08-28 | 2023-09-09 | 72SS+2d | 117d | 0d | 0,00% | 0,00% | 0,00% | 0,00% |
| 74 | 1.5.2.5.3 | Vigas de Cimentación en Concreto | 24d | 2023-09-18 | 2023-10-20 | 73SS+16d | 117d | 0d | 0,00% | 0,00% | 0,00% | 0,00% |
| 75 | 1.5.2.6 | **CIMENTACIÓN PARA ESTACIÓN 20 DE JULIO** | 149d | 2023-08-22 | 2024-03-13 |  | 0d |  | 0,00% | 0,00% | 0,00% | 0,00% |
| 76 | 1.5.2.6.1 | **CONSTRUCCIÓN PILOTES** | 132d | 2023-08-22 | 2024-02-20 |  | 0d |  | 0,00% | 0,00% | 0,00% | 0,00% |
| 77 | 1.5.2.6.1.1 | Excavación para pilotes | 90d | 2023-08-22 | 2023-12-22 | 64 | 0d |  | 0,00% | 0,00% | 0,00% | 0,00% |
| 78 | 1.5.2.6.1.2 | Transporte y Disposición Final de Escombros en Sitio Autorizado | 90d | 2023-08-22 | 2023-12-22 | 77FF | 209d | 166d | 0,00% | 0,00% | 0,00% | 0,00% |
| 79 | 1.5.2.6.1.3 | Acero de Refuerzo | 90d | 2023-08-24 | 2023-12-26 | 77SS+2d | 24d | 0d | 0,00% | 0,00% | 0,00% | 0,00% |
| 80 | 1.5.2.6.1.4 | Concreto | 90d | 2023-08-26 | 2023-12-28 | 79SS+2d | 24d | 0d | 0,00% | 0,00% | 0,00% | 0,00% |
| 81 | 1.5.2.6.1.5 | Descabece de Pilotes | 30d | 2024-01-11 | 2024-02-20 | 80FS+8d | 167d | 124d | 0,00% | 0,00% | 0,00% | 0,00% |

| ID | WBS | Task | Duration | Start | Finish | Predecessors | Total slack | Free slack | % Avance Planeado | % avance planeado en costo (texto) | % Completado (décimales) | % Completado en Costo |
| --- | --- | --- | --- | --- | --- | --- | --- | --- | --- | --- | --- | --- |
| 82 | 1.5.2.6.2 | **CONSTRUCCIÓN DADOS DE CIMENTACIÓN** | 44d | 2023-12-29 | 2024-02-27 |  | 24d |  | 0,00% | 0,00% | 0,00% | 0,00% |
| 83 | 1.5.2.6.2.1 | Excavación para dados | 40d | 2023-12-29 | 2024-02-22 | 80 | 24d | 0d | 0,00% | 0,00% | 0,00% | 0,00% |
| 84 | 1.5.2.6.2.2 | Transporte y Disposición Final de Escombros en Sitio Autorizado | 40d | 2023-12-29 | 2024-02-22 | 83FF | 165d | 122d | 0,00% | 0,00% | 0,00% | 0,00% |
| 85 | 1.5.2.6.2.3 | Acero de Refuerzo | 40d | 2024-01-02 | 2024-02-24 | 83SS+2d | 24d | 0d | 0,00% | 0,00% | 0,00% | 0,00% |
| 86 | 1.5.2.6.2.4 | Concreto | 40d | 2024-01-04 | 2024-02-27 | 85SS+2d | 24d | 0d | 0,00% | 0,00% | 0,00% | 0,00% |
| 87 | 1.5.2.6.3 | Vigas de Cimentación en Concreto | 35d | 2024-01-26 | 2024-03-13 | 86SS+16d | 24d | 0d | 0,00% | 0,00% | 0,00% | 0,00% |
| 88 | 1.5.2.7 | **PUESTA A TIERRA** | 20d | 2024-02-28 | 2024-03-26 |  | 455d |  | 0,00% | 0,00% | 0,00% | 0,00% |
| 89 | 1.5.2.7.1 | Instalación Cable de Cobre | 10d | 2024-02-28 | 2024-03-12 | 86, 73, 61, 134, 157 | 455d | 0d | 0,00% | 0,00% | 0,00% | 0,00% |
| 90 | 1.5.2.7.2 | Varilla COOPER WELD 5/8" x 2.44m. | 10d | 2024-03-12 | 2024-03-26 | 89 | 455d | 197d | 0,00% | 0,00% | 0,00% | 0,00% |
| 91 | 1.5.2.8 | **ESTRUCTURA ESTACIÓN DE TRANSFERENCIA 20 DE JULIO** | 138d | 2024-02-01 | 2024-08-13 |  | 43d | 28d | 0,00% | 0,00% | 0,00% | 0,00% |
| 92 | 1.5.2.8.1 | **ESTRUCTURA MÁSTIL** | 33d | 2024-02-01 | 2024-03-15 |  | 148d |  | 0,00% | 0,00% | 0,00% | 0,00% |
| 93 | 1.5.2.8.1.1 | Acero de Refuerzo Mástil | 31d | 2024-02-01 | 2024-03-13 | 86SS+20d, 73SS+20d | 148d | 0d | 0,00% | 0,00% | 0,00% | 0,00% |
| 94 | 1.5.2.8.1.2 | Concreto para Mástil | 31d | 2024-02-05 | 2024-03-15 | 93SS+2d | 148d | 105d | 0,00% | 0,00% | 0,00% | 0,00% |
| 95 | 1.5.2.8.2 | **ESTRUCTURA PLACA CONTRAPISO NIVEL DE DISPONIBLE / PLANTA BAJA / EQUIPOS** | 26d | 2024-02-10 | 2024-03-15 |  | 43d |  | 0,00% | 0,00% | 0,00% | 0,00% |
| 96 | 1.5.2.8.2.1 | Acero de Refuerzo | 10d | 2024-02-10 | 2024-02-23 | 1021 | 43d | 0d | 0,00% | 0,00% | 0,00% | 0,00% |
| 97 | 1.5.2.8.2.2 | Concreto | 10d | 2024-02-13 | 2024-02-26 | 96SS+2d | 43d | 0d | 0,00% | 0,00% | 0,00% | 0,00% |
| 98 | 1.5.2.8.2.3 | **COLUMNAS DE DISPONIBLE / PLANTA BAJA / EQUIPOS** | 17d | 2024-02-22 | 2024-03-15 |  | 44d |  | 0,00% | 0,00% | 0,00% | 0,00% |
| 99 | 1.5.2.8.2.3.1 | Acero de Refuerzo | 14d | 2024-02-22 | 2024-03-12 | 97SS+7d | 44d | 0d | 0,00% | 0,00% | 0,00% | 0,00% |
| 100 | 1.5.2.8.2.3.2 | Concreto para Columnas | 14d | 2024-02-27 | 2024-03-15 | 99SS+3d | 44d | 1d | 0,00% | 0,00% | 0,00% | 0,00% |
| 101 | 1.5.2.8.3 | **ESTRUCTURA PLACA ENTREPISO MEZANINE** | 47d | 2024-02-27 | 2024-05-02 |  | 43d |  | 0,00% | 0,00% | 0,00% | 0,00% |
| 102 | 1.5.2.8.3.1 | Encofrado y Acero de Refuerzo | 18d | 2024-02-27 | 2024-03-20 | 97, 1021 | 43d | 0d | 0,00% | 0,00% | 0,00% | 0,00% |
| 103 | 1.5.2.8.3.2 | Concreto | 14d | 2024-03-18 | 2024-04-08 | 100, 102FS-3d | 43d | 0d | 0,00% | 0,00% | 0,00% | 0,00% |
| 104 | 1.5.2.8.3.3 | **COLUMNAS DEL MEZANINE HASTA PLACA DE ABORDAJE** | 24d | 2024-04-01 | 2024-05-02 |  | 115d |  | 0,00% | 0,00% | 0,00% | 0,00% |
| 105 | 1.5.2.8.3.3.1 | Encofrado y Acero de Refuerzo | 21d | 2024-04-01 | 2024-04-27 | 103SS+8d | 115d | 0d | 0,00% | 0,00% | 0,00% | 0,00% |
| 106 | 1.5.2.8.3.3.2 | Concreto para Columnas | 19d | 2024-04-08 | 2024-05-02 | 105SS+5d | 115d | 72d | 0,00% | 0,00% | 0,00% | 0,00% |

| ID | WBS | Task | Type | Duration | Start | Finish | Predecessors | Total slack | Free slack | % Avance Planeado | % avance planeado en costo (texto) | % Completado (décimales) | % Completado en Costo |
| --- | --- | --- | --- | --- | --- | --- | --- | --- | --- | --- | --- | --- | --- |
| 107 | 1.5.2.8.4 | **ESTRUCTURA PLACA DE ABORDAJE** |  | 45d | 2024-04-29 | 2024-07-02 |  | 43d |  | 0,00% | 0,00% | 0,00% | 0,00% |
| 108 | 1.5.2.8.4.1 | Encofrado y Acero de Refuerzo |  | 10d | 2024-04-29 | 2024-05-14 | 103FS+15d | 43d | 0d | 0,00% | 0,00% | 0,00% | 0,00% |
| 109 | 1.5.2.8.4.2 | Concreto |  | 7d | 2024-05-14 | 2024-05-22 | 108 | 43d | 0d | 0,00% | 0,00% | 0,00% | 0,00% |
| 110 | 1.5.2.8.4.3 | **COLUMNAS PLATAFORMA DE ABORDAJE A CUBIERTA** |  | 20d | 2024-06-04 | 2024-07-02 |  | 43d |  | 0,00% | 0,00% | 0,00% | 0,00% |
| 111 | 1.5.2.8.4.3.1 | Acero de Refuerzo |  | 15d | 2024-06-04 | 2024-06-25 | 109SS+15d | 43d | 0d | 0,00% | 0,00% | 0,00% | 0,00% |
| 112 | 1.5.2.8.4.3.2 | Concreto para Columnas |  | 15d | 2024-06-12 | 2024-07-02 | 111SS+5d | 43d | 0d | 0,00% | 0,00% | 0,00% | 0,00% |
| 113 | 1.5.2.8.5 | **ESTRUCTURA VIGAS DE CUBIERTA** |  | 17d | 2024-06-25 | 2024-07-18 |  | 43d |  | 0,00% | 0,00% | 0,00% | 0,00% |
| 114 | 1.5.2.8.5.1 | Acero de Refuerzo |  | 12d | 2024-06-25 | 2024-07-11 | 112SS+10d | 43d | 0d | 0,00% | 0,00% | 0,00% | 0,00% |
| 115 | 1.5.2.8.5.2 | Concreto |  | 12d | 2024-07-03 | 2024-07-18 | 114SS+5d | 43d | 0d | 0,00% | 0,00% | 0,00% | 0,00% |
| 116 | 1.5.2.8.6 | **ESCALERAS** |  | 18d | 2024-07-18 | 2024-08-13 |  | 43d |  | 0,00% | 0,00% | 0,00% | 0,00% |
| 117 | 1.5.2.8.6.1 | Acero de Refuerzo |  | 13d | 2024-07-18 | 2024-08-05 | 115 | 43d | 0d | 0,00% | 0,00% | 0,00% | 0,00% |
| 118 | 1.5.2.8.6.2 | Concreto para Escaleras |  | 13d | 2024-07-25 | 2024-08-13 | 117SS+5d | 43d | 0d | 0,00% | 0,00% | 0,00% | 0,00% |
| 119 | 1.5.2.8.7 | **ACERO ESTRUCTURAL** |  | 27d | 2024-06-12 | 2024-07-18 |  | 46d |  | 0,00% | 0,00% | 0,00% | 0,00% |
| 120 | 1.5.2.8.7.1 | **CUBIERTA** |  | 27d | 2024-06-12 | 2024-07-18 |  | 46d |  | 0,00% | 0,00% | 0,00% | 0,00% |
| 121 | 1.5.2.8.7.1.1 | Acero ASTM |  | 27d | 2024-06-12 | 2024-07-18 | 111FS-10d | 46d | 0d | 0,00% | 0,00% | 0,00% | 0,00% |
| 122 | 1.5.2.8.8 | Fin Estructura Estación | milestone | 0d | 2024-08-13 | 2024-08-13 | 121, 118, 54, 59, 65, 68, 78, 84, 81, 94, 106 | 43d | 0d | 0,00% | 0,00% | 0,00% | 0,00% |
| 123 | 1.5.2.9 | **CIMENTACIÓN PUENTE ACCESO A ESTACION DE TRANSFERENCIA 20 DE JULIO** |  | 37d | 2023-12-22 | 2024-02-13 |  | 0d |  | 0,00% | 0,00% | 0,00% | 0,00% |
| 124 | 1.5.2.9.1 | **CIMENTACIÓN PARA PUENTE DE ACCESO** |  | 23d | 2023-12-22 | 2024-01-25 |  | 0d |  | 0,00% | 0,00% | 0,00% | 0,00% |
| 125 | 1.5.2.9.1.1 | Excavación para pilotes |  | 12d | 2023-12-22 | 2024-01-11 | 77 | 0d |  | 0,00% | 0,00% | 0,00% | 0,00% |
| 126 | 1.5.2.9.1.2 | Transporte y Disposición Final de Escombros en Sitio Autorizado |  | 12d | 2023-12-22 | 2024-01-11 | 125FF | 511d | 11d | 0,00% | 0,00% | 0,00% | 0,00% |
| 127 | 1.5.2.9.1.3 | Acero de Refuerzo |  | 12d | 2023-12-22 | 2024-01-11 | 125SS | 16d | 0d | 0,00% | 0,00% | 0,00% | 0,00% |
| 128 | 1.5.2.9.1.4 | Concreto |  | 12d | 2023-12-22 | 2024-01-11 | 127SS | 16d | 0d | 0,00% | 0,00% | 0,00% | 0,00% |
| 129 | 1.5.2.9.1.5 | Descabece de Pilotes |  | 3d | 2024-01-22 | 2024-01-25 | 128FS+8d | 500d | 0d | 0,00% | 0,00% | 0,00% | 0,00% |
| 130 | 1.5.2.9.2 | **CONSTRUCCIÓN DADOS DE CIMENTACIÓN** |  | 8d | 2024-01-11 | 2024-01-22 |  | 16d |  | 0,00% | 0,00% | 0,00% | 0,00% |
| 131 | 1.5.2.9.2.1 | Excavación para dados |  | 4d | 2024-01-11 | 2024-01-16 | 128 | 16d | 0d | 0,00% | 0,00% | 0,00% | 0,00% |
| 132 | 1.5.2.9.2.2 | Transporte y Disposición Final de Escombros en Sitio Autorizado |  | 4d | 2024-01-11 | 2024-01-16 | 131FF | 507d | 7d | 0,00% | 0,00% | 0,00% | 0,00% |
| 133 | 1.5.2.9.2.3 | Acero de Refuerzo |  | 4d | 2024-01-15 | 2024-01-18 | 131SS+2d | 16d | 0d | 0,00% | 0,00% | 0,00% | 0,00% |
| 134 | 1.5.2.9.2.4 | Concreto |  | 4d | 2024-01-17 | 2024-01-22 | 133SS+2d | 16d | 0d | 0,00% | 0,00% | 0,00% | 0,00% |
| 135 | 1.5.2.9.3 | Vigas de Cimentación en Concreto |  | 5d | 2024-02-07 | 2024-02-13 | 134SS+16d | 16d |  | 0,00% | 0,00% | 0,00% | 0,00% |
| 136 | 1.5.2.9.4 | FIN CIMENTACIÓN PUENTE ACCESO A ESTACION DE TRANSFERENCIA 20 DE JULIO | milestone | 0d | 2024-01-25 | 2024-01-25 | 126, 129, 132 | 500d | 242d | 0,00% | 0,00% | 0,00% | 0,00% |

| ID | WBS | Task | Type | Duration | Start | Finish | Predecessors | Total slack | Free slack | % Avance Planeado | % avance planeado en costo (texto) | % Completado (décimales) | % Completado en Costo |
| --- | --- | --- | --- | --- | --- | --- | --- | --- | --- | --- | --- | --- | --- |
| 137 | 1.5.2.10 | **ESTRUCTURA PUENTE DE ACCESO A ESTACION DE TRANSFERENCIA** |  | 67d | 2024-05-06 | 2024-08-08 |  | 46d | 31d | 0,00% | 0,00% | 0,00% | 0,00% |
| 138 | 1.5.2.10.1 | **PEDESTALES PUENTE** |  | 10d | 2024-06-12 | 2024-06-25 |  | 46d |  | 0,00% | 0,00% | 0,00% | 0,00% |
| 139 | 1.5.2.10.1.1 | Acero de Refuerzo |  | 10d | 2024-06-12 | 2024-06-25 | 121SS | 46d | 0d | 0,00% | 0,00% | 0,00% | 0,00% |
| 140 | 1.5.2.10.1.2 | Concreto para pedestal |  | 10d | 2024-06-12 | 2024-06-25 | 139SS | 46d | 0d | 0,00% | 0,00% | 0,00% | 0,00% |
| 141 | 1.5.2.10.2 | **ACERO ESTRUCTURAL** |  | 67d | 2024-05-06 | 2024-08-08 |  | 46d |  | 0,00% | 0,00% | 0,00% | 0,00% |
| 142 | 1.5.2.10.2.1 | Fabricación de Estructura para Puente Peatonal de acceso a Est. Transferencia |  | 35d | 2024-05-06 | 2024-06-25 | 140FF | 78d | 32d | 0,00% | 0,00% | 0,00% | 0,00% |
| 143 | 1.5.2.10.2.2 | Montaje de Estructura en Acero ASTM para Puente |  | 10d | 2024-06-27 | 2024-07-11 | 140FS+2d | 46d | 0d | 0,00% | 0,00% | 0,00% | 0,00% |
| 144 | 1.5.2.10.2.3 | Vestidura de Puente Peatonal |  | 20d | 2024-07-11 | 2024-08-08 | 143 | 46d | 0d | 0,00% | 0,00% | 0,00% | 0,00% |
| 145 | 1.5.2.10.3 | Fin Estructuras Plataforma de Abordaje | milestone | 0d | 2024-08-08 | 2024-08-08 | 144, 142 | 46d | 3d | 0,00% | 0,00% | 0,00% | 0,00% |
| 146 | 1.5.2.11 | **CIMENTACIÓN EDIFICIO DE CONEXIÓN A PLATAFORMA DE ALIMENTADORES** |  | 43d | 2024-01-11 | 2024-03-07 |  | 0d |  | 0,00% | 0,00% | 0,00% | 0,00% |
| 147 | 1.5.2.11.1 | **CIMENTACIÓN PARAEDIFICIO DE CONEXIÓN A PLATAFORMA DE ALIMENTADORES** |  | 29d | 2024-01-11 | 2024-02-19 |  | 0d |  | 0,00% | 0,00% | 0,00% | 0,00% |
| 148 | 1.5.2.11.1.1 | Excavación para pilotes |  | 16d | 2024-01-11 | 2024-02-01 | 125 | 0d |  | 0,00% | 0,00% | 0,00% | 0,00% |
| 149 | 1.5.2.11.1.2 | Transporte y Disposición Final de Escombros en Sitio Autorizado |  | 16d | 2024-01-11 | 2024-02-01 | 148FF | 495d | 13d | 0,00% | 0,00% | 0,00% | 0,00% |
| 150 | 1.5.2.11.1.3 | Acero de Refuerzo |  | 16d | 2024-01-11 | 2024-02-01 | 148SS | 0d |  | 0,00% | 0,00% | 0,00% | 0,00% |
| 151 | 1.5.2.11.1.4 | Concreto |  | 16d | 2024-01-11 | 2024-02-01 | 150SS | 0d |  | 0,00% | 0,00% | 0,00% | 0,00% |
| 152 | 1.5.2.11.1.5 | Descabece de Pilotes |  | 5d | 2024-02-12 | 2024-02-19 | 151FS+8d | 482d | 0d | 0,00% | 0,00% | 0,00% | 0,00% |
| 153 | 1.5.2.11.2 | **CONSTRUCCIÓN DADOS DE CIMENTACIÓN** |  | 10d | 2024-02-01 | 2024-02-14 |  | 0d |  | 0,00% | 0,00% | 0,00% | 0,00% |
| 154 | 1.5.2.11.2.1 | Excavación para dados |  | 6d | 2024-02-01 | 2024-02-08 | 151 | 0d |  | 0,00% | 0,00% | 0,00% | 0,00% |
| 155 | 1.5.2.11.2.2 | Transporte y Disposición Final de Escombros en Sitio Autorizado |  | 6d | 2024-02-01 | 2024-02-08 | 154FF | 489d | 7d | 0,00% | 0,00% | 0,00% | 0,00% |
| 156 | 1.5.2.11.2.3 | Acero de Refuerzo |  | 6d | 2024-02-05 | 2024-02-12 | 154SS+2d | 0d |  | 0,00% | 0,00% | 0,00% | 0,00% |
| 157 | 1.5.2.11.2.4 | Concreto |  | 6d | 2024-02-07 | 2024-02-14 | 156SS+2d | 0d |  | 0,00% | 0,00% | 0,00% | 0,00% |
| 158 | 1.5.2.11.3 | Vigas de Cimentación en Concreto |  | 7d | 2024-02-28 | 2024-03-07 | 157SS+16d | 0d |  | 0,00% | 0,00% | 0,00% | 0,00% |
| 159 | 1.5.2.11.4 | FIN CIMENTACIÓN EDIFICIO DE CONEXIÓN A PLATAFORMA DE ALIMENTADORES | milestone | 0d | 2024-02-19 | 2024-02-19 | 149, 152, 155 | 482d | 224d | 0,00% | 0,00% | 0,00% | 0,00% |
| 160 | 1.5.2.12 | **ESTRUCTURA EDIFICIO DE CONEXIÓN A PLATAFORMA DE ALIMENTADORES** |  | 72d | 2024-04-29 | 2024-08-08 |  | 46d | 31d | 0,00% | 0,00% | 0,00% | 0,00% |
| 161 | 1.5.2.12.1 | **PEDESTALES EDIFICIO DE CONEXIÓN** |  | 10d | 2024-06-12 | 2024-06-25 |  | 46d |  | 0,00% | 0,00% | 0,00% | 0,00% |
| 162 | 1.5.2.12.1.1 | Acero de Refuerzo |  | 10d | 2024-06-12 | 2024-06-25 | 121SS | 46d | 0d | 0,00% | 0,00% | 0,00% | 0,00% |
| 163 | 1.5.2.12.1.2 | Concreto para pedestales |  | 10d | 2024-06-12 | 2024-06-25 | 162SS | 46d | 0d | 0,00% | 0,00% | 0,00% | 0,00% |

| ID | WBS | Task | Type | Duration | Start | Finish | Predecessors | Total slack | Free slack | % Avance Planeado | % avance planeado en costo (texto) | % Completado (décimales) | % Completado en Costo |
| --- | --- | --- | --- | --- | --- | --- | --- | --- | --- | --- | --- | --- | --- |
| 164 | 1.5.2.12.2 | **ACERO ESTRUCTURAL** |  | 72d | 2024-04-29 | 2024-08-08 |  | 46d |  | 0,00% | 0,00% | 0,00% | 0,00% |
| 165 | 1.5.2.12.2.1 | Fabricación de Estructura para Edificio de Conexión |  | 40d | 2024-04-29 | 2024-06-25 | 163FF | 78d | 32d | 0,00% | 0,00% | 0,00% | 0,00% |
| 166 | 1.5.2.12.2.2 | Montaje de Estructura en Acero ASTM para Puente |  | 10d | 2024-06-27 | 2024-07-11 | 163FS+2d | 46d | 0d | 0,00% | 0,00% | 0,00% | 0,00% |
| 167 | 1.5.2.12.2.3 | Vestidura de Edificio de Conexión |  | 20d | 2024-07-11 | 2024-08-08 | 166 | 46d | 0d | 0,00% | 0,00% | 0,00% | 0,00% |
| 168 | 1.5.2.12.3 | Fin Estructuras Plataforma de Abordaje | milestone | 0d | 2024-08-08 | 2024-08-08 | 167, 165 | 46d | 3d | 0,00% | 0,00% | 0,00% | 0,00% |
| 169 | 1.5.2.13 | **SUMINISTRO Y MONTAJE COMPONENTE ELECTROMECÁNICO** |  | 78d | 2024-08-13 | 2024-11-28 |  | 0d |  | 0,00% | 0,00% | 0,00% | 0,00% |
| 170 | 1.5.2.13.1 | Montaje Mecánico |  | 35d | 2024-08-13 | 2024-09-28 | 15SS+60d, 145, 122, 168, 17 | 43d |  | 0,00% | 0,00% | 0,00% | 0,00% |
| 171 | 1.5.2.13.2 | Montaje Eléctrico |  | 28d | 2024-10-21 | 2024-11-28 | 170FS-28d, 211, 210 | 0d |  | 0,00% | 0,00% | 0,00% | 0,00% |
| 172 | 1.5.2.13.3 | Fin Montaje Electromecánico | milestone | 0d | 2024-11-28 | 2024-11-28 | 170, 171 | 0d |  | 0,00% | 0,00% | 0,00% | 0,00% |
| 173 | 1.5.2.14 | **CUBIERTA PARA ESTACIÓN DE TRANSFERENCIA** |  | 28d | 2024-08-13 | 2024-09-19 |  | 258d | 0d | 0,00% | 0,00% | 0,00% | 0,00% |
| 174 | 1.5.2.14.1 | Cubierta Lisa Tipo Sándwich Deck en Aluzinc |  | 28d | 2024-08-13 | 2024-09-19 | 145, 122, 168 | 258d | 0d | 0,00% | 0,00% | 0,00% | 0,00% |
| 175 | 1.5.2.14.2 | Fin Instalación de Cubierta para Plataforma de Abordaje | milestone | 0d | 2024-09-19 | 2024-09-19 | 174 | 258d | 0d | 0,00% | 0,00% | 0,00% | 0,00% |
| 176 | 1.5.2.15 | **REDES HIDRÁULICAS Y SANITARIAS** |  | 169d | 2024-02-28 | 2024-10-21 |  | 306d | 24d | 0,00% | 0,00% | 0,00% | 0,00% |
| 177 | 1.5.2.15.1 | **REDES INTERNAS** |  | 67d | 2024-02-28 | 2024-05-31 |  | 408d |  | 0,00% | 0,00% | 0,00% | 0,00% |
| 178 | 1.5.2.15.1.1 | **PLATAFORMA DE ABORDAJE** |  | 67d | 2024-02-28 | 2024-05-31 |  | 408d |  | 0,00% | 0,00% | 0,00% | 0,00% |
| 179 | 1.5.2.15.1.1.1 | Tubería PVC Sanitaria |  | 62d | 2024-02-28 | 2024-05-24 | 87SS, 74SS, 135SS, 158SS, 1002SS | 408d | 0d | 0,00% | 0,00% | 0,00% | 0,00% |
| 180 | 1.5.2.15.1.1.2 | Tubería PVC RDE |  | 67d | 2024-02-28 | 2024-05-31 | 179SS | 408d | 0d | 0,00% | 0,00% | 0,00% | 0,00% |
| 181 | 1.5.2.15.1.1.3 | Accesorios |  | 62d | 2024-02-28 | 2024-05-24 | 179SS | 413d | 5d | 0,00% | 0,00% | 0,00% | 0,00% |
| 182 | 1.5.2.15.2 | **REDES EXTERNAS** |  | 131d | 2024-04-22 | 2024-10-21 |  | 306d |  | 0,00% | 0,00% | 0,00% | 0,00% |
| 183 | 1.5.2.15.2.1 | **Redes de Acueducto** |  | 29d | 2024-04-22 | 2024-05-31 |  | 408d |  | 0,00% | 0,00% | 0,00% | 0,00% |
| 184 | 1.5.2.15.2.1.1 | Excavación manual para redes |  | 25d | 2024-04-22 | 2024-05-27 | 262 | 408d | 0d | 0,00% | 0,00% | 0,00% | 0,00% |
| 185 | 1.5.2.15.2.1.2 | Instalación de Tubería, incluye accesorios. |  | 25d | 2024-04-24 | 2024-05-29 | 184SS+2d | 408d | 0d | 0,00% | 0,00% | 0,00% | 0,00% |
| 186 | 1.5.2.15.2.1.3 | Rellenos para redes |  | 25d | 2024-04-26 | 2024-05-31 | 185SS+2d | 408d | 150d | 0,00% | 0,00% | 0,00% | 0,00% |
| 187 | 1.5.2.15.2.2 | **Redes de Alcantarillado** |  | 29d | 2024-09-12 | 2024-10-21 |  | 303d |  | 0,00% | 0,00% | 0,00% | 0,00% |
| 188 | 1.5.2.15.2.2.1 | Excavación manual para redes |  | 25d | 2024-09-12 | 2024-10-16 | 270SS | 303d | 0d | 0,00% | 0,00% | 0,00% | 0,00% |
| 189 | 1.5.2.15.2.2.2 | Instalación de Tubería, incluye accesorios. |  | 25d | 2024-09-14 | 2024-10-18 | 188SS+2d | 303d | 0d | 0,00% | 0,00% | 0,00% | 0,00% |
| 190 | 1.5.2.15.2.2.3 | Rellenos para redes |  | 25d | 2024-09-17 | 2024-10-21 | 189SS+2d | 303d | 0d | 0,00% | 0,00% | 0,00% | 0,00% |
| 191 | 1.5.2.15.3 | FIN REDES HIDRÁULICAS Y SANITARIAS | milestone | 0d | 2024-05-31 | 2024-05-31 | 180, 181 | 408d | 150d | 0,00% | 0,00% | 0,00% | 0,00% |

| ID | WBS | Task | Type | Duration | Start | Finish | Predecessors | Total slack | Free slack | % Avance Planeado | % avance planeado en costo (texto) | % Completado (décimales) | % Completado en Costo |
| --- | --- | --- | --- | --- | --- | --- | --- | --- | --- | --- | --- | --- | --- |
| 192 | 1.5.2.16 | **REDES ELÉCTRICAS, VOZ Y DATOS** |  | 182d | 2024-02-09 | 2024-10-19 |  | 14d |  | 0,00% | 0,00% | 0,00% | 0,00% |
| 193 | 1.5.2.16.1 | **REDES INTERNAS** |  | 167d | 2024-02-28 | 2024-10-18 |  | 0d |  | 0,00% | 0,00% | 0,00% | 0,00% |
| 194 | 1.5.2.16.1.1 | **ESTACION Y PLATAFORMA DE ABORDAJE** |  | 167d | 2024-02-28 | 2024-10-18 |  | 0d |  | 0,00% | 0,00% | 0,00% | 0,00% |
| 195 | 1.5.2.16.1.1.1 | Tubería Conduit |  | 138d | 2024-02-28 | 2024-09-09 | 87SS, 74SS, 135SS, 158SS | 0d |  | 0,00% | 0,00% | 0,00% | 0,00% |
| 196 | 1.5.2.16.1.1.2 | Tubería Galvanizada |  | 138d | 2024-02-28 | 2024-09-09 | 195SS | 0d |  | 0,00% | 0,00% | 0,00% | 0,00% |
| 197 | 1.5.2.16.1.1.3 | Accesorios |  | 138d | 2024-02-28 | 2024-09-09 | 195SS, 196SS | 308d | 0d | 0,00% | 0,00% | 0,00% | 0,00% |
| 198 | 1.5.2.16.1.1.4 | Cableado |  | 22d | 2024-09-10 | 2024-10-08 | 197 | 308d | 0d | 0,00% | 0,00% | 0,00% | 0,00% |
| 199 | 1.5.2.16.1.1.5 | Instalación de Aparatos Electricos |  | 7d | 2024-10-08 | 2024-10-18 | 198 | 308d | 0d | 0,00% | 0,00% | 0,00% | 0,00% |
| 200 | 1.5.2.16.2 | **APANTALLAMIENTO** |  | 28d | 2024-08-13 | 2024-09-19 |  | 329d |  | 0,00% | 0,00% | 0,00% | 0,00% |
| 201 | 1.5.2.16.2.1 | Pararrayos Tipo Punta De Franklin |  | 28d | 2024-08-13 | 2024-09-19 | 175FF | 329d | 0d | 0,00% | 0,00% | 0,00% | 0,00% |
| 202 | 1.5.2.16.2.2 | Cable De Cobre Desnudo |  | 28d | 2024-08-13 | 2024-09-19 | 201SS | 329d | 21d | 0,00% | 0,00% | 0,00% | 0,00% |
| 203 | 1.5.2.16.3 | **REDES EXTERNAS** |  | 182d | 2024-02-09 | 2024-10-19 |  | 62d |  | 0,00% | 0,00% | 0,00% | 0,00% |
| 204 | 1.5.2.16.3.1 | **ILUMINACIÓN EXTERIOR** |  | 100d | 2024-04-22 | 2024-09-09 |  | 29d |  | 0,00% | 0,00% | 0,00% | 0,00% |
| 205 | 1.5.2.16.3.1.1 | Tubería Eléctrica PVC |  | 71d | 2024-04-22 | 2024-07-30 | 262 | 29d | 0d | 0,00% | 0,00% | 0,00% | 0,00% |
| 206 | 1.5.2.16.3.1.2 | Accesorios |  | 71d | 2024-04-22 | 2024-07-30 | 205SS | 337d | 0d | 0,00% | 0,00% | 0,00% | 0,00% |
| 207 | 1.5.2.16.3.1.3 | Cableado |  | 22d | 2024-07-31 | 2024-08-30 | 206 | 337d | 0d | 0,00% | 0,00% | 0,00% | 0,00% |
| 208 | 1.5.2.16.3.1.4 | Instalación de A.P. |  | 7d | 2024-08-30 | 2024-09-09 | 207 | 337d | 29d | 0,00% | 0,00% | 0,00% | 0,00% |
| 209 | 1.5.2.16.3.2 | **SISTEMA DE ALIMENTACIÓN Y POTENCIA** |  | 182d | 2024-02-09 | 2024-10-19 |  | 0d |  | 0,00% | 0,00% | 0,00% | 0,00% |
| 210 | 1.5.2.16.3.2.1 | Suministro Subestación Eléctrica |  | 90d | 2024-02-09 | 2024-06-14 | 49FS+150d | 62d |  | 0,00% | 0,00% | 0,00% | 0,00% |
| 211 | 1.5.2.16.3.2.2 | Montaje de Subestación Eléctrica |  | 30d | 2024-09-10 | 2024-10-19 | 210, 242, 196, 205 | 0d |  | 0,00% | 0,00% | 0,00% | 0,00% |
| 212 | 1.5.2.16.4 | FIN REDES ELÉCTRICAS, VOZ Y DATOS | milestone | 0d | 2024-10-18 | 2024-10-18 | 199, 202, 208 | 308d | 50d | 0,00% | 0,00% | 0,00% | 0,00% |
| 213 | 1.5.2.17 | **ELEVADORES: ESTACION Y PUENTE PEATONAL** |  | 352d | 2023-08-25 | 2024-12-26 |  | 258d | 0d | 0,00% | 0,00% | 0,00% | 0,00% |
| 214 | 1.5.2.17.1 | Fabricación, Importación, Transporte y Nacionalización |  | 150d | 2023-08-25 | 2024-03-18 | 2FS+167d | 361d | 100d | 0,00% | 0,00% | 0,00% | 0,00% |
| 215 | 1.5.2.17.2 | Obras Civiles y Trabajos Preparatorios |  | 3d | 2024-08-08 | 2024-08-13 | 214, 145FF, 122FF, 168FF | 261d | 0d | 0,00% | 0,00% | 0,00% | 0,00% |
| 216 | 1.5.2.17.3 | Toma de las Medidas del Pozo. Estudio y Análisis de las Medidas. Organización de Almacén y Traslado de Materiales |  | 5d | 2024-08-05 | 2024-08-13 | 215FF | 261d | 3d | 0,00% | 0,00% | 0,00% | 0,00% |
| 217 | 1.5.2.17.4 | Izaje de Guías de Carro y CWT. Instalación de Brackets y Primer Tramo de Guías. Instalación de Amortiguadores y Elementos de PIT |  | 25d | 2024-08-16 | 2024-09-19 | 216, 175FF, 145, 122, 168 | 258d | 0d | 0,00% | 0,00% | 0,00% | 0,00% |
| 218 | 1.5.2.17.5 | Ensamble de Chasis de Cabina, CWT, Armado de Cabina e Izaje de Última Parada, Puesta en MSK |  | 10d | 2024-09-19 | 2024-10-02 | 217 | 258d | 0d | 0,00% | 0,00% | 0,00% | 0,00% |
| 219 | 1.5.2.17.6 | Instalación de Soportes de Guías, Rectificación y Alineación |  | 13d | 2024-10-03 | 2024-10-21 | 218 | 258d | 0d | 0,00% | 0,00% | 0,00% | 0,00% |
| 220 | 1.5.2.17.7 | Ensamble e Instalación de los Marcos y Puertas de Entrada de Piso |  | 13d | 2024-10-22 | 2024-11-08 | 219 | 258d | 0d | 0,00% | 0,00% | 0,00% | 0,00% |
| 221 | 1.5.2.17.8 | Elaboración de Remates Frontales y Acabados de los Mismos, Instalación de Cajas para Botoneras e Indicadores. |  | 15d | 2024-10-22 | 2024-11-12 | 220SS | 258d | 0d | 0,00% | 0,00% | 0,00% | 0,00% |
| 222 | 1.5.2.17.9 | Instalación de Cableado de Pozo y Botoneras, Conexiones e Instalación de Cable Viajero |  | 13d | 2024-11-13 | 2024-11-29 | 221, 211, 210 | 258d | 0d | 0,00% | 0,00% | 0,00% | 0,00% |
| 223 | 1.5.2.17.10 | Ensamble de Cabina, Instalación de Accesorios y Conexiones |  | 10d | 2024-11-29 | 2024-12-12 | 222 | 258d | 0d | 0,00% | 0,00% | 0,00% | 0,00% |
| 224 | 1.5.2.17.11 | Inspeccion Mecánica y de Calidad |  | 3d | 2024-12-12 | 2024-12-17 | 223 | 258d | 0d | 0,00% | 0,00% | 0,00% | 0,00% |
| 225 | 1.5.2.17.12 | Ajuste y Configuración |  | 7d | 2024-12-12 | 2024-12-21 | 224SS | 258d | 0d | 0,00% | 0,00% | 0,00% | 0,00% |
| 226 | 1.5.2.17.13 | Certificación NTC 5926-1 |  | 3d | 2024-12-23 | 2024-12-26 | 225 | 258d | 0d | 0,00% | 0,00% | 0,00% | 0,00% |
| 227 | 1.5.2.17.14 | Protocolos, Limpieza, Entrega |  | 3d | 2024-12-23 | 2024-12-26 | 225 | 258d | 0d | 0,00% | 0,00% | 0,00% | 0,00% |
| 228 | 1.5.2.17.15 | Fin de Fabricación, Instlación de Elevador | milestone | 0d | 2024-12-26 | 2024-12-26 | 227, 226 | 258d | 0d | 0,00% | 0,00% | 0,00% | 0,00% |

| ID | WBS | Task | Type | Duration | Start | Finish | Predecessors | Total slack | Free slack | % Avance Planeado | % avance planeado en costo (texto) | % Completado (décimales) | % Completado en Costo |
| --- | --- | --- | --- | --- | --- | --- | --- | --- | --- | --- | --- | --- | --- |
| 229 | 1.5.2.18 | **MAMPOSTERÍA, PAÑETES Y ACABADOS** |  | 93d | 2024-06-12 | 2024-10-17 |  | 224d | 51d | 0,00% | 0,00% | 0,00% | 0,00% |
| 230 | 1.5.2.18.1 | **PLATAFORMA DE ABORDAJE** |  | 40d | 2024-06-12 | 2024-08-05 |  | 224d |  | 0,00% | 0,00% | 0,00% | 0,00% |
| 231 | 1.5.2.18.1.1 | Mampostería en Bloque de Concreto 15X20X40 de Dos Perforaciones |  | 40d | 2024-06-12 | 2024-08-05 | 140SS, 112SS, 163SS | 224d | 0d | 0,00% | 0,00% | 0,00% | 0,00% |
| 232 | 1.5.2.18.2 | PAÑETES, ESTUCO, PINTURA Y ENCHAPES |  | 53d | 2024-08-05 | 2024-10-17 | 231 | 264d | 0d | 0,00% | 0,00% | 0,00% | 0,00% |
| 233 | 1.5.2.19 | **ACCESORIOS Y ADECUACIÓN** |  | 27d | 2024-10-17 | 2024-11-25 |  | 264d | 24d | 0,00% | 0,00% | 0,00% | 0,00% |
| 234 | 1.5.2.19.1 | Sanitarios |  | 27d | 2024-10-17 | 2024-11-25 | 232 | 282d | 24d | 0,00% | 0,00% | 0,00% | 0,00% |
| 235 | 1.5.2.19.2 | Lavamanos |  | 27d | 2024-10-17 | 2024-11-25 | 232 | 264d | 0d | 0,00% | 0,00% | 0,00% | 0,00% |
| 236 | 1.5.2.19.3 | Gabinetes |  | 27d | 2024-10-17 | 2024-11-25 | 232 | 282d | 24d | 0,00% | 0,00% | 0,00% | 0,00% |
| 237 | 1.5.2.19.4 | Mesones |  | 27d | 2024-10-17 | 2024-11-25 | 232 | 282d | 24d | 0,00% | 0,00% | 0,00% | 0,00% |
| 238 | 1.5.2.20 | **PISOS** |  | 89d | 2024-02-27 | 2024-07-02 |  | 50d |  | 0,00% | 0,00% | 0,00% | 0,00% |
| 239 | 1.5.2.20.1 | Piso en Concreto de 3.000 PSI |  | 89d | 2024-02-27 | 2024-07-02 | 97 | 50d | 0d | 0,00% | 0,00% | 0,00% | 0,00% |
| 240 | 1.5.2.20.2 | Baldosa en Granito Pulido |  | 89d | 2024-02-27 | 2024-07-02 | 239SS | 50d | 0d | 0,00% | 0,00% | 0,00% | 0,00% |
| 241 | 1.5.2.20.3 | Piso en Granito |  | 89d | 2024-02-27 | 2024-07-02 | 239SS | 50d | 0d | 0,00% | 0,00% | 0,00% | 0,00% |
| 242 | 1.5.2.20.4 | Fin Pisos | milestone | 0d | 2024-07-02 | 2024-07-02 | 239, 240, 241 | 50d |  | 0,00% | 0,00% | 0,00% | 0,00% |
| 243 | 1.5.2.21 | **EQUIPOS ESPECIALES** |  | 27d | 2024-10-17 | 2024-11-25 |  | 282d | 0d | 0,00% | 0,00% | 0,00% | 0,00% |
| 244 | 1.5.2.21.1 | Sistema de Aire Acondicionado |  | 27d | 2024-10-17 | 2024-11-25 | 232 | 282d | 0d | 0,00% | 0,00% | 0,00% | 0,00% |
| 245 | 1.5.2.21.2 | Insonorización Espacios |  | 27d | 2024-10-17 | 2024-11-25 | 244SS | 282d | 24d | 0,00% | 0,00% | 0,00% | 0,00% |
| 246 | 1.5.2.22 | **CARPINTERÍA METÁLICA** |  | 123d | 2024-07-03 | 2024-12-18 |  | 264d | 6d | 0,00% | 0,00% | 0,00% | 0,00% |
| 247 | 1.5.2.22.1 | Ventanas en Aluminio |  | 27d | 2024-10-05 | 2024-11-13 | 232SS+45d | 290d | 32d | 0,00% | 0,00% | 0,00% | 0,00% |
| 248 | 1.5.2.22.2 | Cerramiento en Vidrio |  | 27d | 2024-07-03 | 2024-08-08 | 240 | 360d | 102d | 0,00% | 0,00% | 0,00% | 0,00% |
| 249 | 1.5.2.22.3 | Puertas |  | 27d | 2024-10-05 | 2024-11-13 | 232SS+45d | 290d | 32d | 0,00% | 0,00% | 0,00% | 0,00% |
| 250 | 1.5.2.22.4 | Pasamanos |  | 18d | 2024-10-17 | 2024-11-12 | 232 | 291d | 33d | 0,00% | 0,00% | 0,00% | 0,00% |
| 251 | 1.5.2.22.5 | Divisiones |  | 18d | 2024-11-25 | 2024-12-18 | 235 | 264d | 6d | 0,00% | 0,00% | 0,00% | 0,00% |
| 252 | 1.5.2.23 | **FACHADAS** |  | 67d | 2024-06-12 | 2024-09-11 |  | 224d | 77d | 0,00% | 0,00% | 0,00% | 0,00% |
| 253 | 1.5.2.23.1 | Estructura Metálica |  | 36d | 2024-06-12 | 2024-07-30 | 231SS | 224d | 0d | 0,00% | 0,00% | 0,00% | 0,00% |
| 254 | 1.5.2.23.2 | Panel Fachada Flotante |  | 31d | 2024-07-31 | 2024-09-11 | 253 | 224d | 0d | 0,00% | 0,00% | 0,00% | 0,00% |

| ID | WBS | Task | Type | Duration | Start | Finish | Predecessors | Total slack | Free slack | % Avance Planeado | % avance planeado en costo (texto) | % Completado (décimales) | % Completado en Costo |
| --- | --- | --- | --- | --- | --- | --- | --- | --- | --- | --- | --- | --- | --- |
| 255 | 1.5.2.24 | **RED CONTRA INCENDIOS** |  | 45d | 2024-08-05 | 2024-10-04 |  | 317d | 35d | 0,00% | 0,00% | 0,00% | 0,00% |
| 256 | 1.5.2.24.1 | Tubería |  | 18d | 2024-08-05 | 2024-08-30 | 232SS | 317d | 0d | 0,00% | 0,00% | 0,00% | 0,00% |
| 257 | 1.5.2.24.2 | Cableado |  | 15d | 2024-08-09 | 2024-08-30 | 256SS+3d | 317d | 0d | 0,00% | 0,00% | 0,00% | 0,00% |
| 258 | 1.5.2.24.3 | Bombas |  | 9d | 2024-08-30 | 2024-09-11 | 257 | 317d | 0d | 0,00% | 0,00% | 0,00% | 0,00% |
| 259 | 1.5.2.24.4 | Sensores y accesorios |  | 9d | 2024-09-12 | 2024-09-24 | 258, 257 | 317d | 0d | 0,00% | 0,00% | 0,00% | 0,00% |
| 260 | 1.5.2.24.5 | Pruebas |  | 9d | 2024-09-24 | 2024-10-04 | 259 | 317d | 59d | 0,00% | 0,00% | 0,00% | 0,00% |
| 261 | 1.5.2.25 | **URBANISMO Y ESPACIO PÚBLICO** |  | 81d | 2024-03-13 | 2024-07-08 |  | 29d |  | 0,00% | 0,00% | 0,00% | 0,00% |
| 262 | 1.5.2.25.1 | Rellenos y Bases |  | 27d | 2024-03-13 | 2024-04-22 | 87, 74, 135, 158 | 29d | 0d | 0,00% | 0,00% | 0,00% | 0,00% |
| 263 | 1.5.2.25.2 | Áreas en adoquín y concreto estampado |  | 36d | 2024-04-22 | 2024-06-12 | 262 | 272d | 0d | 0,00% | 0,00% | 0,00% | 0,00% |
| 264 | 1.5.2.25.3 | Áreas en Gramoquin |  | 36d | 2024-04-22 | 2024-06-12 | 262 | 345d | 0d | 0,00% | 0,00% | 0,00% | 0,00% |
| 265 | 1.5.2.25.4 | Mobiliario Urbano |  | 18d | 2024-06-13 | 2024-07-08 | 263 | 272d | 48d | 0,00% | 0,00% | 0,00% | 0,00% |
| 266 | 1.5.2.26 | **PAISAJISMO** |  | 56d | 2024-06-13 | 2024-08-29 |  | 345d | 42d | 0,00% | 0,00% | 0,00% | 0,00% |
| 267 | 1.5.2.26.1 | Plantación de especies nativas |  | 56d | 2024-06-13 | 2024-08-29 | 264 | 345d | 0d | 0,00% | 0,00% | 0,00% | 0,00% |
| 268 | 1.5.2.26.2 | Colocación Grama |  | 56d | 2024-06-13 | 2024-08-29 | 267SS | 345d | 87d | 0,00% | 0,00% | 0,00% | 0,00% |
| 269 | 1.5.2.27 | **PAVIMENTOS** |  | 32d | 2024-09-12 | 2024-10-24 |  | 224d | 0d | 0,00% | 0,00% | 0,00% | 0,00% |
| 270 | 1.5.2.27.1 | Demoliciones y excavaciones |  | 24d | 2024-09-12 | 2024-10-15 | 265, 254 | 224d | 0d | 0,00% | 0,00% | 0,00% | 0,00% |
| 271 | 1.5.2.27.2 | Estructura de vía |  | 24d | 2024-09-18 | 2024-10-21 | 270SS+5d | 303d | 0d | 0,00% | 0,00% | 0,00% | 0,00% |
| 272 | 1.5.2.27.3 | Capa de Rodadura |  | 10d | 2024-10-10 | 2024-10-24 | 271FF+3d, 190FF+3d | 303d | 0d | 0,00% | 0,00% | 0,00% | 0,00% |
| 273 | 1.5.2.27.4 | Fin Pavimentos | milestone | 0d | 2024-10-24 | 2024-10-24 | 272 | 303d | 45d | 0,00% | 0,00% | 0,00% | 0,00% |
| 274 | 1.5.2.28 | Fin Estación 20 de Julio | milestone | 0d | 2024-12-26 | 2024-12-26 | 56, 87, 90, 172, 175, 186, 211, 228, 231, 232, 237, 241, 245, 251, 254, 260, 265, 268, 74, 210, 145, 135, 122, 158, 168, 234, 236, 273, 212, 136, 159, 191, 247, 248, 249, 250, 1002 | 258d |  | 0,00% | 0,00% | 0,00% | 0,00% |
| 275 | 1.5.2.29 | Estación 20 de Julio: Hito de Aprobación Para Pago Preliminares y Cimentación | milestone | 0d | 2024-03-13 | 2024-03-13 | 51, 55, 57, 60, 62, 75, 123, 146 | 464d |  | 0,00% | 0,00% | 0,00% | 0,00% |
| 276 | 1.5.2.30 | Estación 20 de Julio: Hito de Aprobación Para Pago Superestructura | milestone | 0d | 2024-09-19 | 2024-09-19 | 91, 137, 160, 173 | 329d |  | 0,00% | 0,00% | 0,00% | 0,00% |
| 277 | 1.5.2.31 | Estación 20 de Julio: Hito de Aprobación Para Pago Arquitectura, Acabados y Elevadores | milestone | 0d | 2024-12-26 | 2024-12-26 | 213, 229, 233, 238, 246, 252 | 258d |  | 0,00% | 0,00% | 0,00% | 0,00% |
| 278 | 1.5.2.32 | Estación 20 de Julio: Hito de Aprobación Para Pago Redes | milestone | 0d | 2024-11-25 | 2024-11-25 | 176, 192, 243, 255 | 282d |  | 0,00% | 0,00% | 0,00% | 0,00% |
| 279 | 1.5.2.33 | Estación 20 de Julio: Hito de Aprobación Para Pago Urbanismo, Paisajismo y Pavimentos | milestone | 0d | 2024-10-24 | 2024-10-24 | 261, 266, 269 | 303d |  | 0,00% | 0,00% | 0,00% | 0,00% |
| 280 | 1.5.2.34 | Estación 20 de Julio: Hito de Aprobación Para Pago Componente Electromecánico | milestone | 0d | 2024-11-28 | 2024-11-28 | 169 | 279d |  | 0,00% | 0,00% | 0,00% | 0,00% |
| 281 | 1.5.3 | Entrega de predios por parte de IDU al constructor (Predio Transmilenio S A) | milestone | 0d | 2023-07-13 | 2023-07-13 | 47 | 630d | 0d | 0,00% | 0,00% | 0,00% | 0,00% |

| ID | WBS | Task | Type | Duration | Start | Finish | Predecessors | Total slack | Free slack | % Avance Planeado | % avance planeado en costo (texto) | % Completado (décimales) | % Completado en Costo |
| --- | --- | --- | --- | --- | --- | --- | --- | --- | --- | --- | --- | --- | --- |
| 282 | 1.5.4 | **PERMISOS** |  | 0d | 2023-07-13 | 2023-07-13 |  | 630d |  | 0,00% | 0,00% | 0,00% | 0,00% |
| 283 | 1.5.4.1 | Trabajo Nocturno | milestone | 0d | 2023-07-13 | 2023-07-13 | 281 | 630d | 137d | 0,00% | 0,00% | 0,00% | 0,00% |
| 284 | 1.5.4.2 | Silviculturales | milestone | 0d | 2023-07-13 | 2023-07-13 | 281 | 630d | 137d | 0,00% | 0,00% | 0,00% | 0,00% |
| 285 | 1.5.4.3 | PMT | milestone | 0d | 2023-07-13 | 2023-07-13 | 281 | 630d | 137d | 0,00% | 0,00% | 0,00% | 0,00% |
| 286 | 1.5.5 | **TORRE 1** |  | 85d | 2024-01-23 | 2024-05-20 |  | 126d |  | 0,00% | 0,00% | 0,00% | 0,00% |
| 287 | 1.5.5.1 | **PRELIMINARES DE OBRA, MOVIMIENTO DE TIERRAS Y RELLENOS** |  | 2d | 2024-01-23 | 2024-01-25 |  | 493d | 36d | 0,00% | 0,00% | 0,00% | 0,00% |
| 288 | 1.5.5.1.1 | Replanteo General |  | 2d | 2024-01-23 | 2024-01-25 | 281, 283, 284, 285, 125FS-7d, 148FS-7d | 493d | 0d | 0,00% | 0,00% | 0,00% | 0,00% |
| 289 | 1.5.5.1.2 | Cerramiento y Señalización |  | 2d | 2024-01-23 | 2024-01-25 | 288SS | 500d | 7d | 0,00% | 0,00% | 0,00% | 0,00% |
| 290 | 1.5.5.1.3 | Tala de Especies |  | 2d | 2024-01-23 | 2024-01-25 | 288SS | 500d | 7d | 0,00% | 0,00% | 0,00% | 0,00% |
| 291 | 1.5.5.2 | **MOVIMIENTO DE TIERRAS** |  | 7d | 2024-01-25 | 2024-02-03 |  | 493d | 29d | 0,00% | 0,00% | 0,00% | 0,00% |
| 292 | 1.5.5.2.1 | Excavación Mecánica En Material Común |  | 5d | 2024-01-25 | 2024-02-01 | 288 | 493d | 0d | 0,00% | 0,00% | 0,00% | 0,00% |
| 293 | 1.5.5.2.2 | Nivelación y Compactación de Subrasante |  | 2d | 2024-02-01 | 2024-02-03 | 292 | 493d | 0d | 0,00% | 0,00% | 0,00% | 0,00% |
| 294 | 1.5.5.2.3 | Transporte y Disposición Final de Escombros en Sitio Autorizado |  | 5d | 2024-01-25 | 2024-02-01 | 292SS | 495d | 2d | 0,00% | 0,00% | 0,00% | 0,00% |
| 295 | 1.5.5.3 | **CIMENTACIÓN** |  | 25d | 2024-02-01 | 2024-03-05 |  | 119d | 6d | 0,00% | 0,00% | 0,00% | 0,00% |
| 296 | 1.5.5.3.1 | **CONSTRUCCIÓN PILOTES** |  | 7d | 2024-02-01 | 2024-02-09 |  | 119d |  | 0,00% | 0,00% | 0,00% | 0,00% |
| 297 | 1.5.5.3.1.1 | Excavación para Pilotes |  | 5d | 2024-02-01 | 2024-02-07 | 125, 148 | 119d | 0d | 0,00% | 0,00% | 0,00% | 0,00% |
| 298 | 1.5.5.3.1.2 | Acero de Refuerzo |  | 3d | 2024-02-06 | 2024-02-08 | 297FS-2d | 126d | 0d | 0,00% | 0,00% | 0,00% | 0,00% |
| 299 | 1.5.5.3.1.3 | Concreto |  | 3d | 2024-02-07 | 2024-02-09 | 298FS-2d | 126d | 0d | 0,00% | 0,00% | 0,00% | 0,00% |
| 300 | 1.5.5.3.2 | Descabece de Pilotes |  | 2d | 2024-02-10 | 2024-02-13 | 299 | 126d | 0d | 0,00% | 0,00% | 0,00% | 0,00% |
| 301 | 1.5.5.3.3 | **CONSTRUCCIÓN DADOS DE CIMENTACIÓN** |  | 6d | 2024-02-13 | 2024-02-21 |  | 126d |  | 0,00% | 0,00% | 0,00% | 0,00% |
| 302 | 1.5.5.3.3.1 | Acero de Refuerzo |  | 3d | 2024-02-13 | 2024-02-16 | 300 | 126d | 0d | 0,00% | 0,00% | 0,00% | 0,00% |
| 303 | 1.5.5.3.3.2 | Concreto |  | 3d | 2024-02-16 | 2024-02-21 | 302 | 126d | 0d | 0,00% | 0,00% | 0,00% | 0,00% |
| 304 | 1.5.5.3.4 | **PEDESTAL** |  | 10d | 2024-02-21 | 2024-03-05 |  | 126d |  | 0,00% | 0,00% | 0,00% | 0,00% |
| 305 | 1.5.5.3.4.1 | Acero de Refuerzo |  | 5d | 2024-02-21 | 2024-02-27 | 303 | 126d | 0d | 0,00% | 0,00% | 0,00% | 0,00% |
| 306 | 1.5.5.3.4.2 | Concreto |  | 5d | 2024-02-28 | 2024-03-05 | 305 | 126d | 0d | 0,00% | 0,00% | 0,00% | 0,00% |

| ID | WBS | Task | Type | Duration | Start | Finish | Predecessors | Total slack | Free slack | % Avance Planeado | % avance planeado en costo (texto) | % Completado (décimales) | % Completado en Costo |
| --- | --- | --- | --- | --- | --- | --- | --- | --- | --- | --- | --- | --- | --- |
| 307 | 1.5.5.4 | **RELLENOS** |  | 6d | 2024-03-05 | 2024-03-13 |  | 417d | 0d | 0,00% | 0,00% | 0,00% | 0,00% |
| 308 | 1.5.5.4.1 | Relleno de Material Seleccionado |  | 6d | 2024-03-05 | 2024-03-13 | 306 | 417d | 0d | 0,00% | 0,00% | 0,00% | 0,00% |
| 309 | 1.5.5.5 | **PUESTA A TIERRA** |  | 2d | 2024-03-13 | 2024-03-15 |  | 417d | 45d | 0,00% | 0,00% | 0,00% | 0,00% |
| 310 | 1.5.5.5.1 | Instalación Cable de Cobre |  | 1d | 2024-03-13 | 2024-03-14 | 308 | 417d | 0d | 0,00% | 0,00% | 0,00% | 0,00% |
| 311 | 1.5.5.5.2 | Varilla COOPER WELD 5/8" x 2.44m. |  | 1d | 2024-03-14 | 2024-03-15 | 310 | 417d | 0d | 0,00% | 0,00% | 0,00% | 0,00% |
| 312 | 1.5.5.5.3 | Fin Puesta a Tierra | milestone | 0d | 2024-03-15 | 2024-03-15 | 310, 311 | 417d | 0d | 0,00% | 0,00% | 0,00% | 0,00% |
| 313 | 1.5.5.6 | **MONTAJE ELECTROMECÁNICO** |  | 10d | 2024-03-05 | 2024-03-18 |  | 126d | 0d | 0,00% | 0,00% | 0,00% | 0,00% |
| 314 | 1.5.5.6.1 | Montaje Mecánico |  | 5d | 2024-03-05 | 2024-03-12 | 15SS+80d, 306 | 126d | 0d | 0,00% | 0,00% | 0,00% | 0,00% |
| 315 | 1.5.5.6.2 | Montaje Eléctrico |  | 5d | 2024-03-12 | 2024-03-18 | 314 | 460d | 0d | 0,00% | 0,00% | 0,00% | 0,00% |
| 316 | 1.5.5.6.3 | Fin montaje Electromecánico | milestone | 0d | 2024-03-18 | 2024-03-18 | 314, 315 | 460d |  | 0,00% | 0,00% | 0,00% | 0,00% |
| 317 | 1.5.5.7 | **CERTIFICACIONES RETIE Y RETILAP** |  | 45d | 2024-03-15 | 2024-05-20 |  | 417d | 0d | 0,00% | 0,00% | 0,00% | 0,00% |
| 318 | 1.5.5.7.1 | Certificación RETIE |  | 45d | 2024-03-15 | 2024-05-20 | 312 | 417d | 0d | 0,00% | 0,00% | 0,00% | 0,00% |
| 319 | 1.5.5.7.2 | Certificación RETILAP |  | 45d | 2024-03-15 | 2024-05-20 | 318SS | 417d | 0d | 0,00% | 0,00% | 0,00% | 0,00% |
| 320 | 1.5.5.7.3 | Fin Certificaciones RETIE Y RETILAP | milestone | 0d | 2024-05-20 | 2024-05-20 | 319 | 417d |  | 0,00% | 0,00% | 0,00% | 0,00% |
| 321 | 1.5.5.8 | FIN TORRE 1 | milestone | 0d | 2024-02-03 | 2024-02-03 | 289, 290, 293, 294 | 493d |  | 0,00% | 0,00% | 0,00% | 0,00% |
| 322 | 1.5.5.9 | Torre 1: Hito de Aprobación Para Pago Preliminares y Cimentación | milestone | 0d | 2024-03-13 | 2024-03-13 | 287, 291, 295, 307 | 464d |  | 0,00% | 0,00% | 0,00% | 0,00% |
| 323 | 1.5.5.10 | Torre 1: Hito de Aprobación Para Pago Redes | milestone | 0d | 2024-05-20 | 2024-05-20 | 317, 309 | 417d |  | 0,00% | 0,00% | 0,00% | 0,00% |
| 324 | 1.5.5.11 | Torre 1: Hito de Aprobación Para Pago Electromecánico | milestone | 0d | 2024-03-18 | 2024-03-18 | 313 | 460d |  | 0,00% | 0,00% | 0,00% | 0,00% |
| 325 | 1.5.6 | Entrega de predios por parte de IDU al constructor (Predio Transmilenio SA) | milestone | 0d | 2023-07-13 | 2023-07-13 | 47 | 469d | 0d | 0,00% | 0,00% | 0,00% | 0,00% |
| 326 | 1.5.7 | **PERMISOS** |  | 0d | 2023-07-13 | 2023-07-13 |  | 639d |  | 0,00% | 0,00% | 0,00% | 0,00% |
| 327 | 1.5.7.1 | Trabajo Nocturno | milestone | 0d | 2023-07-13 | 2023-07-13 | 325 | 639d |  | 0,00% | 0,00% | 0,00% | 0,00% |
| 328 | 1.5.7.2 | E.S.P. Energía | milestone | 0d | 2023-07-13 | 2023-07-13 | 325 | 639d |  | 0,00% | 0,00% | 0,00% | 0,00% |
| 329 | 1.5.7.3 | Coordinación Operación TRANSMILENIO | milestone | 0d | 2023-07-13 | 2023-07-13 | 325 | 639d |  | 0,00% | 0,00% | 0,00% | 0,00% |
| 330 | 1.5.8 | **TORRE 2** |  | 157d | 2023-11-01 | 2024-06-11 |  | 189d |  | 0,00% | 0,00% | 0,00% | 0,00% |
| 331 | 1.5.8.1 | TRASLADO DE REDES |  | 45d | 2023-11-01 | 2024-01-05 | 5, 325FS+80d | 469d | 0d | 0,00% | 0,00% | 0,00% | 0,00% |

| ID | WBS | Task | Type | Duration | Start | Finish | Predecessors | Total slack | Free slack | % Avance Planeado | % avance planeado en costo (texto) | % Completado (décimales) | % Completado en Costo |
| --- | --- | --- | --- | --- | --- | --- | --- | --- | --- | --- | --- | --- | --- |
| 332 | 1.5.8.2 | **PRELIMINARES DE OBRA, MOVIMIENTO DE TIERRAS Y RELLENOS** |  | 4d | 2024-01-05 | 2024-01-12 |  | 505d | 52d | 0,00% | 0,00% | 0,00% | 0,00% |
| 333 | 1.5.8.2.1 | Replanteo General |  | 2d | 2024-01-05 | 2024-01-10 | 331 | 505d | 0d | 0,00% | 0,00% | 0,00% | 0,00% |
| 334 | 1.5.8.2.2 | Cerramiento y Señalización |  | 2d | 2024-01-10 | 2024-01-12 | 333 | 510d | 5d | 0,00% | 0,00% | 0,00% | 0,00% |
| 335 | 1.5.8.2.3 | Tala de Especies |  | 2d | 2024-01-10 | 2024-01-12 | 333 | 510d | 5d | 0,00% | 0,00% | 0,00% | 0,00% |
| 336 | 1.5.8.3 | **MOVIMIENTO DE TIERRAS** |  | 7d | 2024-01-10 | 2024-01-18 |  | 505d | 47d | 0,00% | 0,00% | 0,00% | 0,00% |
| 337 | 1.5.8.3.1 | Excavación Mecánica En Material Común |  | 5d | 2024-01-10 | 2024-01-16 | 333 | 505d | 0d | 0,00% | 0,00% | 0,00% | 0,00% |
| 338 | 1.5.8.3.2 | Nivelación y Compactación de Subrasante |  | 2d | 2024-01-17 | 2024-01-18 | 337 | 505d | 0d | 0,00% | 0,00% | 0,00% | 0,00% |
| 339 | 1.5.8.3.3 | Transporte y Disposición Final de Escombros en Sitio Autorizado |  | 5d | 2024-01-10 | 2024-01-16 | 337SS | 507d | 2d | 0,00% | 0,00% | 0,00% | 0,00% |
| 340 | 1.5.8.4 | **CIMENTACIÓN** |  | 25d | 2024-02-09 | 2024-03-13 |  | 119d | 6d | 0,00% | 0,00% | 0,00% | 0,00% |
| 341 | 1.5.8.4.1 | **CONSTRUCCIÓN PILOTES** |  | 7d | 2024-02-09 | 2024-02-19 |  | 119d |  | 0,00% | 0,00% | 0,00% | 0,00% |
| 342 | 1.5.8.4.1.1 | Excavación para Pilotes |  | 5d | 2024-02-09 | 2024-02-15 | 297FS+1d | 119d | 0d | 0,00% | 0,00% | 0,00% | 0,00% |
| 343 | 1.5.8.4.1.2 | Acero de Refuerzo |  | 3d | 2024-02-13 | 2024-02-16 | 342FS-2d | 125d | 0d | 0,00% | 0,00% | 0,00% | 0,00% |
| 344 | 1.5.8.4.1.3 | Concreto |  | 3d | 2024-02-14 | 2024-02-19 | 343FS-2d | 125d | 0d | 0,00% | 0,00% | 0,00% | 0,00% |
| 345 | 1.5.8.4.2 | Descabece de Pilotes |  | 2d | 2024-02-19 | 2024-02-21 | 344 | 125d | 0d | 0,00% | 0,00% | 0,00% | 0,00% |
| 346 | 1.5.8.4.3 | **CONSTRUCCIÓN DADOS DE CIMENTACIÓN** |  | 6d | 2024-02-21 | 2024-02-28 |  | 125d |  | 0,00% | 0,00% | 0,00% | 0,00% |
| 347 | 1.5.8.4.3.1 | Acero de Refuerzo |  | 3d | 2024-02-21 | 2024-02-24 | 345 | 125d | 0d | 0,00% | 0,00% | 0,00% | 0,00% |
| 348 | 1.5.8.4.3.2 | Concreto |  | 3d | 2024-02-26 | 2024-02-28 | 347 | 125d | 0d | 0,00% | 0,00% | 0,00% | 0,00% |
| 349 | 1.5.8.4.4 | **PEDESTAL** |  | 10d | 2024-02-29 | 2024-03-13 |  | 125d |  | 0,00% | 0,00% | 0,00% | 0,00% |
| 350 | 1.5.8.4.4.1 | Acero de Refuerzo |  | 5d | 2024-02-29 | 2024-03-06 | 348 | 125d | 0d | 0,00% | 0,00% | 0,00% | 0,00% |
| 351 | 1.5.8.4.4.2 | Concreto |  | 5d | 2024-03-06 | 2024-03-13 | 350 | 125d | 0d | 0,00% | 0,00% | 0,00% | 0,00% |
| 352 | 1.5.8.5 | **RELLENOS** |  | 6d | 2024-03-13 | 2024-03-20 |  | 406d | 0d | 0,00% | 0,00% | 0,00% | 0,00% |
| 353 | 1.5.8.5.1 | Relleno De Material Seleccionado |  | 6d | 2024-03-13 | 2024-03-20 | 351 | 406d | 0d | 0,00% | 0,00% | 0,00% | 0,00% |
| 354 | 1.5.8.6 | **PUESTA A TIERRA** |  | 2d | 2024-03-21 | 2024-03-22 |  | 411d | 54d | 0,00% | 0,00% | 0,00% | 0,00% |
| 355 | 1.5.8.6.1 | Instalación Cable de Cobre |  | 1d | 2024-03-21 | 2024-03-21 | 353 | 411d | 0d | 0,00% | 0,00% | 0,00% | 0,00% |
| 356 | 1.5.8.6.2 | Varilla COOPER WELD 5/8" x 2.44m. |  | 1d | 2024-03-22 | 2024-03-22 | 355 | 411d | 0d | 0,00% | 0,00% | 0,00% | 0,00% |
| 357 | 1.5.8.6.3 | Fin Puesta a Tierra | milestone | 0d | 2024-03-22 | 2024-03-22 | 355, 356 | 411d | 9d | 0,00% | 0,00% | 0,00% | 0,00% |

| ID | WBS | Task | Type | Duration | Start | Finish | Predecessors | Total slack | Free slack | % Avance Planeado | % avance planeado en costo (texto) | % Completado (décimales) | % Completado en Costo |
| --- | --- | --- | --- | --- | --- | --- | --- | --- | --- | --- | --- | --- | --- |
| 358 | 1.5.8.7 | **MONTAJE ELECTROMECÁNICO** |  | 10d | 2024-03-13 | 2024-03-27 |  | 125d | 0d | 0,00% | 0,00% | 0,00% | 0,00% |
| 359 | 1.5.8.7.1 | Montaje Mecánico |  | 5d | 2024-03-13 | 2024-03-19 | 314, 351 | 125d | 0d | 0,00% | 0,00% | 0,00% | 0,00% |
| 360 | 1.5.8.7.2 | Montaje Eléctrico |  | 5d | 2024-03-20 | 2024-03-27 | 359 | 402d | 0d | 0,00% | 0,00% | 0,00% | 0,00% |
| 361 | 1.5.8.7.3 | Fin montaje Electromecánico | milestone | 0d | 2024-03-27 | 2024-03-27 | 359, 360 | 402d | 0d | 0,00% | 0,00% | 0,00% | 0,00% |
| 362 | 1.5.8.8 | **ALIMENTACIÓN ELÉCTRICA** |  | 7d | 2024-03-27 | 2024-04-08 |  | 402d | 45d | 0,00% | 0,00% | 0,00% | 0,00% |
| 363 | 1.5.8.8.1 | Instalacion de tuberia PVC |  | 5d | 2024-03-27 | 2024-04-05 | 361, 353, 351 | 402d | 0d | 0,00% | 0,00% | 0,00% | 0,00% |
| 364 | 1.5.8.8.2 | Cableado |  | 1d | 2024-04-05 | 2024-04-06 | 363 | 402d | 0d | 0,00% | 0,00% | 0,00% | 0,00% |
| 365 | 1.5.8.8.3 | Instalación de Medidor |  | 1d | 2024-04-08 | 2024-04-08 | 364 | 402d | 0d | 0,00% | 0,00% | 0,00% | 0,00% |
| 366 | 1.5.8.8.4 | Fin Alimentación Eléctrica | milestone | 0d | 2024-04-08 | 2024-04-08 | 365 | 402d | 0d | 0,00% | 0,00% | 0,00% | 0,00% |
| 367 | 1.5.8.9 | **CERTIFICACIONES RETIE Y RETILAP** |  | 45d | 2024-04-09 | 2024-06-11 |  | 402d | 0d | 0,00% | 0,00% | 0,00% | 0,00% |
| 368 | 1.5.8.9.1 | Certificación RETIE |  | 45d | 2024-04-09 | 2024-06-11 | 357, 366, 331 | 402d | 0d | 0,00% | 0,00% | 0,00% | 0,00% |
| 369 | 1.5.8.9.2 | Certificación RETILAP |  | 45d | 2024-04-09 | 2024-06-11 | 368SS | 402d | 0d | 0,00% | 0,00% | 0,00% | 0,00% |
| 370 | 1.5.8.9.3 | Fin Certificaciones RETIE Y RETILAP | milestone | 0d | 2024-06-11 | 2024-06-11 | 369 | 402d |  | 0,00% | 0,00% | 0,00% | 0,00% |
| 371 | 1.5.8.10 | FIN TORRE 2 | milestone | 0d | 2024-01-18 | 2024-01-18 | 334, 335, 338, 339 | 505d |  | 0,00% | 0,00% | 0,00% | 0,00% |
| 372 | 1.5.8.11 | Torre 2: Hito de Aprobación Para Pago Preliminares y Cimentación | milestone | 0d | 2024-03-20 | 2024-03-20 | 332, 336, 340, 352 | 458d |  | 0,00% | 0,00% | 0,00% | 0,00% |
| 373 | 1.5.8.12 | Torre 2: Hito de Aprobación Para Pago Redes | milestone | 0d | 2024-06-11 | 2024-06-11 | 354, 362, 331, 367 | 402d |  | 0,00% | 0,00% | 0,00% | 0,00% |
| 374 | 1.5.8.13 | Torre 2: Hito de Aprobación Para Pago Electromecánico | milestone | 0d | 2024-03-27 | 2024-03-27 | 358 | 454d |  | 0,00% | 0,00% | 0,00% | 0,00% |
| 375 | 1.5.9 | Entrega de predios por parte de IDU al constructor | milestone | 0d | 2023-07-13 | 2023-07-13 | 47 | 433d | 0d | 0,00% | 0,00% | 0,00% | 0,00% |
| 376 | 1.5.10 | **PERMISOS** |  | 0d | 2023-07-13 | 2023-07-13 |  | 639d |  | 0,00% | 0,00% | 0,00% | 0,00% |
| 377 | 1.5.10.1 | Trabajo Nocturno | milestone | 0d | 2023-07-13 | 2023-07-13 | 375 | 639d |  | 0,00% | 0,00% | 0,00% | 0,00% |
| 378 | 1.5.10.2 | Ocupación de cauce | milestone | 0d | 2023-07-13 | 2023-07-13 | 375 | 639d |  | 0,00% | 0,00% | 0,00% | 0,00% |
| 379 | 1.5.10.3 | Gas Natural | milestone | 0d | 2023-07-13 | 2023-07-13 | 375 | 639d |  | 0,00% | 0,00% | 0,00% | 0,00% |
| 380 | 1.5.11 | **TORRE 3** |  | 93d | 2024-02-09 | 2024-06-19 |  | 125d |  | 0,00% | 0,00% | 0,00% | 0,00% |
| 381 | 1.5.11.1 | **PRELIMINARES DE OBRA, MOVIMIENTO DE TIERRAS Y RELLENOS** |  | 4d | 2024-02-09 | 2024-02-14 |  | 433d | 54d | 0,00% | 0,00% | 0,00% | 0,00% |
| 382 | 1.5.11.1.1 | Replanteo General |  | 2d | 2024-02-09 | 2024-02-12 | 5, 375FS+150d | 433d | 0d | 0,00% | 0,00% | 0,00% | 0,00% |
| 383 | 1.5.11.1.2 | Cerramiento y Señalización |  | 2d | 2024-02-12 | 2024-02-14 | 382 | 485d | 54d | 0,00% | 0,00% | 0,00% | 0,00% |
| 384 | 1.5.11.1.3 | Tala de Especies |  | 2d | 2024-02-12 | 2024-02-14 | 382 | 461d | 0d | 0,00% | 0,00% | 0,00% | 0,00% |

| ID | WBS | Task | Type | Duration | Start | Finish | Predecessors | Total slack | Free slack | % Avance Planeado | % avance planeado en costo (texto) | % Completado (décimales) | % Completado en Costo |
| --- | --- | --- | --- | --- | --- | --- | --- | --- | --- | --- | --- | --- | --- |
| 385 | 1.5.11.2 | **DEMOLICIONES** |  | 24d | 2024-02-14 | 2024-03-16 |  | 461d | 30d | 0,00% | 0,00% | 0,00% | 0,00% |
| 386 | 1.5.11.2.1 | Demoliciones de construcciones existentes |  | 24d | 2024-02-14 | 2024-03-16 | 384 | 461d | 0d | 0,00% | 0,00% | 0,00% | 0,00% |
| 387 | 1.5.11.2.2 | Fin demoliciones | milestone | 0d | 2024-03-16 | 2024-03-16 | 386 | 461d |  | 0,00% | 0,00% | 0,00% | 0,00% |
| 388 | 1.5.11.3 | **MOVIMIENTO DE TIERRAS** |  | 7d | 2024-02-12 | 2024-02-21 |  | 433d | 49d | 0,00% | 0,00% | 0,00% | 0,00% |
| 389 | 1.5.11.3.1 | Excavación Mecánica En Material Común |  | 5d | 2024-02-12 | 2024-02-19 | 382 | 433d | 0d | 0,00% | 0,00% | 0,00% | 0,00% |
| 390 | 1.5.11.3.2 | Nivelación y Compactación de Subrasante |  | 2d | 2024-02-19 | 2024-02-21 | 389 | 480d | 49d | 0,00% | 0,00% | 0,00% | 0,00% |
| 391 | 1.5.11.3.3 | Transporte Y Disposición Final De Escombros En Sitio Autorizado |  | 5d | 2024-02-12 | 2024-02-19 | 389SS | 482d | 51d | 0,00% | 0,00% | 0,00% | 0,00% |
| 392 | 1.5.11.4 | **CIMENTACIÓN** |  | 25d | 2024-02-16 | 2024-03-20 |  | 119d | 27d | 0,00% | 0,00% | 0,00% | 0,00% |
| 393 | 1.5.11.4.1 | **CONSTRUCCIÓN PILOTES** |  | 7d | 2024-02-16 | 2024-02-26 |  | 119d |  | 0,00% | 0,00% | 0,00% | 0,00% |
| 394 | 1.5.11.4.1.1 | Excavación para Pilotes |  | 5d | 2024-02-16 | 2024-02-23 | 342FS+1d | 119d | 0d | 0,00% | 0,00% | 0,00% | 0,00% |
| 395 | 1.5.11.4.1.2 | Acero de Refuerzo |  | 3d | 2024-02-21 | 2024-02-24 | 394FS-2d | 124d | 0d | 0,00% | 0,00% | 0,00% | 0,00% |
| 396 | 1.5.11.4.1.3 | Concreto |  | 3d | 2024-02-22 | 2024-02-26 | 395FS-2d | 124d | 0d | 0,00% | 0,00% | 0,00% | 0,00% |
| 397 | 1.5.11.4.2 | Descabece de Pilotes |  | 2d | 2024-02-27 | 2024-02-28 | 396 | 124d | 0d | 0,00% | 0,00% | 0,00% | 0,00% |
| 398 | 1.5.11.4.3 | **CONSTRUCCIÓN DADOS DE CIMENTACIÓN** |  | 6d | 2024-02-29 | 2024-03-07 |  | 124d |  | 0,00% | 0,00% | 0,00% | 0,00% |
| 399 | 1.5.11.4.3.1 | Acero de Refuerzo |  | 3d | 2024-02-29 | 2024-03-04 | 397 | 124d | 0d | 0,00% | 0,00% | 0,00% | 0,00% |
| 400 | 1.5.11.4.3.2 | Concreto |  | 3d | 2024-03-04 | 2024-03-07 | 399 | 124d | 0d | 0,00% | 0,00% | 0,00% | 0,00% |
| 401 | 1.5.11.4.4 | **PEDESTAL** |  | 10d | 2024-03-07 | 2024-03-20 |  | 124d |  | 0,00% | 0,00% | 0,00% | 0,00% |
| 402 | 1.5.11.4.4.1 | Acero de Refuerzo |  | 5d | 2024-03-07 | 2024-03-14 | 400 | 124d | 0d | 0,00% | 0,00% | 0,00% | 0,00% |
| 403 | 1.5.11.4.4.2 | Concreto |  | 5d | 2024-03-14 | 2024-03-20 | 402 | 124d | 0d | 0,00% | 0,00% | 0,00% | 0,00% |
| 404 | 1.5.11.5 | **RELLENOS** |  | 6d | 2024-03-21 | 2024-04-02 |  | 400d | 21d | 0,00% | 0,00% | 0,00% | 0,00% |
| 405 | 1.5.11.5.1 | Relleno De Material Seleccionado |  | 6d | 2024-03-21 | 2024-04-02 | 403 | 400d | 0d | 0,00% | 0,00% | 0,00% | 0,00% |
| 406 | 1.5.11.6 | **PUESTA A TIERRA** |  | 2d | 2024-04-02 | 2024-04-04 |  | 405d | 54d | 0,00% | 0,00% | 0,00% | 0,00% |
| 407 | 1.5.11.6.1 | Instalación Cable de Cobre |  | 1d | 2024-04-02 | 2024-04-03 | 405 | 405d | 0d | 0,00% | 0,00% | 0,00% | 0,00% |
| 408 | 1.5.11.6.2 | Varilla COOPER WELD 5/8" x 2.44m. |  | 1d | 2024-04-03 | 2024-04-04 | 407 | 405d | 0d | 0,00% | 0,00% | 0,00% | 0,00% |
| 409 | 1.5.11.6.3 | Fin Puesta a Tierra | milestone | 0d | 2024-04-04 | 2024-04-04 | 407, 408 | 405d | 9d | 0,00% | 0,00% | 0,00% | 0,00% |

| ID | WBS | Task | Type | Duration | Start | Finish | Predecessors | Total slack | Free slack | % Avance Planeado | % avance planeado en costo (texto) | % Completado (décimales) | % Completado en Costo |
| --- | --- | --- | --- | --- | --- | --- | --- | --- | --- | --- | --- | --- | --- |
| 410 | 1.5.11.7 | **MONTAJE ELECTROMECÁNICO** |  | 10d | 2024-03-21 | 2024-04-06 |  | 124d | 0d | 0,00% | 0,00% | 0,00% | 0,00% |
| 411 | 1.5.11.7.1 | Montaje Mecánico |  | 5d | 2024-03-21 | 2024-04-01 | 359, 403 | 124d | 0d | 0,00% | 0,00% | 0,00% | 0,00% |
| 412 | 1.5.11.7.2 | Montaje Eléctrico |  | 5d | 2024-04-01 | 2024-04-06 | 411 | 396d | 0d | 0,00% | 0,00% | 0,00% | 0,00% |
| 413 | 1.5.11.7.3 | Fin montaje Electromecánico | milestone | 0d | 2024-04-06 | 2024-04-06 | 411, 412 | 396d | 0d | 0,00% | 0,00% | 0,00% | 0,00% |
| 414 | 1.5.11.8 | **ALIMENTACIÓN ELÉCTRICA** |  | 7d | 2024-04-08 | 2024-04-16 |  | 396d | 45d | 0,00% | 0,00% | 0,00% | 0,00% |
| 415 | 1.5.11.8.1 | Instalacion de tuberia PVC |  | 5d | 2024-04-08 | 2024-04-12 | 413, 405, 403 | 396d | 0d | 0,00% | 0,00% | 0,00% | 0,00% |
| 416 | 1.5.11.8.2 | Cableado |  | 1d | 2024-04-13 | 2024-04-15 | 415 | 396d | 0d | 0,00% | 0,00% | 0,00% | 0,00% |
| 417 | 1.5.11.8.3 | Instalación de Medidor |  | 1d | 2024-04-15 | 2024-04-16 | 416 | 396d | 0d | 0,00% | 0,00% | 0,00% | 0,00% |
| 418 | 1.5.11.8.4 | Fin Alimentación Eléctrica | milestone | 0d | 2024-04-16 | 2024-04-16 | 417 | 396d | 0d | 0,00% | 0,00% | 0,00% | 0,00% |
| 419 | 1.5.11.9 | **ALUMBRADO PÚBLICO DE TORRE** |  | 5d | 2024-04-08 | 2024-04-12 |  | 400d | 47d | 0,00% | 0,00% | 0,00% | 0,00% |
| 420 | 1.5.11.9.1 | Tubería Eléctrica PVC |  | 5d | 2024-04-08 | 2024-04-12 | 415SS, 363SS | 400d | 0d | 0,00% | 0,00% | 0,00% | 0,00% |
| 421 | 1.5.11.9.2 | Accesorios |  | 1d | 2024-04-08 | 2024-04-08 | 420SS | 400d | 0d | 0,00% | 0,00% | 0,00% | 0,00% |
| 422 | 1.5.11.9.3 | Cableado |  | 1d | 2024-04-09 | 2024-04-09 | 421 | 400d | 0d | 0,00% | 0,00% | 0,00% | 0,00% |
| 423 | 1.5.11.9.4 | Instalación de A.P. |  | 1d | 2024-04-10 | 2024-04-10 | 422 | 400d | 0d | 0,00% | 0,00% | 0,00% | 0,00% |
| 424 | 1.5.11.9.5 | Fin Alumbrado Público de Torre | milestone | 0d | 2024-04-10 | 2024-04-10 | 423 | 400d | 4d | 0,00% | 0,00% | 0,00% | 0,00% |
| 425 | 1.5.11.10 | **CERTIFICACIONES RETIE Y RETILAP** |  | 45d | 2024-04-16 | 2024-06-19 |  | 396d | 0d | 0,00% | 0,00% | 0,00% | 0,00% |
| 426 | 1.5.11.10.1 | Certificación RETIE |  | 45d | 2024-04-16 | 2024-06-19 | 409, 418, 424 | 396d | 0d | 0,00% | 0,00% | 0,00% | 0,00% |
| 427 | 1.5.11.10.2 | Certificación RETILAP |  | 45d | 2024-04-16 | 2024-06-19 | 426SS | 396d | 0d | 0,00% | 0,00% | 0,00% | 0,00% |
| 428 | 1.5.11.10.3 | Fin Certificaciones RETIE Y RETILAP | milestone | 0d | 2024-06-19 | 2024-06-19 | 427 | 396d |  | 0,00% | 0,00% | 0,00% | 0,00% |
| 429 | 1.5.11.11 | **REDES HIDRÁULICAS EXTERNAS** |  | 7d | 2024-02-12 | 2024-02-21 |  | 433d | 84d | 0,00% | 0,00% | 0,00% | 0,00% |
| 430 | 1.5.11.11.1 | **RED DE ALCANTARILLADO** |  | 7d | 2024-02-12 | 2024-02-21 |  | 433d |  | 0,00% | 0,00% | 0,00% | 0,00% |
| 431 | 1.5.11.11.1.1 | Excavación manual para redes y canal monolítico |  | 5d | 2024-02-12 | 2024-02-19 | 389SS | 433d | 0d | 0,00% | 0,00% | 0,00% | 0,00% |
| 432 | 1.5.11.11.1.2 | Instalación de tubería, incluye accesorios. |  | 2d | 2024-02-15 | 2024-02-19 | 431SS+3d | 480d | 0d | 0,00% | 0,00% | 0,00% | 0,00% |
| 433 | 1.5.11.11.1.3 | Rellenos para redes y canal |  | 3d | 2024-02-16 | 2024-02-21 | 432SS+1d | 480d | 49d | 0,00% | 0,00% | 0,00% | 0,00% |
| 434 | 1.5.11.11.1.4 | Instalación de canal monolítico |  | 2d | 2024-02-15 | 2024-02-19 | 431SS+3d | 433d | 0d | 0,00% | 0,00% | 0,00% | 0,00% |

| ID | WBS | Task | Type | Duration | Start | Finish | Predecessors | Total slack | Free slack | % Avance Planeado | % avance planeado en costo (texto) | % Completado (décimales) | % Completado en Costo |
| --- | --- | --- | --- | --- | --- | --- | --- | --- | --- | --- | --- | --- | --- |
| 435 | 1.5.11.12 | **URBANISMO Y PAISAJISMO** |  | 51d | 2024-02-19 | 2024-04-29 |  | 431d | 0d | 0,00% | 0,00% | 0,00% | 0,00% |
| 436 | 1.5.11.12.1 | **ESTRUCTURAS DE CONTENCIÓN PARA URBANISMO** |  | 49d | 2024-02-19 | 2024-04-26 |  | 433d | 2d | 0,00% | 0,00% | 0,00% | 0,00% |
| 437 | 1.5.11.12.1.1 | Construcción de muros en concreto reforzado y mampostería estructural. Incluye otros elementos y la construcción de filtro de drenaje tras muro. |  | 20d | 2024-02-19 | 2024-03-15 | 434 | 433d | 0d | 0,00% | 0,00% | 0,00% | 0,00% |
| 438 | 1.5.11.12.1.2 | Construcción de escaleras. |  | 15d | 2024-04-08 | 2024-04-26 | 437FS+14d | 433d | 0d | 0,00% | 0,00% | 0,00% | 0,00% |
| 439 | 1.5.11.12.1.3 | Fin Estructuras de contención para urbanismo | milestone | 0d | 2024-04-26 | 2024-04-26 | 438 | 433d |  | 0,00% | 0,00% | 0,00% | 0,00% |
| 440 | 1.5.11.12.2 | **PAISAJISMO** |  | 2d | 2024-04-02 | 2024-04-04 |  | 431d |  | 0,00% | 0,00% | 0,00% | 0,00% |
| 441 | 1.5.11.12.2.1 | Contenedores de raices, Instalación de grama y hiedras. Incluye tierra negra. |  | 1d | 2024-04-02 | 2024-04-03 | 405 | 431d | 0d | 0,00% | 0,00% | 0,00% | 0,00% |
| 442 | 1.5.11.12.2.2 | Especies arboreas | milestone | 0d | 2024-04-02 | 2024-04-02 | 441SS | 452d | 21d | 0,00% | 0,00% | 0,00% | 0,00% |
| 443 | 1.5.11.12.2.3 | Jardines horizontales |  | 1d | 2024-04-03 | 2024-04-04 | 441 | 450d | 19d | 0,00% | 0,00% | 0,00% | 0,00% |
| 444 | 1.5.11.12.3 | **URBANISMO** |  | 21d | 2024-04-02 | 2024-04-29 |  | 431d |  | 0,00% | 0,00% | 0,00% | 0,00% |
| 445 | 1.5.11.12.3.1 | Instalación de prefabricados. Incluye cañuelas, sardineles, bordillos, pisos en adoquín, tabletas y concreto escobeado. |  | 15d | 2024-04-02 | 2024-04-22 | 441SS | 431d | 0d | 0,00% | 0,00% | 0,00% | 0,00% |
| 446 | 1.5.11.12.3.2 | Mobiliario y elementos independientes |  | 6d | 2024-04-22 | 2024-04-29 | 445 | 431d | 0d | 0,00% | 0,00% | 0,00% | 0,00% |
| 447 | 1.5.11.13 | FIN TORRE 3 | milestone | 0d | 2024-04-29 | 2024-04-29 | 383, 384, 390, 391, 433, 434, 442, 443, 446 | 431d |  | 0,00% | 0,00% | 0,00% | 0,00% |
| 448 | 1.5.11.14 | Torre 3: Hito de Aprobación Para Pago Preliminares, Demoliciones, Excavación y Cimentación | milestone | 0d | 2024-04-29 | 2024-04-29 | 381, 388, 392, 404, 435, 385, 436, 512 | 431d |  | 0,00% | 0,00% | 0,00% | 0,00% |
| 449 | 1.5.11.15 | Torre 3: Hito de Aprobación Para Pago Redes | milestone | 0d | 2024-06-19 | 2024-06-19 | 406, 414, 419, 425, 429 | 396d |  | 0,00% | 0,00% | 0,00% | 0,00% |
| 450 | 1.5.11.16 | Torre 3: Hito de Aprobación Para Pago Electromecánico | milestone | 0d | 2024-04-06 | 2024-04-06 | 410 | 448d |  | 0,00% | 0,00% | 0,00% | 0,00% |
| 451 | 1.5.12 | Entrega de predios por parte de IDU al constructor | milestone | 0d | 2023-07-13 | 2023-07-13 | 47 | 442d | 0d | 0,00% | 0,00% | 0,00% | 0,00% |
| 452 | 1.5.13 | **PERMISOS** |  | 0d | 2023-07-13 | 2023-07-13 |  | 532d |  | 0,00% | 0,00% | 0,00% | 0,00% |
| 453 | 1.5.13.1 | Trabajo Nocturno | milestone | 0d | 2023-07-13 | 2023-07-13 | 451 | 532d | 90d | 0,00% | 0,00% | 0,00% | 0,00% |
| 454 | 1.5.13.2 | Energía | milestone | 0d | 2023-07-13 | 2023-07-13 | 451 | 532d | 90d | 0,00% | 0,00% | 0,00% | 0,00% |
| 455 | 1.5.14 | **TORRE 4** |  | 159d | 2023-11-17 | 2024-06-27 |  | 191d |  | 0,00% | 0,00% | 0,00% | 0,00% |
| 456 | 1.5.14.1 | TRASLADO DE REDES |  | 45d | 2023-11-17 | 2024-01-19 | 451FS+90d, 453, 454 | 442d | 0d | 0,00% | 0,00% | 0,00% | 0,00% |
| 457 | 1.5.14.2 | **PRELIMINARES DE OBRA, MOVIMIENTO DE TIERRAS Y RELLENOS** |  | 23d | 2024-01-20 | 2024-02-20 |  | 442d | 56d | 0,00% | 0,00% | 0,00% | 0,00% |
| 458 | 1.5.14.2.1 | Replanteo General |  | 3d | 2024-01-20 | 2024-01-24 | 456 | 442d | 0d | 0,00% | 0,00% | 0,00% | 0,00% |
| 459 | 1.5.14.2.2 | Cerramiento y Señalización |  | 2d | 2024-01-24 | 2024-01-26 | 458 | 499d | 74d | 0,00% | 0,00% | 0,00% | 0,00% |
| 460 | 1.5.14.2.3 | Tala de Especies |  | 2d | 2024-01-24 | 2024-01-26 | 458 | 481d | 0d | 0,00% | 0,00% | 0,00% | 0,00% |

| ID | WBS | Task | Type | Duration | Start | Finish | Predecessors | Total slack | Free slack | % Avance Planeado | % avance planeado en costo (texto) | % Completado (décimales) | % Completado en Costo |
| --- | --- | --- | --- | --- | --- | --- | --- | --- | --- | --- | --- | --- | --- |
| 461 | 1.5.14.2.4 | **DEMOLICIONES** |  | 18d | 2024-01-26 | 2024-02-20 |  | 481d | 56d | 0,00% | 0,00% | 0,00% | 0,00% |
| 462 | 1.5.14.2.4.1 | Demoliciones de construcciones existentes |  | 18d | 2024-01-26 | 2024-02-20 | 460 | 481d | 0d | 0,00% | 0,00% | 0,00% | 0,00% |
| 463 | 1.5.14.2.4.2 | Fin demoliciones | milestone | 0d | 2024-02-20 | 2024-02-20 | 462 | 481d |  | 0,00% | 0,00% | 0,00% | 0,00% |
| 464 | 1.5.14.3 | **MOVIMIENTO DE TIERRAS** |  | 7d | 2024-01-24 | 2024-02-02 |  | 442d | 69d | 0,00% | 0,00% | 0,00% | 0,00% |
| 465 | 1.5.14.3.1 | Excavación Mecánica en Material Común |  | 5d | 2024-01-24 | 2024-01-31 | 458 | 442d | 0d | 0,00% | 0,00% | 0,00% | 0,00% |
| 466 | 1.5.14.3.2 | Nivelación y Compactación de Subrasante |  | 2d | 2024-01-31 | 2024-02-02 | 465 | 494d | 69d | 0,00% | 0,00% | 0,00% | 0,00% |
| 467 | 1.5.14.3.3 | Transporte y disposición final de escombros en sitio |  | 5d | 2024-01-24 | 2024-01-31 | 465SS | 496d | 71d | 0,00% | 0,00% | 0,00% | 0,00% |
| 468 | 1.5.14.4 | **CIMENTACIÓN** |  | 25d | 2024-02-26 | 2024-04-02 |  | 119d | 27d | 0,00% | 0,00% | 0,00% | 0,00% |
| 469 | 1.5.14.4.1 | **CONSTRUCCIÓN PILOTES** |  | 7d | 2024-02-26 | 2024-03-05 |  | 119d |  | 0,00% | 0,00% | 0,00% | 0,00% |
| 470 | 1.5.14.4.1.1 | Excavación para Pilotes |  | 5d | 2024-02-26 | 2024-03-01 | 394FS+1d | 119d | 0d | 0,00% | 0,00% | 0,00% | 0,00% |
| 471 | 1.5.14.4.1.2 | acero de refuerzo |  | 3d | 2024-02-29 | 2024-03-04 | 470FS-2d | 123d | 0d | 0,00% | 0,00% | 0,00% | 0,00% |
| 472 | 1.5.14.4.1.3 | Concreto |  | 3d | 2024-03-01 | 2024-03-05 | 471FS-2d | 123d | 0d | 0,00% | 0,00% | 0,00% | 0,00% |
| 473 | 1.5.14.4.2 | Descabece de Pilotes |  | 2d | 2024-03-05 | 2024-03-07 | 472 | 123d | 0d | 0,00% | 0,00% | 0,00% | 0,00% |
| 474 | 1.5.14.4.3 | **CONSTRUCCIÓN DADOS DE CIMENTACIÓN** |  | 6d | 2024-03-07 | 2024-03-15 |  | 123d |  | 0,00% | 0,00% | 0,00% | 0,00% |
| 475 | 1.5.14.4.3.1 | acero de refuerzo |  | 3d | 2024-03-07 | 2024-03-12 | 473 | 123d | 0d | 0,00% | 0,00% | 0,00% | 0,00% |
| 476 | 1.5.14.4.3.2 | concreto |  | 3d | 2024-03-12 | 2024-03-15 | 475 | 123d | 0d | 0,00% | 0,00% | 0,00% | 0,00% |
| 477 | 1.5.14.4.4 | **PEDESTAL** |  | 10d | 2024-03-15 | 2024-04-02 |  | 123d |  | 0,00% | 0,00% | 0,00% | 0,00% |
| 478 | 1.5.14.4.4.1 | acero de refuerzo |  | 5d | 2024-03-15 | 2024-03-21 | 476 | 123d | 0d | 0,00% | 0,00% | 0,00% | 0,00% |
| 479 | 1.5.14.4.4.2 | Concreto |  | 5d | 2024-03-22 | 2024-04-02 | 478 | 123d | 0d | 0,00% | 0,00% | 0,00% | 0,00% |
| 480 | 1.5.14.5 | **RELLENOS** |  | 6d | 2024-04-02 | 2024-04-09 |  | 394d | 21d | 0,00% | 0,00% | 0,00% | 0,00% |
| 481 | 1.5.14.5.1 | Relleno De Material Seleccionado |  | 6d | 2024-04-02 | 2024-04-09 | 479 | 394d | 0d | 0,00% | 0,00% | 0,00% | 0,00% |
| 482 | 1.5.14.6 | **PUESTA A TIERRA** |  | 2d | 2024-04-10 | 2024-04-11 |  | 399d | 54d | 0,00% | 0,00% | 0,00% | 0,00% |
| 483 | 1.5.14.6.1 | Instalación Cable de Cobre |  | 1d | 2024-04-10 | 2024-04-10 | 481 | 399d | 0d | 0,00% | 0,00% | 0,00% | 0,00% |
| 484 | 1.5.14.6.2 | Varilla COOPER WELD 5/8" x 2.44m. |  | 1d | 2024-04-11 | 2024-04-11 | 483 | 399d | 0d | 0,00% | 0,00% | 0,00% | 0,00% |
| 485 | 1.5.14.6.3 | Fin Puesta a Tierra | milestone | 0d | 2024-04-11 | 2024-04-11 | 483, 484 | 399d | 9d | 0,00% | 0,00% | 0,00% | 0,00% |

| ID | WBS | Task | Type | Duration | Start | Finish | Predecessors | Total slack | Free slack | % Avance Planeado | % avance planeado en costo (texto) | % Completado (décimales) | % Completado en Costo |
| --- | --- | --- | --- | --- | --- | --- | --- | --- | --- | --- | --- | --- | --- |
| 486 | 1.5.14.7 | **MONTAJE ELECTROMECÁNICO** |  | 10d | 2024-04-02 | 2024-04-15 |  | 123d | 0d | 0,00% | 0,00% | 0,00% | 0,00% |
| 487 | 1.5.14.7.1 | Montaje Mecánico |  | 5d | 2024-04-02 | 2024-04-08 | 411, 479 | 123d | 0d | 0,00% | 0,00% | 0,00% | 0,00% |
| 488 | 1.5.14.7.2 | Montaje Eléctrico |  | 5d | 2024-04-09 | 2024-04-15 | 487 | 390d | 0d | 0,00% | 0,00% | 0,00% | 0,00% |
| 489 | 1.5.14.7.3 | Fin montaje Electromecánico | milestone | 0d | 2024-04-15 | 2024-04-15 | 487, 488 | 390d | 0d | 0,00% | 0,00% | 0,00% | 0,00% |
| 490 | 1.5.14.8 | **ALIMENTACIÓN ELÉCTRICA** |  | 7d | 2024-04-15 | 2024-04-24 |  | 390d | 45d | 0,00% | 0,00% | 0,00% | 0,00% |
| 491 | 1.5.14.8.1 | Instalacion de tuberia PVC |  | 5d | 2024-04-15 | 2024-04-22 | 489, 479, 481 | 390d | 0d | 0,00% | 0,00% | 0,00% | 0,00% |
| 492 | 1.5.14.8.2 | Cableado |  | 1d | 2024-04-22 | 2024-04-23 | 491 | 390d | 0d | 0,00% | 0,00% | 0,00% | 0,00% |
| 493 | 1.5.14.8.3 | Instalación de Medidor |  | 1d | 2024-04-23 | 2024-04-24 | 492 | 390d | 0d | 0,00% | 0,00% | 0,00% | 0,00% |
| 494 | 1.5.14.8.4 | Fin Alimentación Eléctrica | milestone | 0d | 2024-04-24 | 2024-04-24 | 493 | 390d | 0d | 0,00% | 0,00% | 0,00% | 0,00% |
| 495 | 1.5.14.9 | **ALUMBRADO PÚBLICO DE TORRE** |  | 5d | 2024-04-15 | 2024-04-22 |  | 394d | 47d | 0,00% | 0,00% | 0,00% | 0,00% |
| 496 | 1.5.14.9.1 | Tubería Eléctrica PVC |  | 5d | 2024-04-15 | 2024-04-22 | 491SS | 394d | 0d | 0,00% | 0,00% | 0,00% | 0,00% |
| 497 | 1.5.14.9.2 | Accesorios |  | 1d | 2024-04-15 | 2024-04-16 | 496SS | 394d | 0d | 0,00% | 0,00% | 0,00% | 0,00% |
| 498 | 1.5.14.9.3 | Cableado |  | 1d | 2024-04-16 | 2024-04-17 | 497 | 394d | 0d | 0,00% | 0,00% | 0,00% | 0,00% |
| 499 | 1.5.14.9.4 | Instalación de A.P. |  | 1d | 2024-04-17 | 2024-04-18 | 498 | 394d | 0d | 0,00% | 0,00% | 0,00% | 0,00% |
| 500 | 1.5.14.9.5 | Fin Alumbrado Público de Torre | milestone | 0d | 2024-04-18 | 2024-04-18 | 499 | 394d | 4d | 0,00% | 0,00% | 0,00% | 0,00% |
| 501 | 1.5.14.10 | **CERTIFICACIONES RETIE Y RETILAP** |  | 45d | 2024-04-24 | 2024-06-27 |  | 390d | 0d | 0,00% | 0,00% | 0,00% | 0,00% |
| 502 | 1.5.14.10.1 | Certificación RETIE |  | 45d | 2024-04-24 | 2024-06-27 | 500, 494, 485, 456 | 390d | 0d | 0,00% | 0,00% | 0,00% | 0,00% |
| 503 | 1.5.14.10.2 | Certificación RETILAP |  | 45d | 2024-04-24 | 2024-06-27 | 502SS | 390d | 0d | 0,00% | 0,00% | 0,00% | 0,00% |
| 504 | 1.5.14.10.3 | Fin Certificaciones RETIE Y RETILAP | milestone | 0d | 2024-06-27 | 2024-06-27 | 503 | 390d |  | 0,00% | 0,00% | 0,00% | 0,00% |
| 505 | 1.5.14.11 | **REDES HIDRÁULICAS EXTERNAS** |  | 7d | 2024-01-24 | 2024-02-02 |  | 442d | 104d | 0,00% | 0,00% | 0,00% | 0,00% |
| 506 | 1.5.14.11.1 | **RED DE ALCANTARILLADO** |  | 7d | 2024-01-24 | 2024-02-02 |  | 442d |  | 0,00% | 0,00% | 0,00% | 0,00% |
| 507 | 1.5.14.11.1.1 | Excavación manual para redes y canal monolítico |  | 5d | 2024-01-24 | 2024-01-31 | 465SS | 442d | 0d | 0,00% | 0,00% | 0,00% | 0,00% |
| 508 | 1.5.14.11.1.2 | Instalación de tubería, incluye accesorios. |  | 2d | 2024-01-29 | 2024-01-31 | 507SS+3d | 494d | 0d | 0,00% | 0,00% | 0,00% | 0,00% |
| 509 | 1.5.14.11.1.3 | Rellenos para redes y canal |  | 3d | 2024-01-30 | 2024-02-02 | 508SS+1d | 494d | 69d | 0,00% | 0,00% | 0,00% | 0,00% |
| 510 | 1.5.14.11.1.4 | Instalación de canal monolítico |  | 2d | 2024-01-29 | 2024-01-31 | 507SS+3d | 442d | 0d | 0,00% | 0,00% | 0,00% | 0,00% |

| ID | WBS | Task | Type | Duration | Start | Finish | Predecessors | Total slack | Free slack | % Avance Planeado | % avance planeado en costo (texto) | % Completado (décimales) | % Completado en Costo |
| --- | --- | --- | --- | --- | --- | --- | --- | --- | --- | --- | --- | --- | --- |
| 511 | 1.5.14.12 | **URBANISMO Y PAISAJISMO** |  | 71d | 2024-01-31 | 2024-05-08 |  | 425d | 0d | 0,00% | 0,00% | 0,00% | 0,00% |
| 512 | 1.5.14.12.1 | **ESTRUCTURAS DE CONTENCIÓN PARA URBANISMO** |  | 54d | 2024-01-31 | 2024-04-15 |  | 442d | 11d | 0,00% | 0,00% | 0,00% | 0,00% |
| 513 | 1.5.14.12.1.1 | Construcción de muros en concreto reforzado y mampostería estructural. Incluye otros elementos y construcción de filtro de drenaje tras muro. |  | 32d | 2024-01-31 | 2024-03-13 | 510 | 442d | 0d | 0,00% | 0,00% | 0,00% | 0,00% |
| 514 | 1.5.14.12.1.2 | Construcción de escaleras. |  | 8d | 2024-04-04 | 2024-04-15 | 513FS+14d | 442d | 0d | 0,00% | 0,00% | 0,00% | 0,00% |
| 515 | 1.5.14.12.1.3 | Fin Estructuras de contención para urbanismo | milestone | 0d | 2024-04-15 | 2024-04-15 | 514 | 442d |  | 0,00% | 0,00% | 0,00% | 0,00% |
| 516 | 1.5.14.12.2 | **PAISAJISMO** |  | 2d | 2024-04-10 | 2024-04-11 |  | 425d |  | 0,00% | 0,00% | 0,00% | 0,00% |
| 517 | 1.5.14.12.2.1 | Contenedores de raices, Instalación de grama y hiedras. Incluye tierra negra. |  | 1d | 2024-04-10 | 2024-04-10 | 481 | 425d | 0d | 0,00% | 0,00% | 0,00% | 0,00% |
| 518 | 1.5.14.12.2.2 | Especies arboreas | milestone | 0d | 2024-04-10 | 2024-04-10 | 517SS | 446d | 21d | 0,00% | 0,00% | 0,00% | 0,00% |
| 519 | 1.5.14.12.2.3 | Jardines horizontales |  | 1d | 2024-04-11 | 2024-04-11 | 517 | 444d | 19d | 0,00% | 0,00% | 0,00% | 0,00% |
| 520 | 1.5.14.12.3 | **URBANISMO** |  | 21d | 2024-04-10 | 2024-05-08 |  | 425d |  | 0,00% | 0,00% | 0,00% | 0,00% |
| 521 | 1.5.14.12.3.1 | Instalación de prefabricados. Incluye cañuelas, sardineles, bordillos, pisos en adoquín, tabletas y concreto escobeado. |  | 15d | 2024-04-10 | 2024-04-29 | 517SS | 425d | 0d | 0,00% | 0,00% | 0,00% | 0,00% |
| 522 | 1.5.14.12.3.2 | Mobiliario y elementos independientes |  | 6d | 2024-04-30 | 2024-05-08 | 521 | 425d | 0d | 0,00% | 0,00% | 0,00% | 0,00% |
| 523 | 1.5.14.13 | FIN TORRE 4 | milestone | 0d | 2024-05-08 | 2024-05-08 | 459, 460, 466, 467, 509, 510, 518, 519, 522 | 425d |  | 0,00% | 0,00% | 0,00% | 0,00% |
| 524 | 1.5.14.14 | Torre 4: Hito de Aprobación Para Pago Preliminares, Demoliones, Excavación y Cimentación | milestone | 0d | 2024-05-08 | 2024-05-08 | 457, 464, 468, 480, 461, 511 | 425d |  | 0,00% | 0,00% | 0,00% | 0,00% |
| 525 | 1.5.14.15 | Torre 4: Hito de Aprobación Para Pago Redes | milestone | 0d | 2024-06-27 | 2024-06-27 | 482, 490, 495, 501, 505, 456 | 390d |  | 0,00% | 0,00% | 0,00% | 0,00% |
| 526 | 1.5.14.16 | Torre 4: Hito de Aprobación Para Pago Electromecánico | milestone | 0d | 2024-04-15 | 2024-04-15 | 486 | 442d |  | 0,00% | 0,00% | 0,00% | 0,00% |
| 527 | 1.5.15 | Entrega de predios por parte de IDU al constructor | milestone | 0d | 2023-07-13 | 2023-07-13 | 47 | 438d | 0d | 0,00% | 0,00% | 0,00% | 0,00% |
| 528 | 1.5.16 | **PERMISOS** |  | 1d | 2023-07-13 | 2023-07-14 |  | 532d |  | 0,00% | 0,00% | 0,00% | 0,00% |
| 529 | 1.5.16.1 | Trabajo Nocturno |  | 1d | 2023-07-14 | 2023-07-14 | 527 | 532d | 94d | 0,00% | 0,00% | 0,00% | 0,00% |
| 530 | 1.5.16.2 | Comunicaciones | milestone | 0d | 2023-07-13 | 2023-07-13 | 527 | 639d |  | 0,00% | 0,00% | 0,00% | 0,00% |
| 531 | 1.5.16.3 | Energía (Media Tensión) | milestone | 0d | 2023-07-13 | 2023-07-13 | 527 | 639d |  | 0,00% | 0,00% | 0,00% | 0,00% |
| 532 | 1.5.16.4 | Gestión Institucional | milestone | 0d | 2023-07-13 | 2023-07-13 | 527 | 639d |  | 0,00% | 0,00% | 0,00% | 0,00% |
| 533 | 1.5.16.5 | PMT | milestone | 0d | 2023-07-13 | 2023-07-13 | 527 | 639d |  | 0,00% | 0,00% | 0,00% | 0,00% |
| 534 | 1.5.17 | **TORRE 5** |  | 158d | 2023-11-23 | 2024-07-03 |  | 192d |  | 0,00% | 0,00% | 0,00% | 0,00% |
| 535 | 1.5.17.1 | TRASLADO DE REDES |  | 45d | 2023-11-23 | 2024-01-26 | 527FS+95d, 529 | 438d | 0d | 0,00% | 0,00% | 0,00% | 0,00% |

| ID | WBS | Task | Type | Duration | Start | Finish | Predecessors | Total slack | Free slack | % Avance Planeado | % avance planeado en costo (texto) | % Completado (décimales) | % Completado en Costo |
| --- | --- | --- | --- | --- | --- | --- | --- | --- | --- | --- | --- | --- | --- |
| 536 | 1.5.17.2 | **PRELIMINARES DE OBRA, MOVIMIENTO DE TIERRAS Y RELLENOS** |  | 28d | 2024-01-26 | 2024-03-04 |  | 438d | 52d | 0,00% | 0,00% | 0,00% | 0,00% |
| 537 | 1.5.17.2.1 | Replanteo General |  | 2d | 2024-01-26 | 2024-01-30 | 535 | 438d | 0d | 0,00% | 0,00% | 0,00% | 0,00% |
| 538 | 1.5.17.2.2 | Cerramiento y Señalización |  | 2d | 2024-01-30 | 2024-02-01 | 537 | 495d | 76d | 0,00% | 0,00% | 0,00% | 0,00% |
| 539 | 1.5.17.2.3 | Tala de Especies |  | 2d | 2024-01-30 | 2024-02-01 | 537 | 471d | 0d | 0,00% | 0,00% | 0,00% | 0,00% |
| 540 | 1.5.17.2.4 | **DEMOLICIONES** |  | 24d | 2024-02-01 | 2024-03-04 |  | 471d | 52d | 0,00% | 0,00% | 0,00% | 0,00% |
| 541 | 1.5.17.2.4.1 | Demoliciones de construcciones existentes |  | 24d | 2024-02-01 | 2024-03-04 | 539 | 471d | 0d | 0,00% | 0,00% | 0,00% | 0,00% |
| 542 | 1.5.17.2.4.2 | Fin demoliciones | milestone | 0d | 2024-03-04 | 2024-03-04 | 541 | 471d |  | 0,00% | 0,00% | 0,00% | 0,00% |
| 543 | 1.5.17.3 | **MOVIMIENTO DE TIERRAS** |  | 7d | 2024-01-30 | 2024-02-07 |  | 438d | 71d | 0,00% | 0,00% | 0,00% | 0,00% |
| 544 | 1.5.17.3.1 | Excavación Mecánica En Material Común |  | 5d | 2024-01-30 | 2024-02-05 | 537 | 438d | 0d | 0,00% | 0,00% | 0,00% | 0,00% |
| 545 | 1.5.17.3.2 | Nivelación y Compactación de Subrasante |  | 2d | 2024-02-06 | 2024-02-07 | 544 | 490d | 71d | 0,00% | 0,00% | 0,00% | 0,00% |
| 546 | 1.5.17.3.3 | Transporte y Disposición Final de Escombros en Sitio Autorizado |  | 5d | 2024-01-30 | 2024-02-05 | 544SS | 492d | 73d | 0,00% | 0,00% | 0,00% | 0,00% |
| 547 | 1.5.17.4 | **CIMENTACIÓN** |  | 25d | 2024-03-04 | 2024-04-09 |  | 119d | 27d | 0,00% | 0,00% | 0,00% | 0,00% |
| 548 | 1.5.17.4.1 | **CONSTRUCCIÓN PILOTES** |  | 7d | 2024-03-04 | 2024-03-13 |  | 119d |  | 0,00% | 0,00% | 0,00% | 0,00% |
| 549 | 1.5.17.4.1.1 | Excavación para Pilotes |  | 5d | 2024-03-04 | 2024-03-11 | 470FS+1d | 119d | 0d | 0,00% | 0,00% | 0,00% | 0,00% |
| 550 | 1.5.17.4.1.2 | Acero de Refuerzo |  | 3d | 2024-03-07 | 2024-03-12 | 549FS-2d | 122d | 0d | 0,00% | 0,00% | 0,00% | 0,00% |
| 551 | 1.5.17.4.1.3 | Concreto |  | 3d | 2024-03-08 | 2024-03-13 | 550FS-2d | 122d | 0d | 0,00% | 0,00% | 0,00% | 0,00% |
| 552 | 1.5.17.4.2 | Descabece de Pilotes |  | 2d | 2024-03-13 | 2024-03-15 | 551 | 122d | 0d | 0,00% | 0,00% | 0,00% | 0,00% |
| 553 | 1.5.17.4.3 | **CONSTRUCCIÓN DADOS DE CIMENTACIÓN** |  | 6d | 2024-03-15 | 2024-03-22 |  | 122d |  | 0,00% | 0,00% | 0,00% | 0,00% |
| 554 | 1.5.17.4.3.1 | Acero de Refuerzo |  | 3d | 2024-03-15 | 2024-03-19 | 552 | 122d | 0d | 0,00% | 0,00% | 0,00% | 0,00% |
| 555 | 1.5.17.4.3.2 | Concreto |  | 3d | 2024-03-20 | 2024-03-22 | 554 | 122d | 0d | 0,00% | 0,00% | 0,00% | 0,00% |
| 556 | 1.5.17.4.4 | **PEDESTAL** |  | 10d | 2024-03-23 | 2024-04-09 |  | 122d |  | 0,00% | 0,00% | 0,00% | 0,00% |
| 557 | 1.5.17.4.4.1 | Acero de Refuerzo |  | 5d | 2024-03-23 | 2024-04-03 | 555 | 122d | 0d | 0,00% | 0,00% | 0,00% | 0,00% |
| 558 | 1.5.17.4.4.2 | Concreto |  | 5d | 2024-04-03 | 2024-04-09 | 557 | 122d | 0d | 0,00% | 0,00% | 0,00% | 0,00% |
| 559 | 1.5.17.5 | **RELLENOS** |  | 6d | 2024-04-10 | 2024-04-17 |  | 386d | 21d | 0,00% | 0,00% | 0,00% | 0,00% |
| 560 | 1.5.17.5.1 | Relleno De Material Seleccionado |  | 6d | 2024-04-10 | 2024-04-17 | 558 | 386d | 0d | 0,00% | 0,00% | 0,00% | 0,00% |

| ID | WBS | Task | Type | Duration | Start | Finish | Predecessors | Total slack | Free slack | % Avance Planeado | % avance planeado en costo (texto) | % Completado (décimales) | % Completado en Costo |
| --- | --- | --- | --- | --- | --- | --- | --- | --- | --- | --- | --- | --- | --- |
| 561 | 1.5.17.6 | **PUESTA A TIERRA** |  | 2d | 2024-04-17 | 2024-04-19 |  | 386d | 52d | 0,00% | 0,00% | 0,00% | 0,00% |
| 562 | 1.5.17.6.1 | Instalación Cable de Cobre |  | 1d | 2024-04-17 | 2024-04-18 | 560 | 386d | 0d | 0,00% | 0,00% | 0,00% | 0,00% |
| 563 | 1.5.17.6.2 | Varilla COOPER WELD 5/8" x 2.44m. |  | 1d | 2024-04-18 | 2024-04-19 | 562 | 386d | 0d | 0,00% | 0,00% | 0,00% | 0,00% |
| 564 | 1.5.17.6.3 | Fin Puesta a Tierra | milestone | 0d | 2024-04-19 | 2024-04-19 | 562, 563 | 386d | 0d | 0,00% | 0,00% | 0,00% | 0,00% |
| 565 | 1.5.17.7 | **MONTAJE ELECTROMECÁNICO** |  | 10d | 2024-04-10 | 2024-04-23 |  | 122d | 0d | 0,00% | 0,00% | 0,00% | 0,00% |
| 566 | 1.5.17.7.1 | Montaje Mecánico |  | 5d | 2024-04-10 | 2024-04-16 | 487, 558 | 122d | 0d | 0,00% | 0,00% | 0,00% | 0,00% |
| 567 | 1.5.17.7.2 | Montaje Eléctrico |  | 5d | 2024-04-16 | 2024-04-23 | 566 | 436d | 0d | 0,00% | 0,00% | 0,00% | 0,00% |
| 568 | 1.5.17.7.3 | Fin montaje Electromecánico | milestone | 0d | 2024-04-23 | 2024-04-23 | 566, 567 | 436d |  | 0,00% | 0,00% | 0,00% | 0,00% |
| 569 | 1.5.17.8 | **ALIMENTACIÓN ELÉCTRICA** |  | 7d | 2024-04-19 | 2024-04-29 |  | 386d | 45d | 0,00% | 0,00% | 0,00% | 0,00% |
| 570 | 1.5.17.8.1 | Instalacion de tuberia PVC |  | 5d | 2024-04-19 | 2024-04-26 | 564, 560, 558 | 386d | 0d | 0,00% | 0,00% | 0,00% | 0,00% |
| 571 | 1.5.17.8.2 | Cableado |  | 1d | 2024-04-26 | 2024-04-27 | 570 | 386d | 0d | 0,00% | 0,00% | 0,00% | 0,00% |
| 572 | 1.5.17.8.3 | Instalación de Medidor |  | 1d | 2024-04-29 | 2024-04-29 | 571 | 386d | 0d | 0,00% | 0,00% | 0,00% | 0,00% |
| 573 | 1.5.17.8.4 | Fin Alimentación Eléctrica | milestone | 0d | 2024-04-29 | 2024-04-29 | 572 | 386d | 0d | 0,00% | 0,00% | 0,00% | 0,00% |
| 574 | 1.5.17.9 | **ALUMBRADO PÚBLICO DE TORRE** |  | 5d | 2024-04-19 | 2024-04-26 |  | 390d | 47d | 0,00% | 0,00% | 0,00% | 0,00% |
| 575 | 1.5.17.9.1 | Tubería Eléctrica PVC |  | 5d | 2024-04-19 | 2024-04-26 | 570SS | 390d | 0d | 0,00% | 0,00% | 0,00% | 0,00% |
| 576 | 1.5.17.9.2 | Accesorios |  | 1d | 2024-04-19 | 2024-04-22 | 575SS | 390d | 0d | 0,00% | 0,00% | 0,00% | 0,00% |
| 577 | 1.5.17.9.3 | Cableado |  | 1d | 2024-04-22 | 2024-04-23 | 576 | 390d | 0d | 0,00% | 0,00% | 0,00% | 0,00% |
| 578 | 1.5.17.9.4 | Instalación de A.P. |  | 1d | 2024-04-23 | 2024-04-24 | 577 | 390d | 0d | 0,00% | 0,00% | 0,00% | 0,00% |
| 579 | 1.5.17.9.5 | Fin Alumbrado Público de Torre | milestone | 0d | 2024-04-24 | 2024-04-24 | 578 | 390d | 4d | 0,00% | 0,00% | 0,00% | 0,00% |
| 580 | 1.5.17.10 | **CERTIFICACIONES RETIE Y RETILAP** |  | 45d | 2024-04-30 | 2024-07-03 |  | 386d | 0d | 0,00% | 0,00% | 0,00% | 0,00% |
| 581 | 1.5.17.10.1 | Certificación RETIE |  | 45d | 2024-04-30 | 2024-07-03 | 573, 579, 564, 535 | 386d | 0d | 0,00% | 0,00% | 0,00% | 0,00% |
| 582 | 1.5.17.10.2 | Certificación RETILAP |  | 45d | 2024-04-30 | 2024-07-03 | 581SS | 386d | 0d | 0,00% | 0,00% | 0,00% | 0,00% |
| 583 | 1.5.17.10.3 | Fin Certificaciones RETIE Y RETILAP | milestone | 0d | 2024-07-03 | 2024-07-03 | 582 | 386d |  | 0,00% | 0,00% | 0,00% | 0,00% |
| 584 | 1.5.17.11 | **REDES HIDRÁULICAS EXTERNAS** |  | 7d | 2024-01-30 | 2024-02-07 |  | 438d | 104d | 0,00% | 0,00% | 0,00% | 0,00% |
| 585 | 1.5.17.11.1 | **RED DE ALCANTARILLADO** |  | 7d | 2024-01-30 | 2024-02-07 |  | 438d |  | 0,00% | 0,00% | 0,00% | 0,00% |
| 586 | 1.5.17.11.1.1 | Excavación manual para redes y canal monolítico |  | 5d | 2024-01-30 | 2024-02-05 | 544SS | 438d | 0d | 0,00% | 0,00% | 0,00% | 0,00% |
| 587 | 1.5.17.11.1.2 | Instalación de tubería, incluye accesorios. |  | 2d | 2024-02-02 | 2024-02-05 | 586SS+3d | 490d | 0d | 0,00% | 0,00% | 0,00% | 0,00% |
| 588 | 1.5.17.11.1.3 | Rellenos para redes y canal |  | 3d | 2024-02-05 | 2024-02-07 | 587SS+1d | 490d | 71d | 0,00% | 0,00% | 0,00% | 0,00% |
| 589 | 1.5.17.11.1.4 | Instalación de canal monolítico |  | 2d | 2024-02-02 | 2024-02-05 | 586SS+3d | 438d | 0d | 0,00% | 0,00% | 0,00% | 0,00% |

| ID | WBS | Task | Type | Duration | Start | Finish | Predecessors | Total slack | Free slack | % Avance Planeado | % avance planeado en costo (texto) | % Completado (décimales) | % Completado en Costo |
| --- | --- | --- | --- | --- | --- | --- | --- | --- | --- | --- | --- | --- | --- |
| 590 | 1.5.17.12 | **URBANISMO Y PAISAJISMO** |  | 73d | 2024-02-06 | 2024-05-17 |  | 419d | 0d | 0,00% | 0,00% | 0,00% | 0,00% |
| 591 | 1.5.17.12.1 | **ESTRUCTURAS DE CONTENCIÓN PARA URBANISMO** |  | 54d | 2024-02-06 | 2024-04-19 |  | 438d | 19d | 0,00% | 0,00% | 0,00% | 0,00% |
| 592 | 1.5.17.12.1.1 | Construcción de muros en concreto reforzado y mampostería estructural. Incluye otros elementos y construcción de filtro de drenaje tras muro. |  | 30d | 2024-02-06 | 2024-03-15 | 589 | 438d | 0d | 0,00% | 0,00% | 0,00% | 0,00% |
| 593 | 1.5.17.12.1.2 | Construcción de escaleras y rampas. |  | 10d | 2024-04-08 | 2024-04-19 | 592FS+14d | 438d | 0d | 0,00% | 0,00% | 0,00% | 0,00% |
| 594 | 1.5.17.12.1.3 | Fin Estructuras de contención para urbanismo | milestone | 0d | 2024-04-19 | 2024-04-19 | 593 | 438d |  | 0,00% | 0,00% | 0,00% | 0,00% |
| 595 | 1.5.17.12.2 | **PAISAJISMO** |  | 2d | 2024-04-17 | 2024-04-19 |  | 419d |  | 0,00% | 0,00% | 0,00% | 0,00% |
| 596 | 1.5.17.12.2.1 | Contenedores de raices, Instalación de grama y hiedras. Incluye tierra negra. |  | 1d | 2024-04-17 | 2024-04-18 | 560 | 419d | 0d | 0,00% | 0,00% | 0,00% | 0,00% |
| 597 | 1.5.17.12.2.2 | Especies arboreas | milestone | 0d | 2024-04-17 | 2024-04-17 | 596SS | 440d | 21d | 0,00% | 0,00% | 0,00% | 0,00% |
| 598 | 1.5.17.12.2.3 | Jardines horizontales |  | 1d | 2024-04-18 | 2024-04-19 | 596 | 438d | 19d | 0,00% | 0,00% | 0,00% | 0,00% |
| 599 | 1.5.17.12.3 | **URBANISMO** |  | 21d | 2024-04-17 | 2024-05-17 |  | 419d |  | 0,00% | 0,00% | 0,00% | 0,00% |
| 600 | 1.5.17.12.3.1 | Instalación de prefabricados. Incluye cañuelas, sardineles, bordillos, pisos en adoquín, tabletas y concreto escobeado. |  | 15d | 2024-04-17 | 2024-05-08 | 596SS | 419d | 0d | 0,00% | 0,00% | 0,00% | 0,00% |
| 601 | 1.5.17.12.3.2 | Mobiliario y elementos independientes |  | 6d | 2024-05-08 | 2024-05-17 | 600 | 419d | 0d | 0,00% | 0,00% | 0,00% | 0,00% |
| 602 | 1.5.17.13 | FIN TORRE 5 | milestone | 0d | 2024-05-17 | 2024-05-17 | 538, 539, 545, 546, 588, 589, 597, 598, 601 | 419d |  | 0,00% | 0,00% | 0,00% | 0,00% |
| 603 | 1.5.17.14 | Torre 5: Hito de Aprobación Para Pago Preliminares, Demoliones, Excavación y Cimentación | milestone | 0d | 2024-05-17 | 2024-05-17 | 536, 543, 547, 559, 590, 540, 591 | 419d |  | 0,00% | 0,00% | 0,00% | 0,00% |
| 604 | 1.5.17.15 | Torre 5: Hito de Aprobación Para Pago Redes | milestone | 0d | 2024-07-03 | 2024-07-03 | 535, 561, 569, 574, 580, 584 | 386d |  | 0,00% | 0,00% | 0,00% | 0,00% |
| 605 | 1.5.17.16 | Torre 5: Hito de Aprobación Para Pago Electromecánico | milestone | 0d | 2024-04-23 | 2024-04-23 | 565 | 436d |  | 0,00% | 0,00% | 0,00% | 0,00% |
| 606 | 1.5.18 | Entrega de predios por parte de IDU al constructor | milestone | 0d | 2023-07-13 | 2023-07-13 | 47 | 408d | 0d | 0,00% | 0,00% | 0,00% | 0,00% |
| 607 | 1.5.19 | **PERMISOS** |  | 0d | 2023-07-13 | 2023-07-13 |  | 508d |  | 0,00% | 0,00% | 0,00% | 0,00% |
| 608 | 1.5.19.1 | Trabajo Nocturno | milestone | 0d | 2023-07-13 | 2023-07-13 | 606 | 508d | 100d | 0,00% | 0,00% | 0,00% | 0,00% |
| 609 | 1.5.19.2 | Comunicaciones | milestone | 0d | 2023-07-13 | 2023-07-13 | 606 | 508d | 100d | 0,00% | 0,00% | 0,00% | 0,00% |
| 610 | 1.5.19.3 | Energía (Medía Tensión) | milestone | 0d | 2023-07-13 | 2023-07-13 | 606 | 508d | 100d | 0,00% | 0,00% | 0,00% | 0,00% |
| 611 | 1.5.19.4 | PMT | milestone | 0d | 2023-07-13 | 2023-07-13 | 606 | 508d | 100d | 0,00% | 0,00% | 0,00% | 0,00% |
| 612 | 1.5.20 | **TORRE 6** |  | 222d | 2023-09-07 | 2024-07-15 |  | 254d |  | 0,00% | 0,00% | 0,00% | 0,00% |
| 613 | 1.5.20.1 | TRASLADO DE REDES |  | 45d | 2023-11-30 | 2024-02-02 | 606FS+100d, 608, 609, 610, 611 | 408d | 0d | 0,00% | 0,00% | 0,00% | 0,00% |

| ID | WBS | Task | Type | Duration | Start | Finish | Predecessors | Total slack | Free slack | % Avance Planeado | % avance planeado en costo (texto) | % Completado (décimales) | % Completado en Costo |
| --- | --- | --- | --- | --- | --- | --- | --- | --- | --- | --- | --- | --- | --- |
| 614 | 1.5.20.2 | **PRELIMINARES DE OBRA, MOVIMIENTO DE TIERRAS Y RELLENOS** |  | 110d | 2023-09-07 | 2024-02-07 |  | 490d | 101d | 0,00% | 0,00% | 0,00% | 0,00% |
| 615 | 1.5.20.2.1 | Replanteo General |  | 2d | 2024-02-02 | 2024-02-05 | 613 | 408d | 0d | 0,00% | 0,00% | 0,00% | 0,00% |
| 616 | 1.5.20.2.2 | Cerramiento y Señalización |  | 2d | 2024-02-06 | 2024-02-07 | 615 | 490d | 101d | 0,00% | 0,00% | 0,00% | 0,00% |
| 617 | 1.5.20.2.3 | Tala de Especies |  | 2d | 2024-02-06 | 2024-02-07 | 615 | 490d | 101d | 0,00% | 0,00% | 0,00% | 0,00% |
| 618 | 1.5.20.2.4 | **DEMOLICIONES** |  | 36d | 2023-09-07 | 2023-10-25 |  | 564d | 175d | 0,00% | 0,00% | 0,00% | 0,00% |
| 619 | 1.5.20.2.4.1 | Demoliciones de construcciones existentes |  | 36d | 2023-09-07 | 2023-10-25 | 65 | 564d | 0d | 0,00% | 0,00% | 0,00% | 0,00% |
| 620 | 1.5.20.2.4.2 | Fin demoliciones | milestone | 0d | 2023-10-25 | 2023-10-25 | 619 | 564d |  | 0,00% | 0,00% | 0,00% | 0,00% |
| 621 | 1.5.20.3 | **MOVIMIENTO DE TIERRAS** |  | 7d | 2024-02-06 | 2024-02-14 |  | 408d | 96d | 0,00% | 0,00% | 0,00% | 0,00% |
| 622 | 1.5.20.3.1 | Excavación Mecánica En Material Común |  | 5d | 2024-02-06 | 2024-02-12 | 615 | 408d | 0d | 0,00% | 0,00% | 0,00% | 0,00% |
| 623 | 1.5.20.3.2 | Nivelación y Compactación de Subrasante |  | 2d | 2024-02-12 | 2024-02-14 | 622 | 485d | 96d | 0,00% | 0,00% | 0,00% | 0,00% |
| 624 | 1.5.20.3.3 | Transporte y Disposición Final de Escombros en Sitio Autorizado |  | 5d | 2024-02-06 | 2024-02-12 | 622SS | 487d | 98d | 0,00% | 0,00% | 0,00% | 0,00% |
| 625 | 1.5.20.4 | **CIMENTACIÓN** |  | 25d | 2024-03-12 | 2024-04-17 |  | 119d | 51d | 0,00% | 0,00% | 0,00% | 0,00% |
| 626 | 1.5.20.4.1 | **CONSTRUCCIÓN PILOTES** |  | 7d | 2024-03-12 | 2024-03-20 |  | 119d |  | 0,00% | 0,00% | 0,00% | 0,00% |
| 627 | 1.5.20.4.1.1 | Excavación para Pilotes |  | 5d | 2024-03-12 | 2024-03-18 | 549FS+1d | 119d | 0d | 0,00% | 0,00% | 0,00% | 0,00% |
| 628 | 1.5.20.4.1.2 | Acero de Refuerzo |  | 3d | 2024-03-15 | 2024-03-19 | 627FS-2d | 121d | 0d | 0,00% | 0,00% | 0,00% | 0,00% |
| 629 | 1.5.20.4.1.3 | Concreto |  | 3d | 2024-03-18 | 2024-03-20 | 628FS-2d | 121d | 0d | 0,00% | 0,00% | 0,00% | 0,00% |
| 630 | 1.5.20.4.2 | Descabece de Pilotes |  | 2d | 2024-03-21 | 2024-03-22 | 629 | 121d | 0d | 0,00% | 0,00% | 0,00% | 0,00% |
| 631 | 1.5.20.4.3 | **CONSTRUCCIÓN DADOS DE CIMENTACIÓN** |  | 6d | 2024-03-23 | 2024-04-04 |  | 121d |  | 0,00% | 0,00% | 0,00% | 0,00% |
| 632 | 1.5.20.4.3.1 | Acero de Refuerzo |  | 3d | 2024-03-23 | 2024-04-01 | 630 | 121d | 0d | 0,00% | 0,00% | 0,00% | 0,00% |
| 633 | 1.5.20.4.3.2 | Concreto |  | 3d | 2024-04-01 | 2024-04-04 | 632 | 121d | 0d | 0,00% | 0,00% | 0,00% | 0,00% |
| 634 | 1.5.20.4.4 | **PEDESTAL** |  | 10d | 2024-04-04 | 2024-04-17 |  | 121d |  | 0,00% | 0,00% | 0,00% | 0,00% |
| 635 | 1.5.20.4.4.1 | Acero de Refuerzo |  | 5d | 2024-04-04 | 2024-04-10 | 633 | 121d | 0d | 0,00% | 0,00% | 0,00% | 0,00% |
| 636 | 1.5.20.4.4.2 | Concreto |  | 5d | 2024-04-11 | 2024-04-17 | 635 | 121d | 0d | 0,00% | 0,00% | 0,00% | 0,00% |
| 637 | 1.5.20.5 | **RELLENOS** |  | 6d | 2024-04-17 | 2024-04-25 |  | 380d | 45d | 0,00% | 0,00% | 0,00% | 0,00% |
| 638 | 1.5.20.5.1 | Relleno De Material Seleccionado |  | 6d | 2024-04-17 | 2024-04-25 | 636 | 380d | 0d | 0,00% | 0,00% | 0,00% | 0,00% |

| ID | WBS | Task | Type | Duration | Start | Finish | Predecessors | Total slack | Free slack | % Avance Planeado | % avance planeado en costo (texto) | % Completado (décimales) | % Completado en Costo |
| --- | --- | --- | --- | --- | --- | --- | --- | --- | --- | --- | --- | --- | --- |
| 639 | 1.5.20.6 | **PUESTA A TIERRA** |  | 2d | 2024-04-25 | 2024-04-27 |  | 380d | 54d | 0,00% | 0,00% | 0,00% | 0,00% |
| 640 | 1.5.20.6.1 | Instalación Cable de Cobre |  | 1d | 2024-04-25 | 2024-04-26 | 638 | 380d | 0d | 0,00% | 0,00% | 0,00% | 0,00% |
| 641 | 1.5.20.6.2 | Varilla COOPER WELD 5/8" x 2.44m. |  | 1d | 2024-04-26 | 2024-04-27 | 640 | 380d | 0d | 0,00% | 0,00% | 0,00% | 0,00% |
| 642 | 1.5.20.6.3 | Fin Puesta a Tierra | milestone | 0d | 2024-04-27 | 2024-04-27 | 640, 641 | 380d | 2d | 0,00% | 0,00% | 0,00% | 0,00% |
| 643 | 1.5.20.7 | **MONTAJE ELECTROMECÁNICO** |  | 10d | 2024-04-17 | 2024-04-30 |  | 121d | 0d | 0,00% | 0,00% | 0,00% | 0,00% |
| 644 | 1.5.20.7.1 | Montaje Mecánico |  | 5d | 2024-04-17 | 2024-04-24 | 566, 636 | 121d | 0d | 0,00% | 0,00% | 0,00% | 0,00% |
| 645 | 1.5.20.7.2 | Montaje Eléctrico |  | 5d | 2024-04-24 | 2024-04-30 | 644 | 378d | 0d | 0,00% | 0,00% | 0,00% | 0,00% |
| 646 | 1.5.20.7.3 | Fin montaje Electromecánico | milestone | 0d | 2024-04-30 | 2024-04-30 | 644, 645 | 378d | 0d | 0,00% | 0,00% | 0,00% | 0,00% |
| 647 | 1.5.20.8 | **ALIMENTACIÓN ELÉCTRICA** |  | 7d | 2024-05-02 | 2024-05-10 |  | 378d | 45d | 0,00% | 0,00% | 0,00% | 0,00% |
| 648 | 1.5.20.8.1 | Instalacion de tuberia PVC |  | 5d | 2024-05-02 | 2024-05-08 | 642, 646, 638, 636 | 378d | 0d | 0,00% | 0,00% | 0,00% | 0,00% |
| 649 | 1.5.20.8.2 | Cableado |  | 1d | 2024-05-08 | 2024-05-09 | 648 | 378d | 0d | 0,00% | 0,00% | 0,00% | 0,00% |
| 650 | 1.5.20.8.3 | Instalación de Medidor |  | 1d | 2024-05-09 | 2024-05-10 | 649 | 378d | 0d | 0,00% | 0,00% | 0,00% | 0,00% |
| 651 | 1.5.20.8.4 | Fin Alimentación Eléctrica | milestone | 0d | 2024-05-10 | 2024-05-10 | 650 | 378d | 0d | 0,00% | 0,00% | 0,00% | 0,00% |
| 652 | 1.5.20.9 | **ALUMBRADO PÚBLICO DE TORRE** |  | 5d | 2024-05-02 | 2024-05-08 |  | 382d | 47d | 0,00% | 0,00% | 0,00% | 0,00% |
| 653 | 1.5.20.9.1 | Tubería Eléctrica PVC |  | 5d | 2024-05-02 | 2024-05-08 | 648SS | 382d | 0d | 0,00% | 0,00% | 0,00% | 0,00% |
| 654 | 1.5.20.9.2 | Accesorios |  | 1d | 2024-05-02 | 2024-05-02 | 653SS | 382d | 0d | 0,00% | 0,00% | 0,00% | 0,00% |
| 655 | 1.5.20.9.3 | Cableado |  | 1d | 2024-05-03 | 2024-05-03 | 654 | 382d | 0d | 0,00% | 0,00% | 0,00% | 0,00% |
| 656 | 1.5.20.9.4 | Instalación de A.P. |  | 1d | 2024-05-04 | 2024-05-06 | 655 | 382d | 0d | 0,00% | 0,00% | 0,00% | 0,00% |
| 657 | 1.5.20.9.5 | Fin Alumbrado Público de Torre | milestone | 0d | 2024-05-06 | 2024-05-06 | 656 | 382d | 4d | 0,00% | 0,00% | 0,00% | 0,00% |
| 658 | 1.5.20.10 | **CERTIFICACIONES RETIE Y RETILAP** |  | 114d | 2024-02-06 | 2024-07-15 |  | 378d | 0d | 0,00% | 0,00% | 0,00% | 0,00% |
| 659 | 1.5.20.10.1 | Certificación RETIE |  | 45d | 2024-05-10 | 2024-07-15 | 651, 657, 642, 613 | 378d | 0d | 0,00% | 0,00% | 0,00% | 0,00% |
| 660 | 1.5.20.10.2 | Certificación RETILAP |  | 45d | 2024-05-10 | 2024-07-15 | 659SS | 378d | 0d | 0,00% | 0,00% | 0,00% | 0,00% |
| 661 | 1.5.20.10.3 | Fin Certificaciones RETIE Y RETILAP | milestone | 0d | 2024-07-15 | 2024-07-15 | 660 | 378d |  | 0,00% | 0,00% | 0,00% | 0,00% |
| 662 | 1.5.20.10.4 | **REDES HIDRÁULICAS EXTERNAS** |  | 7d | 2024-02-06 | 2024-02-14 |  | 408d |  | 0,00% | 0,00% | 0,00% | 0,00% |
| 663 | 1.5.20.10.4.1 | **RED DE ALCANTARILLADO** |  | 7d | 2024-02-06 | 2024-02-14 |  | 408d |  | 0,00% | 0,00% | 0,00% | 0,00% |
| 664 | 1.5.20.10.4.1.1 | Excavación manual para redes y canal monolítico |  | 5d | 2024-02-06 | 2024-02-12 | 622SS | 408d | 0d | 0,00% | 0,00% | 0,00% | 0,00% |
| 665 | 1.5.20.10.4.1.2 | Instalación de tubería, incluye accesorios. |  | 2d | 2024-02-09 | 2024-02-12 | 664SS+3d | 485d | 0d | 0,00% | 0,00% | 0,00% | 0,00% |
| 666 | 1.5.20.10.4.1.3 | Rellenos para redes y canal |  | 3d | 2024-02-10 | 2024-02-14 | 665SS+1d | 485d | 96d | 0,00% | 0,00% | 0,00% | 0,00% |
| 667 | 1.5.20.10.4.1.4 | Instalación de canal monolítico |  | 2d | 2024-02-09 | 2024-02-12 | 664SS+3d | 408d | 0d | 0,00% | 0,00% | 0,00% | 0,00% |

| ID | WBS | Task | Type | Duration | Start | Finish | Predecessors | Total slack | Free slack | % Avance Planeado | % avance planeado en costo (texto) | % Completado (décimales) | % Completado en Costo |
| --- | --- | --- | --- | --- | --- | --- | --- | --- | --- | --- | --- | --- | --- |
| 668 | 1.5.20.11 | **URBANISMO Y PAISAJISMO** |  | 98d | 2024-02-12 | 2024-06-28 |  | 389d | 0d | 0,00% | 0,00% | 0,00% | 0,00% |
| 669 | 1.5.20.11.1 | **ESTRUCTURAS DE CONTENCIÓN PARA URBANISMO** |  | 79d | 2024-02-12 | 2024-05-31 |  | 408d | 19d | 0,00% | 0,00% | 0,00% | 0,00% |
| 670 | 1.5.20.11.1.1 | Construcción de muros en concreto reforzado y mampostería estructural. Incluye otros elementos y construcción de filtro de drenaje tras muro. |  | 50d | 2024-02-12 | 2024-04-22 | 667 | 408d | 0d | 0,00% | 0,00% | 0,00% | 0,00% |
| 671 | 1.5.20.11.1.2 | Construcción de escaleras. |  | 15d | 2024-05-10 | 2024-05-31 | 670FS+14d | 408d | 0d | 0,00% | 0,00% | 0,00% | 0,00% |
| 672 | 1.5.20.11.1.3 | Fin Estructuras de contención para urbanismo | milestone | 0d | 2024-05-31 | 2024-05-31 | 671 | 408d |  | 0,00% | 0,00% | 0,00% | 0,00% |
| 673 | 1.5.20.11.2 | **PAISAJISMO** |  | 5d | 2024-04-25 | 2024-05-02 |  | 389d |  | 0,00% | 0,00% | 0,00% | 0,00% |
| 674 | 1.5.20.11.2.1 | Contenedores de raices, Instalación de grama y hiedras. Incluye tierra negra. |  | 2d | 2024-04-25 | 2024-04-27 | 638 | 389d | 0d | 0,00% | 0,00% | 0,00% | 0,00% |
| 675 | 1.5.20.11.2.2 | Especies arboreas |  | 1d | 2024-04-25 | 2024-04-26 | 674SS | 433d | 44d | 0,00% | 0,00% | 0,00% | 0,00% |
| 676 | 1.5.20.11.2.3 | Jardines horizontales |  | 3d | 2024-04-29 | 2024-05-02 | 674 | 429d | 40d | 0,00% | 0,00% | 0,00% | 0,00% |
| 677 | 1.5.20.11.3 | **URBANISMO** |  | 45d | 2024-04-25 | 2024-06-28 |  | 389d |  | 0,00% | 0,00% | 0,00% | 0,00% |
| 678 | 1.5.20.11.3.1 | Instalación de prefabricados. Incluye cañuelas, sardineles, bordillos, pisos en adoquín, tabletas y concreto escobeado. |  | 30d | 2024-04-25 | 2024-06-07 | 674SS | 389d | 0d | 0,00% | 0,00% | 0,00% | 0,00% |
| 679 | 1.5.20.11.3.2 | Mobiliario y elementos independientes |  | 15d | 2024-06-07 | 2024-06-28 | 678 | 389d | 0d | 0,00% | 0,00% | 0,00% | 0,00% |
| 680 | 1.5.20.12 | FIN TORRE 6 | milestone | 0d | 2024-06-28 | 2024-06-28 | 616, 617, 623, 624, 666, 667, 675, 676, 679 | 389d |  | 0,00% | 0,00% | 0,00% | 0,00% |
| 681 | 1.5.20.13 | Torre 6: Hito de Aprobación Para Pago Preliminares, Demoliones, Excavación y Cimentación | milestone | 0d | 2024-06-28 | 2024-06-28 | 614, 621, 625, 637, 668, 618, 669 | 389d |  | 0,00% | 0,00% | 0,00% | 0,00% |
| 682 | 1.5.20.14 | Torre 6: Hito de Aprobación Para Pago Redes | milestone | 0d | 2024-07-15 | 2024-07-15 | 613, 639, 647, 652, 658 | 378d |  | 0,00% | 0,00% | 0,00% | 0,00% |
| 683 | 1.5.20.15 | Torre 6: Hito de Aprobación Para Pago Electromecánico | milestone | 0d | 2024-04-30 | 2024-04-30 | 643 | 430d |  | 0,00% | 0,00% | 0,00% | 0,00% |
| 684 | 1.5.21 | Disponibilidad de predial Torres | milestone | 0d | 2023-07-13 | 2023-07-13 | 47 | 444d | 0d | 0,00% | 0,00% | 0,00% | 0,00% |
| 685 | 1.5.22 | **PERMISOS** |  | 0d | 2023-07-13 | 2023-07-13 |  | 549d |  | 0,00% | 0,00% | 0,00% | 0,00% |
| 686 | 1.5.22.1 | Trabajo Nocturno | milestone | 0d | 2023-07-13 | 2023-07-13 | 684 | 549d | 105d | 0,00% | 0,00% | 0,00% | 0,00% |
| 687 | 1.5.22.2 | Comunicaciones | milestone | 0d | 2023-07-13 | 2023-07-13 | 684 | 549d | 105d | 0,00% | 0,00% | 0,00% | 0,00% |
| 688 | 1.5.23 | **TORRE 7** |  | 162d | 2023-12-07 | 2024-07-23 |  | 194d |  | 0,00% | 0,00% | 0,00% | 0,00% |
| 689 | 1.5.23.1 | TRASLADO DE REDES |  | 45d | 2023-12-07 | 2024-02-08 | 684FS+105d, 686, 687 | 444d | 0d | 0,00% | 0,00% | 0,00% | 0,00% |
| 690 | 1.5.23.2 | **PRELIMINARES DE OBRA, MOVIMIENTO DE TIERRAS Y RELLENOS** |  | 5d | 2024-02-09 | 2024-02-15 |  | 479d | 56d | 0,00% | 0,00% | 0,00% | 0,00% |
| 691 | 1.5.23.2.1 | Replanteo General |  | 3d | 2024-02-09 | 2024-02-13 | 689 | 479d | 0d | 0,00% | 0,00% | 0,00% | 0,00% |
| 692 | 1.5.23.2.2 | Cerramiento y Señalización |  | 2d | 2024-02-13 | 2024-02-15 | 691 | 484d | 5d | 0,00% | 0,00% | 0,00% | 0,00% |
| 693 | 1.5.23.2.3 | Tala de Especies |  | 2d | 2024-02-13 | 2024-02-15 | 691 | 484d | 5d | 0,00% | 0,00% | 0,00% | 0,00% |

| ID | WBS | Task | Type | Duration | Start | Finish | Predecessors | Total slack | Free slack | % Avance Planeado | % avance planeado en costo (texto) | % Completado (décimales) | % Completado en Costo |
| --- | --- | --- | --- | --- | --- | --- | --- | --- | --- | --- | --- | --- | --- |
| 694 | 1.5.23.3 | **MOVIMIENTO DE TIERRAS** |  | 7d | 2024-02-13 | 2024-02-22 |  | 479d | 51d | 0,00% | 0,00% | 0,00% | 0,00% |
| 695 | 1.5.23.3.1 | Excavación Mecánica En Material Común |  | 5d | 2024-02-13 | 2024-02-20 | 691 | 479d | 0d | 0,00% | 0,00% | 0,00% | 0,00% |
| 696 | 1.5.23.3.2 | Nivelación y Compactación de Subrasante |  | 2d | 2024-02-20 | 2024-02-22 | 695 | 479d | 0d | 0,00% | 0,00% | 0,00% | 0,00% |
| 697 | 1.5.23.3.3 | Transporte y Disposición Final de Escombros en Sitio Autorizado |  | 5d | 2024-02-13 | 2024-02-20 | 695SS | 481d | 2d | 0,00% | 0,00% | 0,00% | 0,00% |
| 698 | 1.5.23.4 | **CIMENTACIÓN** |  | 25d | 2024-03-20 | 2024-04-25 |  | 119d | 6d | 0,00% | 0,00% | 0,00% | 0,00% |
| 699 | 1.5.23.4.1 | **CONSTRUCCIÓN PILOTES** |  | 7d | 2024-03-20 | 2024-04-02 |  | 119d |  | 0,00% | 0,00% | 0,00% | 0,00% |
| 700 | 1.5.23.4.1.1 | Excavación para Pilotes |  | 5d | 2024-03-20 | 2024-03-27 | 627FS+1d | 119d | 0d | 0,00% | 0,00% | 0,00% | 0,00% |
| 701 | 1.5.23.4.1.2 | Acero de Refuerzo |  | 3d | 2024-03-23 | 2024-04-01 | 700FS-2d | 120d | 0d | 0,00% | 0,00% | 0,00% | 0,00% |
| 702 | 1.5.23.4.1.3 | Concreto |  | 3d | 2024-03-26 | 2024-04-02 | 701FS-2d | 120d | 0d | 0,00% | 0,00% | 0,00% | 0,00% |
| 703 | 1.5.23.4.2 | Descabece de Pilotes |  | 2d | 2024-04-02 | 2024-04-04 | 702 | 120d | 0d | 0,00% | 0,00% | 0,00% | 0,00% |
| 704 | 1.5.23.4.3 | **CONSTRUCCIÓN DADOS DE CIMENTACIÓN** |  | 6d | 2024-04-04 | 2024-04-11 |  | 120d |  | 0,00% | 0,00% | 0,00% | 0,00% |
| 705 | 1.5.23.4.3.1 | Acero de Refuerzo |  | 3d | 2024-04-04 | 2024-04-08 | 703 | 120d | 0d | 0,00% | 0,00% | 0,00% | 0,00% |
| 706 | 1.5.23.4.3.2 | Concreto |  | 3d | 2024-04-09 | 2024-04-11 | 705 | 120d | 0d | 0,00% | 0,00% | 0,00% | 0,00% |
| 707 | 1.5.23.4.4 | **PEDESTAL** |  | 10d | 2024-04-12 | 2024-04-25 |  | 120d |  | 0,00% | 0,00% | 0,00% | 0,00% |
| 708 | 1.5.23.4.4.1 | Acero de Refuerzo |  | 5d | 2024-04-12 | 2024-04-18 | 706 | 120d | 0d | 0,00% | 0,00% | 0,00% | 0,00% |
| 709 | 1.5.23.4.4.2 | Concreto |  | 5d | 2024-04-18 | 2024-04-25 | 708 | 120d | 0d | 0,00% | 0,00% | 0,00% | 0,00% |
| 710 | 1.5.23.5 | **RELLENOS** |  | 6d | 2024-04-25 | 2024-05-03 |  | 376d | 0d | 0,00% | 0,00% | 0,00% | 0,00% |
| 711 | 1.5.23.5.1 | Relleno De Material Seleccionado |  | 6d | 2024-04-25 | 2024-05-03 | 709 | 376d | 0d | 0,00% | 0,00% | 0,00% | 0,00% |
| 712 | 1.5.23.6 | **PUESTA A TIERRA** |  | 2d | 2024-05-04 | 2024-05-07 |  | 381d | 54d | 0,00% | 0,00% | 0,00% | 0,00% |
| 713 | 1.5.23.6.1 | Instalación Cable de Cobre |  | 1d | 2024-05-04 | 2024-05-06 | 711 | 381d | 0d | 0,00% | 0,00% | 0,00% | 0,00% |
| 714 | 1.5.23.6.2 | Varilla COOPER WELD 5/8" x 2.44m. |  | 1d | 2024-05-06 | 2024-05-07 | 713 | 381d | 0d | 0,00% | 0,00% | 0,00% | 0,00% |
| 715 | 1.5.23.6.3 | Fin Puesta a Tierra | milestone | 0d | 2024-05-07 | 2024-05-07 | 713, 714 | 381d | 9d | 0,00% | 0,00% | 0,00% | 0,00% |
| 716 | 1.5.23.7 | **MONTAJE ELECTROMECÁNICO** |  | 10d | 2024-04-25 | 2024-05-09 |  | 120d | 0d | 0,00% | 0,00% | 0,00% | 0,00% |
| 717 | 1.5.23.7.1 | Montaje Mecánico |  | 5d | 2024-04-25 | 2024-05-02 | 644, 709 | 120d | 0d | 0,00% | 0,00% | 0,00% | 0,00% |
| 718 | 1.5.23.7.2 | Montaje Eléctrico |  | 5d | 2024-05-03 | 2024-05-09 | 717 | 372d | 0d | 0,00% | 0,00% | 0,00% | 0,00% |
| 719 | 1.5.23.7.3 | Fin montaje Electromecánico | milestone | 0d | 2024-05-09 | 2024-05-09 | 717, 718 | 372d | 0d | 0,00% | 0,00% | 0,00% | 0,00% |

| ID | WBS | Task | Type | Duration | Start | Finish | Predecessors | Total slack | Free slack | % Avance Planeado | % avance planeado en costo (texto) | % Completado (décimales) | % Completado en Costo |
| --- | --- | --- | --- | --- | --- | --- | --- | --- | --- | --- | --- | --- | --- |
| 720 | 1.5.23.8 | **ALIMENTACIÓN ELÉCTRICA** |  | 7d | 2024-05-09 | 2024-05-20 |  | 372d | 45d | 0,00% | 0,00% | 0,00% | 0,00% |
| 721 | 1.5.23.8.1 | Instalacion de tuberia PVC |  | 5d | 2024-05-09 | 2024-05-17 | 719, 711, 709 | 372d | 0d | 0,00% | 0,00% | 0,00% | 0,00% |
| 722 | 1.5.23.8.2 | Cableado |  | 1d | 2024-05-17 | 2024-05-18 | 721 | 372d | 0d | 0,00% | 0,00% | 0,00% | 0,00% |
| 723 | 1.5.23.8.3 | Instalación de Medidor |  | 1d | 2024-05-20 | 2024-05-20 | 722 | 372d | 0d | 0,00% | 0,00% | 0,00% | 0,00% |
| 724 | 1.5.23.8.4 | Fin Alimentación Eléctrica | milestone | 0d | 2024-05-20 | 2024-05-20 | 723 | 372d | 0d | 0,00% | 0,00% | 0,00% | 0,00% |
| 725 | 1.5.23.9 | **CERTIFICACIONES RETIE Y RETILAP** |  | 45d | 2024-05-21 | 2024-07-23 |  | 372d | 0d | 0,00% | 0,00% | 0,00% | 0,00% |
| 726 | 1.5.23.9.1 | Certificación RETIE |  | 45d | 2024-05-21 | 2024-07-23 | 724, 715, 689 | 372d | 0d | 0,00% | 0,00% | 0,00% | 0,00% |
| 727 | 1.5.23.9.2 | Certificación RETILAP |  | 45d | 2024-05-21 | 2024-07-23 | 726SS | 372d | 0d | 0,00% | 0,00% | 0,00% | 0,00% |
| 728 | 1.5.23.9.3 | Fin Certificaciones RETIE Y RETILAP | milestone | 0d | 2024-07-23 | 2024-07-23 | 727 | 372d |  | 0,00% | 0,00% | 0,00% | 0,00% |
| 729 | 1.5.23.10 | FIN TORRE 7 | milestone | 0d | 2024-02-22 | 2024-02-22 | 692, 693, 696, 697 | 479d |  | 0,00% | 0,00% | 0,00% | 0,00% |
| 730 | 1.5.23.11 | Torre 7: Hito de Aprobación Para Pago Preliminares y Cimentación | milestone | 0d | 2024-05-03 | 2024-05-03 | 690, 694, 698, 710 | 428d |  | 0,00% | 0,00% | 0,00% | 0,00% |
| 731 | 1.5.23.12 | Torre 7: Hito de Aprobación Para Pago Redes | milestone | 0d | 2024-07-23 | 2024-07-23 | 689, 712, 720, 725 | 372d |  | 0,00% | 0,00% | 0,00% | 0,00% |
| 732 | 1.5.23.13 | Torre 7: Hito de Aprobación Para Pago Electromecánico | milestone | 0d | 2024-05-09 | 2024-05-09 | 716 | 424d |  | 0,00% | 0,00% | 0,00% | 0,00% |
| 733 | 1.5.24 | Entrega de predios por parte de IDU al constructor | milestone | 0d | 2023-07-13 | 2023-07-13 | 47 | 415d | 0d | 0,00% | 0,00% | 0,00% | 0,00% |
| 734 | 1.5.25 | **PERMISOS** |  | 0d | 2023-07-13 | 2023-07-13 |  | 532d |  | 0,00% | 0,00% | 0,00% | 0,00% |
| 735 | 1.5.25.1 | Trabajo Nocturno | milestone | 0d | 2023-07-13 | 2023-07-13 | 733 | 532d | 117d | 0,00% | 0,00% | 0,00% | 0,00% |
| 736 | 1.5.25.2 | Coordinación Acueducto y Alcantarillado | milestone | 0d | 2023-07-13 | 2023-07-13 | 733 | 532d | 117d | 0,00% | 0,00% | 0,00% | 0,00% |
| 737 | 1.5.25.3 | Comunicaciones | milestone | 0d | 2023-07-13 | 2023-07-13 | 733 | 532d | 117d | 0,00% | 0,00% | 0,00% | 0,00% |
| 738 | 1.5.25.4 | Gestión Institucional | milestone | 0d | 2023-07-13 | 2023-07-13 | 733 | 532d | 117d | 0,00% | 0,00% | 0,00% | 0,00% |
| 739 | 1.5.25.5 | PMT | milestone | 0d | 2023-07-13 | 2023-07-13 | 733 | 532d | 117d | 0,00% | 0,00% | 0,00% | 0,00% |
| 740 | 1.5.26 | **TORRE 8** |  | 156d | 2023-12-26 | 2024-07-30 |  | 188d |  | 0,00% | 0,00% | 0,00% | 0,00% |
| 741 | 1.5.26.1 | TRASLADO DE REDES |  | 45d | 2023-12-26 | 2024-02-24 | 733FS+117d, 735, 736, 737, 738, 739 | 415d | 0d | 0,00% | 0,00% | 0,00% | 0,00% |
| 742 | 1.5.26.2 | **PRELIMINARES DE OBRA, MOVIMIENTO DE TIERRAS Y RELLENOS** |  | 28d | 2024-02-26 | 2024-04-05 |  | 415d | 57d | 0,00% | 0,00% | 0,00% | 0,00% |
| 743 | 1.5.26.2.1 | Replanteo General |  | 2d | 2024-02-26 | 2024-02-27 | 741 | 415d | 0d | 0,00% | 0,00% | 0,00% | 0,00% |
| 744 | 1.5.26.2.2 | Cerramiento y Señalización |  | 2d | 2024-02-28 | 2024-02-29 | 743 | 473d | 81d | 0,00% | 0,00% | 0,00% | 0,00% |
| 745 | 1.5.26.2.3 | Tala de Especies |  | 2d | 2024-02-28 | 2024-02-29 | 743 | 449d | 0d | 0,00% | 0,00% | 0,00% | 0,00% |

| ID | WBS | Task | Type | Duration | Start | Finish | Predecessors | Total slack | Free slack | % Avance Planeado | % avance planeado en costo (texto) | % Completado (décimales) | % Completado en Costo |
| --- | --- | --- | --- | --- | --- | --- | --- | --- | --- | --- | --- | --- | --- |
| 746 | 1.5.26.2.4 | **DEMOLICIONES** |  | 24d | 2024-03-01 | 2024-04-05 |  | 449d | 57d | 0,00% | 0,00% | 0,00% | 0,00% |
| 747 | 1.5.26.2.4.1 | Demoliciones de construcciones existentes |  | 24d | 2024-03-01 | 2024-04-05 | 745 | 449d | 0d | 0,00% | 0,00% | 0,00% | 0,00% |
| 748 | 1.5.26.2.4.2 | Fin demoliciones | milestone | 0d | 2024-04-05 | 2024-04-05 | 747 | 449d |  | 0,00% | 0,00% | 0,00% | 0,00% |
| 749 | 1.5.26.3 | **MOVIMIENTO DE TIERRAS** |  | 7d | 2024-02-28 | 2024-03-07 |  | 415d | 76d | 0,00% | 0,00% | 0,00% | 0,00% |
| 750 | 1.5.26.3.1 | Excavación Mecánica En Material Común |  | 5d | 2024-02-28 | 2024-03-05 | 743 | 415d | 0d | 0,00% | 0,00% | 0,00% | 0,00% |
| 751 | 1.5.26.3.2 | Nivelación y Compactación de Subrasante |  | 2d | 2024-03-05 | 2024-03-07 | 750 | 468d | 76d | 0,00% | 0,00% | 0,00% | 0,00% |
| 752 | 1.5.26.3.3 | Transporte y Disposición Final de Escombros en Sitio Autorizado |  | 1d | 2024-02-28 | 2024-02-28 | 750SS | 474d | 82d | 0,00% | 0,00% | 0,00% | 0,00% |
| 753 | 1.5.26.4 | **CIMENTACIÓN** |  | 25d | 2024-04-01 | 2024-05-03 |  | 119d | 36d | 0,00% | 0,00% | 0,00% | 0,00% |
| 754 | 1.5.26.4.1 | **CONSTRUCCIÓN PILOTES** |  | 7d | 2024-04-01 | 2024-04-09 |  | 119d |  | 0,00% | 0,00% | 0,00% | 0,00% |
| 755 | 1.5.26.4.1.1 | Excavación para Pilotes |  | 5d | 2024-04-01 | 2024-04-06 | 700FS+1d | 119d | 0d | 0,00% | 0,00% | 0,00% | 0,00% |
| 756 | 1.5.26.4.1.2 | Acero de Refuerzo |  | 3d | 2024-04-04 | 2024-04-08 | 755FS-2d | 119d | 0d | 0,00% | 0,00% | 0,00% | 0,00% |
| 757 | 1.5.26.4.1.3 | Concreto |  | 3d | 2024-04-05 | 2024-04-09 | 756FS-2d | 119d | 0d | 0,00% | 0,00% | 0,00% | 0,00% |
| 758 | 1.5.26.4.2 | Descabece de Pilotes |  | 2d | 2024-04-10 | 2024-04-11 | 757 | 119d | 0d | 0,00% | 0,00% | 0,00% | 0,00% |
| 759 | 1.5.26.4.3 | **CONSTRUCCIÓN DADOS DE CIMENTACIÓN** |  | 6d | 2024-04-12 | 2024-04-19 |  | 119d |  | 0,00% | 0,00% | 0,00% | 0,00% |
| 760 | 1.5.26.4.3.1 | Acero de Refuerzo |  | 3d | 2024-04-12 | 2024-04-16 | 758 | 119d | 0d | 0,00% | 0,00% | 0,00% | 0,00% |
| 761 | 1.5.26.4.3.2 | Concreto |  | 3d | 2024-04-16 | 2024-04-19 | 760 | 119d | 0d | 0,00% | 0,00% | 0,00% | 0,00% |
| 762 | 1.5.26.4.4 | **PEDESTAL** |  | 10d | 2024-04-19 | 2024-05-03 |  | 119d |  | 0,00% | 0,00% | 0,00% | 0,00% |
| 763 | 1.5.26.4.4.1 | Acero de Refuerzo |  | 5d | 2024-04-19 | 2024-04-26 | 761 | 119d | 0d | 0,00% | 0,00% | 0,00% | 0,00% |
| 764 | 1.5.26.4.4.2 | Concreto |  | 5d | 2024-04-26 | 2024-05-03 | 763 | 119d | 0d | 0,00% | 0,00% | 0,00% | 0,00% |
| 765 | 1.5.26.5 | **RELLENOS** |  | 5d | 2024-05-04 | 2024-05-10 |  | 370d | 31d | 0,00% | 0,00% | 0,00% | 0,00% |
| 766 | 1.5.26.5.1 | Relleno De Material Seleccionado |  | 5d | 2024-05-04 | 2024-05-10 | 764 | 370d | 0d | 0,00% | 0,00% | 0,00% | 0,00% |
| 767 | 1.5.26.6 | **PUESTA A TIERRA** |  | 2d | 2024-05-10 | 2024-05-15 |  | 370d | 55d | 0,00% | 0,00% | 0,00% | 0,00% |
| 768 | 1.5.26.6.1 | Instalación Cable de Cobre |  | 1d | 2024-05-10 | 2024-05-14 | 766 | 370d | 0d | 0,00% | 0,00% | 0,00% | 0,00% |
| 769 | 1.5.26.6.2 | Varilla COOPER WELD 5/8" x 2.44m. |  | 1d | 2024-05-14 | 2024-05-15 | 768 | 376d | 0d | 0,00% | 0,00% | 0,00% | 0,00% |
| 770 | 1.5.26.6.3 | Fin Puesta a Tierra | milestone | 0d | 2024-05-15 | 2024-05-15 | 768, 769 | 376d | 10d | 0,00% | 0,00% | 0,00% | 0,00% |

| ID | WBS | Task | Type | Duration | Start | Finish | Predecessors | Total slack | Free slack | % Avance Planeado | % avance planeado en costo (texto) | % Completado (décimales) | % Completado en Costo |
| --- | --- | --- | --- | --- | --- | --- | --- | --- | --- | --- | --- | --- | --- |
| 771 | 1.5.26.7 | **MONTAJE ELECTROMECÁNICO** |  | 10d | 2024-05-04 | 2024-05-18 |  | 119d | 0d | 0,00% | 0,00% | 0,00% | 0,00% |
| 772 | 1.5.26.7.1 | Montaje Mecánico |  | 5d | 2024-05-04 | 2024-05-10 | 717, 764 | 119d | 0d | 0,00% | 0,00% | 0,00% | 0,00% |
| 773 | 1.5.26.7.2 | Montaje Eléctrico |  | 5d | 2024-05-10 | 2024-05-18 | 772 | 366d | 0d | 0,00% | 0,00% | 0,00% | 0,00% |
| 774 | 1.5.26.7.3 | Fin montaje Electromecánico | milestone | 0d | 2024-05-18 | 2024-05-18 | 772, 773 | 366d | 0d | 0,00% | 0,00% | 0,00% | 0,00% |
| 775 | 1.5.26.8 | **ALIMENTACIÓN ELÉCTRICA** |  | 7d | 2024-05-20 | 2024-05-28 |  | 366d | 45d | 0,00% | 0,00% | 0,00% | 0,00% |
| 776 | 1.5.26.8.1 | Instalacion de tuberia PVC |  | 5d | 2024-05-20 | 2024-05-24 | 774, 768, 764 | 366d | 0d | 0,00% | 0,00% | 0,00% | 0,00% |
| 777 | 1.5.26.8.2 | Cableado |  | 1d | 2024-05-25 | 2024-05-27 | 776 | 366d | 0d | 0,00% | 0,00% | 0,00% | 0,00% |
| 778 | 1.5.26.8.3 | Instalación de Medidor |  | 1d | 2024-05-27 | 2024-05-28 | 777 | 366d | 0d | 0,00% | 0,00% | 0,00% | 0,00% |
| 779 | 1.5.26.8.4 | Fin Alimentación Eléctrica | milestone | 0d | 2024-05-28 | 2024-05-28 | 778 | 366d | 0d | 0,00% | 0,00% | 0,00% | 0,00% |
| 780 | 1.5.26.9 | **ALUMBRADO PÚBLICO DE TORRE** |  | 5d | 2024-05-20 | 2024-05-24 |  | 370d | 47d | 0,00% | 0,00% | 0,00% | 0,00% |
| 781 | 1.5.26.9.1 | Tubería Eléctrica PVC |  | 5d | 2024-05-20 | 2024-05-24 | 776SS | 370d | 0d | 0,00% | 0,00% | 0,00% | 0,00% |
| 782 | 1.5.26.9.2 | Accesorios |  | 1d | 2024-05-20 | 2024-05-20 | 781SS | 370d | 0d | 0,00% | 0,00% | 0,00% | 0,00% |
| 783 | 1.5.26.9.3 | Cableado |  | 1d | 2024-05-21 | 2024-05-21 | 782 | 370d | 0d | 0,00% | 0,00% | 0,00% | 0,00% |
| 784 | 1.5.26.9.4 | Instalación de A.P. |  | 1d | 2024-05-22 | 2024-05-22 | 783 | 370d | 0d | 0,00% | 0,00% | 0,00% | 0,00% |
| 785 | 1.5.26.9.5 | Fin Alumbrado Público de Torre | milestone | 0d | 2024-05-22 | 2024-05-22 | 784 | 370d | 4d | 0,00% | 0,00% | 0,00% | 0,00% |
| 786 | 1.5.26.10 | **CERTIFICACIONES RETIE Y RETILAP** |  | 45d | 2024-05-28 | 2024-07-30 |  | 366d | 0d | 0,00% | 0,00% | 0,00% | 0,00% |
| 787 | 1.5.26.10.1 | Certificación RETIE |  | 45d | 2024-05-28 | 2024-07-30 | 779, 785, 770, 741 | 366d | 0d | 0,00% | 0,00% | 0,00% | 0,00% |
| 788 | 1.5.26.10.2 | Certificación RETILAP |  | 45d | 2024-05-28 | 2024-07-30 | 787SS | 366d | 0d | 0,00% | 0,00% | 0,00% | 0,00% |
| 789 | 1.5.26.10.3 | Fin Certificaciones RETIE Y RETILAP | milestone | 0d | 2024-07-30 | 2024-07-30 | 788 | 366d |  | 0,00% | 0,00% | 0,00% | 0,00% |
| 790 | 1.5.26.11 | **REDES HIDRÁULICAS EXTERNAS** |  | 7d | 2024-02-28 | 2024-03-07 |  | 415d | 102d | 0,00% | 0,00% | 0,00% | 0,00% |
| 791 | 1.5.26.11.1 | **RED DE ALCANTARILLADO** |  | 7d | 2024-02-28 | 2024-03-07 |  | 415d |  | 0,00% | 0,00% | 0,00% | 0,00% |
| 792 | 1.5.26.11.1.1 | Excavación manual para redes y canal monolítico |  | 5d | 2024-02-28 | 2024-03-05 | 750SS | 415d | 0d | 0,00% | 0,00% | 0,00% | 0,00% |
| 793 | 1.5.26.11.1.2 | Instalación de tubería, incluye accesorios. |  | 2d | 2024-03-02 | 2024-03-05 | 792SS+3d | 468d | 0d | 0,00% | 0,00% | 0,00% | 0,00% |
| 794 | 1.5.26.11.1.3 | Rellenos para redes y canal |  | 3d | 2024-03-04 | 2024-03-07 | 793SS+1d | 468d | 76d | 0,00% | 0,00% | 0,00% | 0,00% |
| 795 | 1.5.26.11.1.4 | Instalación de canal monolítico |  | 2d | 2024-03-02 | 2024-03-05 | 792SS+3d | 415d | 0d | 0,00% | 0,00% | 0,00% | 0,00% |

| ID | WBS | Task | Type | Duration | Start | Finish | Predecessors | Total slack | Free slack | % Avance Planeado | % avance planeado en costo (texto) | % Completado (décimales) | % Completado en Costo |
| --- | --- | --- | --- | --- | --- | --- | --- | --- | --- | --- | --- | --- | --- |
| 796 | 1.5.26.12 | **URBANISMO Y PAISAJISMO** |  | 78d | 2024-03-05 | 2024-06-25 |  | 392d | 0d | 0,00% | 0,00% | 0,00% | 0,00% |
| 797 | 1.5.26.12.1 | **ESTRUCTURAS DE CONTENCIÓN PARA URBANISMO** |  | 55d | 2024-03-05 | 2024-05-22 |  | 415d | 23d | 0,00% | 0,00% | 0,00% | 0,00% |
| 798 | 1.5.26.12.1.1 | Construcción de muros en concreto reforzado y mampostería estructural. Incluye otros elementos y construcción de filtro de drenaje tras muro. |  | 36d | 2024-03-05 | 2024-04-25 | 795 | 415d | 0d | 0,00% | 0,00% | 0,00% | 0,00% |
| 799 | 1.5.26.12.1.2 | Construcción de escaleras. |  | 5d | 2024-05-16 | 2024-05-22 | 798FS+14d | 415d | 0d | 0,00% | 0,00% | 0,00% | 0,00% |
| 800 | 1.5.26.12.1.3 | Fin Estructuras de contención para urbanismo | milestone | 0d | 2024-05-22 | 2024-05-22 | 799 | 415d |  | 0,00% | 0,00% | 0,00% | 0,00% |
| 801 | 1.5.26.12.2 | **PAISAJISMO** |  | 3d | 2024-05-10 | 2024-05-16 |  | 392d |  | 0,00% | 0,00% | 0,00% | 0,00% |
| 802 | 1.5.26.12.2.1 | Contenedores de raices, Instalación de grama y hiedras. Incluye tierra negra. |  | 1d | 2024-05-10 | 2024-05-14 | 766 | 392d | 0d | 0,00% | 0,00% | 0,00% | 0,00% |
| 803 | 1.5.26.12.2.2 | Especies arboreas |  | 1d | 2024-05-10 | 2024-05-14 | 802SS | 422d | 30d | 0,00% | 0,00% | 0,00% | 0,00% |
| 804 | 1.5.26.12.2.3 | Jardines horizontales |  | 2d | 2024-05-14 | 2024-05-16 | 802 | 420d | 28d | 0,00% | 0,00% | 0,00% | 0,00% |
| 805 | 1.5.26.12.3 | **URBANISMO** |  | 31d | 2024-05-10 | 2024-06-25 |  | 392d |  | 0,00% | 0,00% | 0,00% | 0,00% |
| 806 | 1.5.26.12.3.1 | Instalación de prefabricados. Incluye cañuelas, sardineles, bordillos, pisos en adoquín, tabletas y concreto escobeado. |  | 18d | 2024-05-10 | 2024-06-06 | 802SS | 392d | 0d | 0,00% | 0,00% | 0,00% | 0,00% |
| 807 | 1.5.26.12.3.2 | Mobiliario y elementos independientes |  | 13d | 2024-06-06 | 2024-06-25 | 806 | 392d | 0d | 0,00% | 0,00% | 0,00% | 0,00% |
| 808 | 1.5.26.13 | FIN TORRE 8 | milestone | 0d | 2024-06-25 | 2024-06-25 | 744, 745, 751, 752, 794, 795, 803, 804, 807 | 392d |  | 0,00% | 0,00% | 0,00% | 0,00% |
| 809 | 1.5.26.14 | Torre 8: Hito de Aprobación Para Pago Preliminares, Demoliones, Excavación y Cimentación | milestone | 0d | 2024-06-25 | 2024-06-25 | 742, 749, 753, 765, 796, 746, 797 | 392d |  | 0,00% | 0,00% | 0,00% | 0,00% |
| 810 | 1.5.26.15 | Torre 8: Hito de Aprobación Para Pago Redes | milestone | 0d | 2024-07-30 | 2024-07-30 | 741, 767, 775, 780, 786, 790 | 366d |  | 0,00% | 0,00% | 0,00% | 0,00% |
| 811 | 1.5.26.16 | Torre 8: Hito de Aprobación Para Pago Electromecánico | milestone | 0d | 2024-05-18 | 2024-05-18 | 771 | 418d |  | 0,00% | 0,00% | 0,00% | 0,00% |
| 812 | 1.5.27 | Entrega de predios por parte de IDU al constructor | milestone | 0d | 2023-07-13 | 2023-07-13 | 47 | 454d | 0d | 0,00% | 0,00% | 0,00% | 0,00% |
| 813 | 1.5.28 | **PERMISOS** |  | 3d | 2023-07-13 | 2023-07-18 |  | 546d |  | 0,00% | 0,00% | 0,00% | 0,00% |
| 814 | 1.5.28.1 | Trabajo Nocturno | milestone | 0d | 2023-07-13 | 2023-07-13 | 812 | 549d | 95d | 0,00% | 0,00% | 0,00% | 0,00% |
| 815 | 1.5.28.2 | Silvicultura les |  | 3d | 2023-07-14 | 2023-07-18 | 812 | 546d | 92d | 0,00% | 0,00% | 0,00% | 0,00% |
| 816 | 1.5.28.3 | Energía (Baja Tensión) |  | 1d | 2023-07-14 | 2023-07-14 | 812 | 548d | 94d | 0,00% | 0,00% | 0,00% | 0,00% |
| 817 | 1.5.28.4 | PMT |  | 1d | 2023-07-14 | 2023-07-14 | 812 | 548d | 94d | 0,00% | 0,00% | 0,00% | 0,00% |
| 818 | 1.5.29 | **TORRE 9** |  | 212d | 2023-10-26 | 2024-08-20 |  | 186d |  | 0,00% | 0,00% | 0,00% | 0,00% |
| 819 | 1.5.29.1 | TRASLADO DE REDES |  | 45d | 2023-11-23 | 2024-01-26 | 812FS+95d, 814, 815, 816, 817 | 454d | 0d | 0,00% | 0,00% | 0,00% | 0,00% |

| ID | WBS | Task | Type | Duration | Start | Finish | Predecessors | Total slack | Free slack | % Avance Planeado | % avance planeado en costo (texto) | % Completado (décimales) | % Completado en Costo |
| --- | --- | --- | --- | --- | --- | --- | --- | --- | --- | --- | --- | --- | --- |
| 820 | 1.5.29.2 | **PRELIMINARES DE OBRA, MOVIMIENTO DE TIERRAS Y RELLENOS** |  | 5d | 2024-01-26 | 2024-02-02 |  | 461d | 33d | 0,00% | 0,00% | 0,00% | 0,00% |
| 821 | 1.5.29.2.1 | Replanteo General |  | 3d | 2024-01-26 | 2024-01-31 | 819 | 461d | 0d | 0,00% | 0,00% | 0,00% | 0,00% |
| 822 | 1.5.29.2.2 | Cerramiento y Señalización |  | 2d | 2024-01-31 | 2024-02-02 | 821 | 494d | 5d | 0,00% | 0,00% | 0,00% | 0,00% |
| 823 | 1.5.29.2.3 | Tala de Especies |  | 2d | 2024-01-31 | 2024-02-02 | 821 | 494d | 5d | 0,00% | 0,00% | 0,00% | 0,00% |
| 824 | 1.5.29.3 | **MOVIMIENTO DE TIERRAS** |  | 7d | 2024-01-31 | 2024-02-08 |  | 461d | 28d | 0,00% | 0,00% | 0,00% | 0,00% |
| 825 | 1.5.29.3.1 | Excavación Mecánica En Material Común |  | 5d | 2024-01-31 | 2024-02-06 | 821 | 461d | 0d | 0,00% | 0,00% | 0,00% | 0,00% |
| 826 | 1.5.29.3.2 | Nivelación y Compactación de Subrasante |  | 2d | 2024-02-07 | 2024-02-08 | 825 | 489d | 0d | 0,00% | 0,00% | 0,00% | 0,00% |
| 827 | 1.5.29.3.3 | Transporte y Disposición Final de Escombros en Sitio Autorizado |  | 5d | 2024-01-31 | 2024-02-06 | 825SS | 491d | 2d | 0,00% | 0,00% | 0,00% | 0,00% |
| 828 | 1.5.29.4 | **CIMENTACIÓN** |  | 25d | 2023-10-26 | 2023-11-30 |  | 186d | 78d | 0,00% | 0,00% | 0,00% | 0,00% |
| 829 | 1.5.29.4.1 | **CONSTRUCCIÓN PILOTES** |  | 7d | 2023-10-26 | 2023-11-03 |  | 186d |  | 0,00% | 0,00% | 0,00% | 0,00% |
| 830 | 1.5.29.4.1.1 | Excavación para Pilotes |  | 5d | 2023-10-26 | 2023-11-01 | 992FS+1d | 186d | 0d | 0,00% | 0,00% | 0,00% | 0,00% |
| 831 | 1.5.29.4.1.2 | Acero de Refuerzo |  | 3d | 2023-10-30 | 2023-11-02 | 830FS-2d | 235d | 0d | 0,00% | 0,00% | 0,00% | 0,00% |
| 832 | 1.5.29.4.1.3 | Concreto |  | 3d | 2023-10-31 | 2023-11-03 | 831FS-2d | 235d | 0d | 0,00% | 0,00% | 0,00% | 0,00% |
| 833 | 1.5.29.4.2 | Descabece de Pilotes |  | 2d | 2023-11-03 | 2023-11-08 | 832 | 235d | 0d | 0,00% | 0,00% | 0,00% | 0,00% |
| 834 | 1.5.29.4.3 | **CONSTRUCCIÓN DADOS DE CIMENTACIÓN** |  | 6d | 2023-11-08 | 2023-11-16 |  | 235d |  | 0,00% | 0,00% | 0,00% | 0,00% |
| 835 | 1.5.29.4.3.1 | Acero de Refuerzo |  | 3d | 2023-11-08 | 2023-11-11 | 833 | 235d | 0d | 0,00% | 0,00% | 0,00% | 0,00% |
| 836 | 1.5.29.4.3.2 | Concreto |  | 3d | 2023-11-14 | 2023-11-16 | 835 | 235d | 0d | 0,00% | 0,00% | 0,00% | 0,00% |
| 837 | 1.5.29.4.4 | **PEDESTAL** |  | 10d | 2023-11-17 | 2023-11-30 |  | 235d |  | 0,00% | 0,00% | 0,00% | 0,00% |
| 838 | 1.5.29.4.4.1 | Acero de Refuerzo |  | 5d | 2023-11-17 | 2023-11-23 | 836 | 235d | 0d | 0,00% | 0,00% | 0,00% | 0,00% |
| 839 | 1.5.29.4.4.2 | Concreto |  | 5d | 2023-11-23 | 2023-11-30 | 838 | 235d | 0d | 0,00% | 0,00% | 0,00% | 0,00% |
| 840 | 1.5.29.5 | **RELLENOS** |  | 6d | 2023-11-30 | 2023-12-07 |  | 481d | 72d | 0,00% | 0,00% | 0,00% | 0,00% |
| 841 | 1.5.29.5.1 | Relleno De Material Seleccionado |  | 6d | 2023-11-30 | 2023-12-07 | 839 | 481d | 0d | 0,00% | 0,00% | 0,00% | 0,00% |
| 842 | 1.5.29.6 | **PUESTA A TIERRA** |  | 2d | 2023-12-09 | 2023-12-12 |  | 486d | 179d | 0,00% | 0,00% | 0,00% | 0,00% |
| 843 | 1.5.29.6.1 | Instalación Cable de Cobre |  | 1d | 2023-12-09 | 2023-12-11 | 841 | 486d | 0d | 0,00% | 0,00% | 0,00% | 0,00% |
| 844 | 1.5.29.6.2 | Varilla COOPER WELD 5/8" x 2.44m. |  | 1d | 2023-12-11 | 2023-12-12 | 843 | 486d | 0d | 0,00% | 0,00% | 0,00% | 0,00% |
| 845 | 1.5.29.6.3 | Fin Puesta a Tierra | milestone | 0d | 2023-12-12 | 2023-12-12 | 843, 844 | 486d | 134d | 0,00% | 0,00% | 0,00% | 0,00% |

| ID | WBS | Task | Type | Duration | Start | Finish | Predecessors | Total slack | Free slack | % Avance Planeado | % avance planeado en costo (texto) | % Completado (décimales) | % Completado en Costo |
| --- | --- | --- | --- | --- | --- | --- | --- | --- | --- | --- | --- | --- | --- |
| 846 | 1.5.29.7 | **MONTAJE ELECTROMECÁNICO** |  | 19d | 2024-05-10 | 2024-06-07 |  | 119d | 0d | 0,00% | 0,00% | 0,00% | 0,00% |
| 847 | 1.5.29.7.1 | Montaje Mecánico |  | 10d | 2024-05-10 | 2024-05-24 | 772, 839 | 119d | 0d | 0,00% | 0,00% | 0,00% | 0,00% |
| 848 | 1.5.29.7.2 | Montaje Eléctrico |  | 9d | 2024-05-25 | 2024-06-07 | 847 | 352d | 0d | 0,00% | 0,00% | 0,00% | 0,00% |
| 849 | 1.5.29.7.3 | Fin montaje Electromecánico | milestone | 0d | 2024-06-07 | 2024-06-07 | 847, 848 | 352d | 0d | 0,00% | 0,00% | 0,00% | 0,00% |
| 850 | 1.5.29.8 | **ALIMENTACIÓN ELÉCTRICA** |  | 7d | 2024-06-07 | 2024-06-18 |  | 352d | 45d | 0,00% | 0,00% | 0,00% | 0,00% |
| 851 | 1.5.29.8.1 | Instalacion de tuberia PVC |  | 5d | 2024-06-07 | 2024-06-14 | 849, 841, 839 | 352d | 0d | 0,00% | 0,00% | 0,00% | 0,00% |
| 852 | 1.5.29.8.2 | Cableado |  | 1d | 2024-06-15 | 2024-06-17 | 851 | 352d | 0d | 0,00% | 0,00% | 0,00% | 0,00% |
| 853 | 1.5.29.8.3 | Instalación de Medidor |  | 1d | 2024-06-17 | 2024-06-18 | 852 | 352d | 0d | 0,00% | 0,00% | 0,00% | 0,00% |
| 854 | 1.5.29.8.4 | Fin Alimentación Eléctrica | milestone | 0d | 2024-06-18 | 2024-06-18 | 853 | 352d | 0d | 0,00% | 0,00% | 0,00% | 0,00% |
| 855 | 1.5.29.9 | **CERTIFICACIONES RETIE Y RETILAP** |  | 45d | 2024-06-18 | 2024-08-20 |  | 352d | 0d | 0,00% | 0,00% | 0,00% | 0,00% |
| 856 | 1.5.29.9.1 | Certificación RETIE |  | 45d | 2024-06-18 | 2024-08-20 | 854, 845, 819 | 352d | 0d | 0,00% | 0,00% | 0,00% | 0,00% |
| 857 | 1.5.29.9.2 | Certificación RETILAP |  | 45d | 2024-06-18 | 2024-08-20 | 856SS | 352d | 0d | 0,00% | 0,00% | 0,00% | 0,00% |
| 858 | 1.5.29.9.3 | Fin Certificaciones RETIE Y RETILAP | milestone | 0d | 2024-08-20 | 2024-08-20 | 857 | 352d |  | 0,00% | 0,00% | 0,00% | 0,00% |
| 859 | 1.5.29.10 | **REDES HIDRÁULICAS EXTERNAS** |  | 7d | 2024-01-31 | 2024-02-08 |  | 461d | 137d | 0,00% | 0,00% | 0,00% | 0,00% |
| 860 | 1.5.29.10.1 | **RED DE ALCANTARILLADO** |  | 7d | 2024-01-31 | 2024-02-08 |  | 461d |  | 0,00% | 0,00% | 0,00% | 0,00% |
| 861 | 1.5.29.10.1.1 | Excavación manual para redes y canal monolítico |  | 5d | 2024-01-31 | 2024-02-06 | 825SS | 461d | 0d | 0,00% | 0,00% | 0,00% | 0,00% |
| 862 | 1.5.29.10.1.2 | Instalación de tubería, incluye accesorios. |  | 2d | 2024-02-05 | 2024-02-06 | 861SS+3d | 489d | 0d | 0,00% | 0,00% | 0,00% | 0,00% |
| 863 | 1.5.29.10.1.3 | Rellenos para redes y canal |  | 3d | 2024-02-06 | 2024-02-08 | 862SS+1d | 489d | 0d | 0,00% | 0,00% | 0,00% | 0,00% |
| 864 | 1.5.29.10.1.4 | Instalación de canal monolítico |  | 2d | 2024-02-05 | 2024-02-06 | 861SS+3d | 461d | 0d | 0,00% | 0,00% | 0,00% | 0,00% |
| 865 | 1.5.29.11 | **URBANISMO Y PAISAJISMO** |  | 72d | 2023-12-09 | 2024-03-16 |  | 461d | 0d | 0,00% | 0,00% | 0,00% | 0,00% |
| 866 | 1.5.29.11.1 | **ESTRUCTURAS DE CONTENCIÓN PARA URBANISMO** |  | 30d | 2024-02-07 | 2024-03-16 |  | 461d | 0d | 0,00% | 0,00% | 0,00% | 0,00% |
| 867 | 1.5.29.11.1.1 | Construcción de muros en concreto reforzado y mampostería estructural. Incluye otros elementos y construcción de filtro de drenaje tras muro. |  | 30d | 2024-02-07 | 2024-03-16 | 864 | 461d | 0d | 0,00% | 0,00% | 0,00% | 0,00% |
| 868 | 1.5.29.11.1.2 | Fin Estructuras de contención para urbanismo | milestone | 0d | 2024-03-16 | 2024-03-16 | 867 | 461d |  | 0,00% | 0,00% | 0,00% | 0,00% |
| 869 | 1.5.29.11.2 | **URBANISMO** |  | 20d | 2023-12-09 | 2024-01-09 |  | 513d |  | 0,00% | 0,00% | 0,00% | 0,00% |
| 870 | 1.5.29.11.2.1 | Instalación de prefabricados. Incluye cañuelas, sardineles, bordillos, pisos en adoquín, tabletas y concreto escobeado. |  | 10d | 2023-12-09 | 2023-12-22 | 841 | 513d | 0d | 0,00% | 0,00% | 0,00% | 0,00% |
| 871 | 1.5.29.11.2.2 | Mobiliario y elementos independientes |  | 10d | 2023-12-22 | 2024-01-09 | 870 | 513d | 24d | 0,00% | 0,00% | 0,00% | 0,00% |
| 872 | 1.5.29.12 | FIN TORRE 9 | milestone | 0d | 2024-02-08 | 2024-02-08 | 822, 823, 826, 827, 863, 864, 871 | 489d |  | 0,00% | 0,00% | 0,00% | 0,00% |
| 873 | 1.5.29.13 | Torre 9: Hito de Aprobación Para Pago Preliminares y Cimentación | milestone | 0d | 2024-03-16 | 2024-03-16 | 820, 824, 828, 840, 865, 866 | 461d |  | 0,00% | 0,00% | 0,00% | 0,00% |
| 874 | 1.5.29.14 | Torre 9: Hito de Aprobación Para Pago Redes | milestone | 0d | 2024-08-20 | 2024-08-20 | 819, 842, 850, 855, 859 | 352d |  | 0,00% | 0,00% | 0,00% | 0,00% |
| 875 | 1.5.29.15 | Torre 9: Hito de Aprobación Para Pago Electromecánico | milestone | 0d | 2024-06-07 | 2024-06-07 | 846 | 404d |  | 0,00% | 0,00% | 0,00% | 0,00% |
| 876 | 1.5.30 | Entrega de predios por parte de IDU al constructor | milestone | 0d | 2023-07-13 | 2023-07-13 | 47 | 449d | 0d | 0,00% | 0,00% | 0,00% | 0,00% |

| ID | WBS | Task | Type | Duration | Start | Finish | Predecessors | Total slack | Free slack | % Avance Planeado | % avance planeado en costo (texto) | % Completado (décimales) | % Completado en Costo |
| --- | --- | --- | --- | --- | --- | --- | --- | --- | --- | --- | --- | --- | --- |
| 877 | 1.5.31 | **PERMISOS** |  | 0d | 2023-07-13 | 2023-07-13 |  | 549d |  | 0,00% | 0,00% | 0,00% | 0,00% |
| 878 | 1.5.31.1 | Trabajo Nocturno | milestone | 0d | 2023-07-13 | 2023-07-13 | 876 | 549d | 100d | 0,00% | 0,00% | 0,00% | 0,00% |
| 879 | 1.5.31.2 | Coordinación Acueducto y Alcantarillado | milestone | 0d | 2023-07-13 | 2023-07-13 | 876 | 549d | 100d | 0,00% | 0,00% | 0,00% | 0,00% |
| 880 | 1.5.31.3 | Comunicaciones | milestone | 0d | 2023-07-13 | 2023-07-13 | 876 | 549d | 100d | 0,00% | 0,00% | 0,00% | 0,00% |
| 881 | 1.5.31.4 | Energía (Baja Tensión) | milestone | 0d | 2023-07-13 | 2023-07-13 | 876 | 549d | 100d | 0,00% | 0,00% | 0,00% | 0,00% |
| 882 | 1.5.31.5 | PMT | milestone | 0d | 2023-07-13 | 2023-07-13 | 876 | 549d | 100d | 0,00% | 0,00% | 0,00% | 0,00% |
| 883 | 1.5.32 | **TORRE 10** |  | 207d | 2023-11-02 | 2024-08-21 |  | 186d |  | 0,00% | 0,00% | 0,00% | 0,00% |
| 884 | 1.5.32.1 | TRASLADO DE REDES |  | 45d | 2023-11-30 | 2024-02-02 | 876FS+100d, 878, 879, 880, 881, 882 | 449d | 0d | 0,00% | 0,00% | 0,00% | 0,00% |
| 885 | 1.5.32.2 | **PRELIMINARES DE OBRA, MOVIMIENTO DE TIERRAS Y RELLENOS** |  | 4d | 2024-02-05 | 2024-02-08 |  | 484d | 5d | 0,00% | 0,00% | 0,00% | 0,00% |
| 886 | 1.5.32.2.1 | Replanteo General |  | 2d | 2024-02-05 | 2024-02-06 | 884FS+1d | 484d | 0d | 0,00% | 0,00% | 0,00% | 0,00% |
| 887 | 1.5.32.2.2 | Cerramiento y Señalización |  | 2d | 2024-02-07 | 2024-02-08 | 886 | 489d | 5d | 0,00% | 0,00% | 0,00% | 0,00% |
| 888 | 1.5.32.2.3 | Tala de Especies |  | 2d | 2024-02-07 | 2024-02-08 | 886 | 489d | 5d | 0,00% | 0,00% | 0,00% | 0,00% |
| 889 | 1.5.32.3 | **MOVIMIENTO DE TIERRAS** |  | 7d | 2024-02-07 | 2024-02-15 |  | 484d | 0d | 0,00% | 0,00% | 0,00% | 0,00% |
| 890 | 1.5.32.3.1 | Excavación Mecánica En Material Común |  | 5d | 2024-02-07 | 2024-02-13 | 886 | 484d | 0d | 0,00% | 0,00% | 0,00% | 0,00% |
| 891 | 1.5.32.3.2 | Nivelación y Compactación de Subrasante |  | 2d | 2024-02-13 | 2024-02-15 | 890 | 484d | 0d | 0,00% | 0,00% | 0,00% | 0,00% |
| 892 | 1.5.32.3.3 | Transporte y Disposición Final de Escombros en Sitio Autorizado |  | 5d | 2024-02-07 | 2024-02-13 | 890SS | 486d | 2d | 0,00% | 0,00% | 0,00% | 0,00% |
| 893 | 1.5.32.4 | **CIMENTACIÓN** |  | 25d | 2023-11-02 | 2023-12-07 |  | 186d | 49d | 0,00% | 0,00% | 0,00% | 0,00% |
| 894 | 1.5.32.4.1 | **CONSTRUCCIÓN PILOTES** |  | 7d | 2023-11-02 | 2023-11-14 |  | 186d |  | 0,00% | 0,00% | 0,00% | 0,00% |
| 895 | 1.5.32.4.1.1 | Excavación para Pilotes |  | 5d | 2023-11-02 | 2023-11-10 | 830FS+1d | 186d | 0d | 0,00% | 0,00% | 0,00% | 0,00% |
| 896 | 1.5.32.4.1.2 | Acero de Refuerzo |  | 3d | 2023-11-08 | 2023-11-11 | 895FS-2d | 239d | 0d | 0,00% | 0,00% | 0,00% | 0,00% |
| 897 | 1.5.32.4.1.3 | Concreto |  | 3d | 2023-11-09 | 2023-11-14 | 896FS-2d | 239d | 0d | 0,00% | 0,00% | 0,00% | 0,00% |
| 898 | 1.5.32.4.2 | Descabece de Pilotes |  | 2d | 2023-11-15 | 2023-11-16 | 897 | 239d | 0d | 0,00% | 0,00% | 0,00% | 0,00% |
| 899 | 1.5.32.4.3 | **CONSTRUCCIÓN DADOS DE CIMENTACIÓN** |  | 6d | 2023-11-17 | 2023-11-24 |  | 239d |  | 0,00% | 0,00% | 0,00% | 0,00% |
| 900 | 1.5.32.4.3.1 | Acero de Refuerzo |  | 3d | 2023-11-17 | 2023-11-21 | 898 | 239d | 0d | 0,00% | 0,00% | 0,00% | 0,00% |
| 901 | 1.5.32.4.3.2 | Concreto |  | 3d | 2023-11-21 | 2023-11-24 | 900 | 239d | 0d | 0,00% | 0,00% | 0,00% | 0,00% |

| ID | WBS | Task | Type | Duration | Start | Finish | Predecessors | Total slack | Free slack | % Avance Planeado | % avance planeado en costo (texto) | % Completado (décimales) | % Completado en Costo |
| --- | --- | --- | --- | --- | --- | --- | --- | --- | --- | --- | --- | --- | --- |
| 902 | 1.5.32.4.4 | **PEDESTAL** |  | 10d | 2023-11-24 | 2023-12-07 |  | 239d |  | 0,00% | 0,00% | 0,00% | 0,00% |
| 903 | 1.5.32.4.4.1 | Acero de Refuerzo |  | 5d | 2023-11-24 | 2023-12-01 | 901 | 239d | 0d | 0,00% | 0,00% | 0,00% | 0,00% |
| 904 | 1.5.32.4.4.2 | Concreto |  | 5d | 2023-12-01 | 2023-12-07 | 903 | 239d | 0d | 0,00% | 0,00% | 0,00% | 0,00% |
| 905 | 1.5.32.5 | **RELLENOS** |  | 6d | 2023-12-09 | 2023-12-18 |  | 475d | 43d | 0,00% | 0,00% | 0,00% | 0,00% |
| 906 | 1.5.32.5.1 | Relleno De Material Seleccionado |  | 6d | 2023-12-09 | 2023-12-18 | 904 | 475d | 0d | 0,00% | 0,00% | 0,00% | 0,00% |
| 907 | 1.5.32.6 | **PUESTA A TIERRA** |  | 2d | 2023-12-18 | 2023-12-20 |  | 480d | 174d | 0,00% | 0,00% | 0,00% | 0,00% |
| 908 | 1.5.32.6.1 | Instalación Cable de Cobre |  | 1d | 2023-12-18 | 2023-12-19 | 906 | 480d | 0d | 0,00% | 0,00% | 0,00% | 0,00% |
| 909 | 1.5.32.6.2 | Varilla COOPER WELD 5/8" x 2.44m. |  | 1d | 2023-12-19 | 2023-12-20 | 908 | 480d | 0d | 0,00% | 0,00% | 0,00% | 0,00% |
| 910 | 1.5.32.6.3 | Fin Puesta a Tierra | milestone | 0d | 2023-12-20 | 2023-12-20 | 908, 909 | 480d | 129d | 0,00% | 0,00% | 0,00% | 0,00% |
| 911 | 1.5.32.7 | **MONTAJE ELECTROMECÁNICO** |  | 10d | 2024-05-25 | 2024-06-08 |  | 119d | 0d | 0,00% | 0,00% | 0,00% | 0,00% |
| 912 | 1.5.32.7.1 | Montaje Mecánico |  | 5d | 2024-05-25 | 2024-05-31 | 847, 904 | 119d | 0d | 0,00% | 0,00% | 0,00% | 0,00% |
| 913 | 1.5.32.7.2 | Montaje Eléctrico |  | 5d | 2024-05-31 | 2024-06-08 | 912 | 351d | 0d | 0,00% | 0,00% | 0,00% | 0,00% |
| 914 | 1.5.32.7.3 | Fin montaje Electromecánico | milestone | 0d | 2024-06-08 | 2024-06-08 | 912, 913 | 351d | 0d | 0,00% | 0,00% | 0,00% | 0,00% |
| 915 | 1.5.32.8 | **ALIMENTACIÓN ELÉCTRICA** |  | 7d | 2024-06-11 | 2024-06-19 |  | 351d | 45d | 0,00% | 0,00% | 0,00% | 0,00% |
| 916 | 1.5.32.8.1 | Instalacion de tuberia PVC |  | 5d | 2024-06-11 | 2024-06-17 | 914, 906, 904 | 351d | 0d | 0,00% | 0,00% | 0,00% | 0,00% |
| 917 | 1.5.32.8.2 | Cableado |  | 1d | 2024-06-17 | 2024-06-18 | 916 | 351d | 0d | 0,00% | 0,00% | 0,00% | 0,00% |
| 918 | 1.5.32.8.3 | Instalación de Medidor |  | 1d | 2024-06-18 | 2024-06-19 | 917 | 351d | 0d | 0,00% | 0,00% | 0,00% | 0,00% |
| 919 | 1.5.32.8.4 | Fin Alimentación Eléctrica | milestone | 0d | 2024-06-19 | 2024-06-19 | 918 | 351d | 0d | 0,00% | 0,00% | 0,00% | 0,00% |
| 920 | 1.5.32.9 | **CERTIFICACIONES RETIE Y RETILAP** |  | 45d | 2024-06-19 | 2024-08-21 |  | 351d | 0d | 0,00% | 0,00% | 0,00% | 0,00% |
| 921 | 1.5.32.9.1 | Certificación RETIE |  | 45d | 2024-06-19 | 2024-08-21 | 919, 910, 884 | 351d | 0d | 0,00% | 0,00% | 0,00% | 0,00% |
| 922 | 1.5.32.9.2 | Certificación RETILAP |  | 45d | 2024-06-19 | 2024-08-21 | 921SS | 351d | 0d | 0,00% | 0,00% | 0,00% | 0,00% |
| 923 | 1.5.32.9.3 | Fin Certificaciones RETIE Y RETILAP | milestone | 0d | 2024-08-21 | 2024-08-21 | 922 | 351d |  | 0,00% | 0,00% | 0,00% | 0,00% |
| 924 | 1.5.32.10 | FIN TORRE 10 | milestone | 0d | 2024-02-15 | 2024-02-15 | 887, 888, 891, 892 | 484d |  | 0,00% | 0,00% | 0,00% | 0,00% |
| 925 | 1.5.32.11 | Torre 10: Hito de Aprobación Para Pago Preliminares y Cimentación | milestone | 0d | 2024-02-15 | 2024-02-15 | 885, 889, 893, 905 | 484d |  | 0,00% | 0,00% | 0,00% | 0,00% |
| 926 | 1.5.32.12 | Torre 10: Hito de Aprobación Para Pago Redes | milestone | 0d | 2024-08-21 | 2024-08-21 | 884, 907, 915, 920 | 351d |  | 0,00% | 0,00% | 0,00% | 0,00% |
| 927 | 1.5.32.13 | Torre 10: Hito de Aprobación Para Pago Electromecánico | milestone | 0d | 2024-06-08 | 2024-06-08 | 911 | 403d |  | 0,00% | 0,00% | 0,00% | 0,00% |
| 928 | 1.5.33 | Entrega de predios por parte de IDU al constructor | milestone | 0d | 2023-07-13 | 2023-07-13 | 47 | 444d | 0d | 0,00% | 0,00% | 0,00% | 0,00% |

| ID | WBS | Task | Type | Duration | Start | Finish | Predecessors | Total slack | Free slack | % Avance Planeado | % avance planeado en costo (texto) | % Completado (décimales) | % Completado en Costo |
| --- | --- | --- | --- | --- | --- | --- | --- | --- | --- | --- | --- | --- | --- |
| 929 | 1.5.34 | **PERMISOS** |  | 0d | 2023-07-13 | 2023-07-13 |  | 639d |  | 0,00% | 0,00% | 0,00% | 0,00% |
| 930 | 1.5.34.1 | Trabajo Nocturno | milestone | 0d | 2023-07-13 | 2023-07-13 | 928 | 639d |  | 0,00% | 0,00% | 0,00% | 0,00% |
| 931 | 1.5.34.2 | Energía (Baja Tensión) | milestone | 0d | 2023-07-13 | 2023-07-13 | 928 | 639d |  | 0,00% | 0,00% | 0,00% | 0,00% |
| 932 | 1.5.35 | **TORRES 11** |  | 154d | 2023-11-14 | 2024-06-17 |  | 186d |  | 0,00% | 0,00% | 0,00% | 0,00% |
| 933 | 1.5.35.1 | TRASLADO DE REDES |  | 45d | 2023-12-07 | 2024-02-08 | 928FS+105d | 444d | 0d | 0,00% | 0,00% | 0,00% | 0,00% |
| 934 | 1.5.35.2 | **PRELIMINARES DE OBRA, MOVIMIENTO DE TIERRAS Y RELLENOS** |  | 4d | 2024-02-09 | 2024-02-14 |  | 480d | 5d | 0,00% | 0,00% | 0,00% | 0,00% |
| 935 | 1.5.35.2.1 | Replanteo General |  | 2d | 2024-02-09 | 2024-02-12 | 933 | 480d | 0d | 0,00% | 0,00% | 0,00% | 0,00% |
| 936 | 1.5.35.2.2 | Cerramiento y Señalización |  | 2d | 2024-02-12 | 2024-02-14 | 935 | 485d | 5d | 0,00% | 0,00% | 0,00% | 0,00% |
| 937 | 1.5.35.2.3 | Tala de Especies |  | 2d | 2024-02-12 | 2024-02-14 | 935 | 485d | 5d | 0,00% | 0,00% | 0,00% | 0,00% |
| 938 | 1.5.35.3 | **MOVIMIENTO DE TIERRAS** |  | 7d | 2024-02-12 | 2024-02-21 |  | 480d | 0d | 0,00% | 0,00% | 0,00% | 0,00% |
| 939 | 1.5.35.3.1 | Excavación Mecánica En Material Común |  | 5d | 2024-02-12 | 2024-02-19 | 935 | 480d | 0d | 0,00% | 0,00% | 0,00% | 0,00% |
| 940 | 1.5.35.3.2 | Nivelación y Compactación de Subrasante |  | 2d | 2024-02-19 | 2024-02-21 | 939 | 480d | 0d | 0,00% | 0,00% | 0,00% | 0,00% |
| 941 | 1.5.35.3.3 | Transporte y Disposición Final de Escombros en Sitio Autorizado |  | 5d | 2024-02-12 | 2024-02-19 | 939SS | 482d | 2d | 0,00% | 0,00% | 0,00% | 0,00% |
| 942 | 1.5.35.4 | **CIMENTACIÓN** |  | 25d | 2023-11-14 | 2023-12-18 |  | 186d | 47d | 0,00% | 0,00% | 0,00% | 0,00% |
| 943 | 1.5.35.4.1 | **CONSTRUCCIÓN PILOTES** |  | 7d | 2023-11-14 | 2023-11-22 |  | 186d |  | 0,00% | 0,00% | 0,00% | 0,00% |
| 944 | 1.5.35.4.1.1 | Excavación para Pilotes |  | 5d | 2023-11-14 | 2023-11-20 | 895FS+1d | 186d | 0d | 0,00% | 0,00% | 0,00% | 0,00% |
| 945 | 1.5.35.4.1.2 | Acero de Refuerzo |  | 3d | 2023-11-17 | 2023-11-21 | 944FS-2d | 238d | 0d | 0,00% | 0,00% | 0,00% | 0,00% |
| 946 | 1.5.35.4.1.3 | Concreto |  | 3d | 2023-11-18 | 2023-11-22 | 945FS-2d | 238d | 0d | 0,00% | 0,00% | 0,00% | 0,00% |
| 947 | 1.5.35.4.2 | Descabece de Pilotes |  | 2d | 2023-11-22 | 2023-11-24 | 946 | 238d | 0d | 0,00% | 0,00% | 0,00% | 0,00% |
| 948 | 1.5.35.4.3 | **CONSTRUCCIÓN DADOS DE CIMENTACIÓN** |  | 6d | 2023-11-24 | 2023-12-02 |  | 238d |  | 0,00% | 0,00% | 0,00% | 0,00% |
| 949 | 1.5.35.4.3.1 | Acero de Refuerzo |  | 3d | 2023-11-24 | 2023-11-29 | 947 | 238d | 0d | 0,00% | 0,00% | 0,00% | 0,00% |
| 950 | 1.5.35.4.3.2 | Concreto |  | 3d | 2023-11-29 | 2023-12-02 | 949 | 238d | 0d | 0,00% | 0,00% | 0,00% | 0,00% |
| 951 | 1.5.35.4.4 | **PEDESTAL** |  | 10d | 2023-12-04 | 2023-12-18 |  | 238d |  | 0,00% | 0,00% | 0,00% | 0,00% |
| 952 | 1.5.35.4.4.1 | Acero de Refuerzo |  | 5d | 2023-12-04 | 2023-12-11 | 950 | 238d | 0d | 0,00% | 0,00% | 0,00% | 0,00% |
| 953 | 1.5.35.4.4.2 | Concreto |  | 5d | 2023-12-11 | 2023-12-18 | 952 | 238d | 0d | 0,00% | 0,00% | 0,00% | 0,00% |

| ID | WBS | Task | Type | Duration | Start | Finish | Predecessors | Total slack | Free slack | % Avance Planeado | % avance planeado en costo (texto) | % Completado (décimales) | % Completado en Costo |
| --- | --- | --- | --- | --- | --- | --- | --- | --- | --- | --- | --- | --- | --- |
| 954 | 1.5.35.5 | **RELLENOS** |  | 6d | 2023-12-18 | 2023-12-26 |  | 474d | 41d | 0,00% | 0,00% | 0,00% | 0,00% |
| 955 | 1.5.35.5.1 | Relleno De Material Seleccionado |  | 6d | 2023-12-18 | 2023-12-26 | 953 | 474d | 0d | 0,00% | 0,00% | 0,00% | 0,00% |
| 956 | 1.5.35.6 | **PUESTA A TIERRA** |  | 2d | 2023-12-27 | 2023-12-28 |  | 474d | 75d | 0,00% | 0,00% | 0,00% | 0,00% |
| 957 | 1.5.35.6.1 | Instalación Cable de Cobre |  | 1d | 2023-12-27 | 2023-12-27 | 955 | 474d | 0d | 0,00% | 0,00% | 0,00% | 0,00% |
| 958 | 1.5.35.6.2 | Varilla COOPER WELD 5/8" x 2.44m. |  | 1d | 2023-12-28 | 2023-12-28 | 957 | 474d | 0d | 0,00% | 0,00% | 0,00% | 0,00% |
| 959 | 1.5.35.6.3 | Fin Puesta a Tierra | milestone | 0d | 2023-12-28 | 2023-12-28 | 957, 958 | 474d | 30d | 0,00% | 0,00% | 0,00% | 0,00% |
| 960 | 1.5.35.7 | **MONTAJE ELECTROMECÁNICO** |  | 10d | 2024-05-31 | 2024-06-17 |  | 119d | 0d | 0,00% | 0,00% | 0,00% | 0,00% |
| 961 | 1.5.35.7.1 | Montaje Mecánico |  | 5d | 2024-05-31 | 2024-06-08 | 912, 953 | 119d | 0d | 0,00% | 0,00% | 0,00% | 0,00% |
| 962 | 1.5.35.7.2 | Montaje Eléctrico |  | 5d | 2024-06-11 | 2024-06-17 | 961 | 119d | 0d | 0,00% | 0,00% | 0,00% | 0,00% |
| 963 | 1.5.35.7.3 | Fin montaje Electromecánico | milestone | 0d | 2024-06-17 | 2024-06-17 | 961, 962 | 119d |  | 0,00% | 0,00% | 0,00% | 0,00% |
| 964 | 1.5.35.8 | **CERTIFICACIONES RETIE Y RETILAP** |  | 45d | 2024-02-09 | 2024-04-11 |  | 444d | 0d | 0,00% | 0,00% | 0,00% | 0,00% |
| 965 | 1.5.35.8.1 | Certificación RETIE |  | 45d | 2024-02-09 | 2024-04-11 | 959, 933 | 444d | 0d | 0,00% | 0,00% | 0,00% | 0,00% |
| 966 | 1.5.35.8.2 | Certificación RETILAP |  | 45d | 2024-02-09 | 2024-04-11 | 965SS | 444d | 0d | 0,00% | 0,00% | 0,00% | 0,00% |
| 967 | 1.5.35.8.3 | Fin Certificaciones RETIE Y RETILAP | milestone | 0d | 2024-04-11 | 2024-04-11 | 966 | 444d |  | 0,00% | 0,00% | 0,00% | 0,00% |
| 968 | 1.5.35.9 | FIN TORRE 11 | milestone | 0d | 2024-02-21 | 2024-02-21 | 936, 937, 940, 941 | 480d |  | 0,00% | 0,00% | 0,00% | 0,00% |
| 969 | 1.5.35.10 | Torre 11: Hito de Aprobación Para Pago Preliminares y Cimentación | milestone | 0d | 2024-02-21 | 2024-02-21 | 934, 938, 942, 954 | 480d |  | 0,00% | 0,00% | 0,00% | 0,00% |
| 970 | 1.5.35.11 | Torre 11: Hito de Aprobación Para Pago Redes | milestone | 0d | 2024-04-11 | 2024-04-11 | 933, 956, 964 | 444d |  | 0,00% | 0,00% | 0,00% | 0,00% |
| 971 | 1.5.35.12 | Torre 11: Hito de Aprobación Para Pago Electromecánico | milestone | 0d | 2024-06-17 | 2024-06-17 | 960 | 398d |  | 0,00% | 0,00% | 0,00% | 0,00% |
| 972 | 1.5.36 | Entrega de predios por parte de IDU al constructor- Estación La Victoria | milestone | 0d | 2023-07-13 | 2023-07-13 | 47 | 2d | 0d | 0,00% | 0,00% | 0,00% | 0,00% |
| 973 | 1.5.37 | **PERMISOS** |  | 0d | 2023-07-13 | 2023-07-13 |  | 20d |  | 0,00% | 0,00% | 0,00% | 0,00% |
| 974 | 1.5.37.1 | Trabajo Nocturno | milestone | 0d | 2023-07-13 | 2023-07-13 | 972 | 20d | 18d | 0,00% | 0,00% | 0,00% | 0,00% |
| 975 | 1.5.37.2 | Coordinación Acueducto y Alcantarillado | milestone | 0d | 2023-07-13 | 2023-07-13 | 972 | 20d | 18d | 0,00% | 0,00% | 0,00% | 0,00% |
| 976 | 1.5.37.3 | PMT | milestone | 0d | 2023-07-13 | 2023-07-13 | 972 | 20d | 18d | 0,00% | 0,00% | 0,00% | 0,00% |
| 977 | 1.5.38 | **2. ESTACIÓN MOTRIZ, INTERMEDIA - LA VICTORIA** |  | 447d | 2023-08-09 | 2025-04-23 |  | 2d |  | 0,00% | 0,00% | 0,00% | 0,00% |
| 978 | 1.5.38.1 | **PRELIMINARES DE OBRA, MOVIMIENTO DE TIERRAS Y RELLENOS** |  | 29d | 2023-08-09 | 2023-09-18 |  | 2d |  | 0,00% | 0,00% | 0,00% | 0,00% |
| 979 | 1.5.38.1.1 | Replanteo General |  | 5d | 2023-08-09 | 2023-08-16 | 972FS+18d, 974, 975, 976 | 2d | 0d | 0,00% | 0,00% | 0,00% | 0,00% |
| 980 | 1.5.38.1.2 | Cerramiento y Señalización |  | 5d | 2023-08-16 | 2023-08-23 | 979 | 2d | 0d | 0,00% | 0,00% | 0,00% | 0,00% |
| 981 | 1.5.38.1.3 | Tala de Especies |  | 5d | 2023-08-24 | 2023-08-30 | 980 | 2d | 0d | 0,00% | 0,00% | 0,00% | 0,00% |
| 982 | 1.5.38.1.4 | Campamento |  | 5d | 2023-08-30 | 2023-09-06 | 981 | 2d | 0d | 0,00% | 0,00% | 0,00% | 0,00% |
| 983 | 1.5.38.1.5 | Descapote a Maquina en Material Común, E=0.20mts |  | 9d | 2023-09-06 | 2023-09-18 | 982 | 2d | 0d | 0,00% | 0,00% | 0,00% | 0,00% |

| ID | WBS | Task | Duration | Start | Finish | Predecessors | Total slack | Free slack | % Avance Planeado | % avance planeado en costo (texto) | % Completado (décimales) | % Completado en Costo |
| --- | --- | --- | --- | --- | --- | --- | --- | --- | --- | --- | --- | --- |
| 984 | 1.5.38.2 | **DEMOLICIONES** | 18d | 2023-09-18 | 2023-10-11 |  | 2d |  | 0,00% | 0,00% | 0,00% | 0,00% |
| 985 | 1.5.38.2.1 | Demolición Estructuras de Concreto | 18d | 2023-09-18 | 2023-10-11 | 983 | 2d | 0d | 0,00% | 0,00% | 0,00% | 0,00% |
| 986 | 1.5.38.3 | **MOVIMIENTO DE TIERRAS** | 58d | 2023-09-18 | 2023-12-06 |  | 438d | 46d | 0,00% | 0,00% | 0,00% | 0,00% |
| 987 | 1.5.38.3.1 | Excavación Mecánica En Material Común | 40d | 2023-09-18 | 2023-11-11 | 983 | 438d | 0d | 0,00% | 0,00% | 0,00% | 0,00% |
| 988 | 1.5.38.3.2 | Nivelación y Compactación de Subrasante | 18d | 2023-11-14 | 2023-12-06 | 987 | 438d | 203d | 0,00% | 0,00% | 0,00% | 0,00% |
| 989 | 1.5.38.3.3 | Transporte y Disposición Final de Escombros en Autorizado | 40d | 2023-09-18 | 2023-11-11 | 987SS | 552d | 378d | 0,00% | 0,00% | 0,00% | 0,00% |
| 990 | 1.5.38.4 | **CIMENTACIÓN - MASTILES ESTACIÓN MOTRIZ** | 93d | 2023-09-21 | 2024-01-31 |  | 2d |  | 0,00% | 0,00% | 0,00% | 0,00% |
| 991 | 1.5.38.4.1 | **CONSTRUCCIÓN PILOTES** | 52d | 2023-09-21 | 2023-12-02 |  | 2d |  | 0,00% | 0,00% | 0,00% | 0,00% |
| 992 | 1.5.38.4.1.1 | Excavación mecánica para pilotes | 24d | 2023-09-21 | 2023-10-24 | 985SS+3d | 2d | 0d | 0,00% | 0,00% | 0,00% | 0,00% |
| 993 | 1.5.38.4.1.2 | Transporte y Disposición Final de Escombros en Sitio Autorizado | 24d | 2023-09-21 | 2023-10-24 | 992FF | 469d | 234d | 0,00% | 0,00% | 0,00% | 0,00% |
| 994 | 1.5.38.4.1.3 | Acero de Refuerzo | 24d | 2023-10-26 | 2023-11-29 | 992SS+1d, 1005SS+1d | 80d | 0d | 0,00% | 0,00% | 0,00% | 0,00% |
| 995 | 1.5.38.4.1.4 | Concreto | 12d | 2023-11-14 | 2023-11-29 | 994FF | 80d | 0d | 0,00% | 0,00% | 0,00% | 0,00% |
| 996 | 1.5.38.4.1.5 | Descabece de Pilotes | 7d | 2023-11-23 | 2023-12-02 | 995SS+8d | 441d | 206d | 0,00% | 0,00% | 0,00% | 0,00% |
| 997 | 1.5.38.4.2 | **CONSTRUCCIÓN DADOS DE CIMENTACIÓN** | 14d | 2023-11-29 | 2023-12-19 |  | 80d |  | 0,00% | 0,00% | 0,00% | 0,00% |
| 998 | 1.5.38.4.2.1 | Excavación mecánica para dados | 10d | 2023-11-29 | 2023-12-13 | 995 | 80d | 0d | 0,00% | 0,00% | 0,00% | 0,00% |
| 999 | 1.5.38.4.2.2 | Transporte y Disposición Final de Escombros en Sitio Autorizado | 10d | 2023-11-29 | 2023-12-13 | 998FF | 434d | 199d | 0,00% | 0,00% | 0,00% | 0,00% |
| 1000 | 1.5.38.4.2.3 | Acero de Refuerzo | 10d | 2023-12-01 | 2023-12-15 | 998SS+2d | 80d | 0d | 0,00% | 0,00% | 0,00% | 0,00% |
| 1001 | 1.5.38.4.2.4 | Concreto | 10d | 2023-12-05 | 2023-12-19 | 1000SS+2d | 80d | 0d | 0,00% | 0,00% | 0,00% | 0,00% |
| 1002 | 1.5.38.4.3 | Vigas de Cimentación en Concreto | 24d | 2023-12-28 | 2024-01-31 | 1001SS+16d | 80d | 0d | 0,00% | 0,00% | 0,00% | 0,00% |
| 1003 | 1.5.38.5 | **CIMENTACIÓN - ESTACIÓN MOTRIZ** | 84d | 2023-10-11 | 2024-02-07 |  | 11d | 2d | 0,00% | 0,00% | 0,00% | 0,00% |
| 1004 | 1.5.38.5.1 | **CONSTRUCCIÓN PILOTES** | 77d | 2023-10-23 | 2024-02-07 |  | 4d |  | 0,00% | 0,00% | 0,00% | 0,00% |
| 1005 | 1.5.38.5.1.1 | Excavación mecánica para pilotes | 56d | 2023-10-25 | 2024-01-13 | 992 | 2d | 0d | 0,00% | 0,00% | 0,00% | 0,00% |
| 1006 | 1.5.38.5.1.2 | Transporte y Disposición Final de Escombros en Sitio Autorizado | 58d | 2023-10-23 | 2024-01-13 | 1005FF | 413d | 178d | 0,00% | 0,00% | 0,00% | 0,00% |
| 1007 | 1.5.38.5.1.3 | Acero de Refuerzo | 56d | 2023-10-27 | 2024-01-16 | 1005SS+2d | 2d | 0d | 0,00% | 0,00% | 0,00% | 0,00% |
| 1008 | 1.5.38.5.1.4 | Concreto | 58d | 2023-10-27 | 2024-01-18 | 1007SS | 394d | 0d | 0,00% | 0,00% | 0,00% | 0,00% |
| 1009 | 1.5.38.5.1.5 | Descabece de Pilotes | 7d | 2024-01-30 | 2024-02-07 | 1008FS+8d | 394d | 159d | 0,00% | 0,00% | 0,00% | 0,00% |

| ID | WBS | Task | Duration | Start | Finish | Predecessors | Total slack | Free slack | % Avance Planeado | % avance planeado en costo (texto) | % Completado (décimales) | % Completado en Costo |
| --- | --- | --- | --- | --- | --- | --- | --- | --- | --- | --- | --- | --- |
| 1010 | 1.5.38.5.2 | **CONSTRUCCIÓN MURO PANTALLA PRE-EXCAVADO** | 21d | 2023-10-11 | 2023-11-10 |  | 457d |  | 0,00% | 0,00% | 0,00% | 0,00% |
| 1011 | 1.5.38.5.2.1 | Excavación mecánica para muro | 15d | 2023-10-11 | 2023-11-01 | 985 | 457d | 0d | 0,00% | 0,00% | 0,00% | 0,00% |
| 1012 | 1.5.38.5.2.2 | Transporte y Disposición Final de Escombros en Sitio Autorizado | 15d | 2023-10-11 | 2023-11-01 | 1011FF | 559d |  | 0,00% | 0,00% | 0,00% | 0,00% |
| 1013 | 1.5.38.5.2.3 | Acero de Refuerzo | 15d | 2023-10-20 | 2023-11-10 | 1011SS+6d | 457d | 0d | 0,00% | 0,00% | 0,00% | 0,00% |
| 1014 | 1.5.38.5.2.4 | Concreto | 15d | 2023-10-20 | 2023-11-10 | 1013SS | 457d | 222d | 0,00% | 0,00% | 0,00% | 0,00% |
| 1015 | 1.5.38.5.3 | **CONSTRUCCIÓN DADOS DE CIMENTACIÓN** | 10d | 2024-01-04 | 2024-01-18 |  | 2d |  | 0,00% | 0,00% | 0,00% | 0,00% |
| 1016 | 1.5.38.5.3.1 | Excavación mecánica para dados | 7d | 2024-01-10 | 2024-01-18 | 1008FF | 409d | 0d | 0,00% | 0,00% | 0,00% | 0,00% |
| 1017 | 1.5.38.5.3.2 | Transporte y Disposición Final de Escombros en Sitio Autorizado | 7d | 2024-01-10 | 2024-01-18 | 1016FF | 409d | 174d | 0,00% | 0,00% | 0,00% | 0,00% |
| 1018 | 1.5.38.5.3.3 | Acero de Refuerzo | 7d | 2024-01-04 | 2024-01-15 | 1007FS-8d | 2d | 0d | 0,00% | 0,00% | 0,00% | 0,00% |
| 1019 | 1.5.38.5.3.4 | Concreto | 7d | 2024-01-04 | 2024-01-15 | 1018SS | 2d | 0d | 0,00% | 0,00% | 0,00% | 0,00% |
| 1020 | 1.5.38.6 | **RELLENOS** | 20d | 2024-01-16 | 2024-02-09 |  | 2d | 0d | 0,00% | 0,00% | 0,00% | 0,00% |
| 1021 | 1.5.38.6.1 | Relleno en Subbase Granular | 20d | 2024-01-16 | 2024-02-09 | 1019 | 2d | 0d | 0,00% | 0,00% | 0,00% | 0,00% |
| 1022 | 1.5.38.7 | **PUESTA A TIERRA** | 10d | 2024-02-10 | 2024-02-23 |  | 382d | 293d | 0,00% | 0,00% | 0,00% | 0,00% |
| 1023 | 1.5.38.7.1 | Instalación Cable de Cobre | 10d | 2024-02-10 | 2024-02-23 | 1021, 1019, 1002 | 382d | 0d | 0,00% | 0,00% | 0,00% | 0,00% |
| 1024 | 1.5.38.7.2 | Varilla COOPER WELD 5/8" x 2.44m. | 10d | 2024-02-10 | 2024-02-23 | 1023SS | 382d | 147d | 0,00% | 0,00% | 0,00% | 0,00% |
| 1025 | 1.5.38.8 | **ESTRUCTURA ESTACIÓN MOTRIZ LA VICTORIA** | 177d | 2024-01-16 | 2024-09-17 |  | 22d |  | 0,00% | 0,00% | 0,00% | 0,00% |
| 1026 | 1.5.38.8.1 | **ESTRUCTURA MÁSTIL** | 41d | 2024-01-16 | 2024-03-08 |  | 371d |  | 0,00% | 0,00% | 0,00% | 0,00% |
| 1027 | 1.5.38.8.1.1 | Acero de Refuerzo Mástil | 36d | 2024-01-16 | 2024-03-01 | 1019 | 371d | 0d | 0,00% | 0,00% | 0,00% | 0,00% |
| 1028 | 1.5.38.8.1.2 | Concreto para Mástil | 36d | 2024-01-22 | 2024-03-08 | 1027SS+5d | 371d | 136d | 0,00% | 0,00% | 0,00% | 0,00% |
| 1029 | 1.5.38.8.2 | **ESTRUCTURA PLACA CONTRAPISO Y NIVEL DE EQUIPOS** | 14d | 2024-02-10 | 2024-02-28 |  | 2d |  | 0,00% | 0,00% | 0,00% | 0,00% |
| 1030 | 1.5.38.8.2.1 | Acero de Refuerzo | 12d | 2024-02-10 | 2024-02-26 | 1021 | 2d | 0d | 0,00% | 0,00% | 0,00% | 0,00% |
| 1031 | 1.5.38.8.2.2 | Concreto | 12d | 2024-02-13 | 2024-02-28 | 1030SS+2d | 2d | 0d | 0,00% | 0,00% | 0,00% | 0,00% |
| 1032 | 1.5.38.8.3 | **COLUMNAS NIVEL DE EQUIPOS** | 21d | 2024-02-22 | 2024-03-20 |  | 8d |  | 0,00% | 0,00% | 0,00% | 0,00% |
| 1033 | 1.5.38.8.3.1 | Acero de Refuerzo | 18d | 2024-02-22 | 2024-03-16 | 1031SS+7d | 8d | 0d | 0,00% | 0,00% | 0,00% | 0,00% |
| 1034 | 1.5.38.8.3.2 | Concreto para Columnas | 18d | 2024-02-27 | 2024-03-20 | 1033SS+3d | 8d | 6d | 0,00% | 0,00% | 0,00% | 0,00% |

| ID | WBS | Task | Duration | Start | Finish | Predecessors | Total slack | Free slack | % Avance Planeado | % avance planeado en costo (texto) | % Completado (décimales) | % Completado en Costo |
| --- | --- | --- | --- | --- | --- | --- | --- | --- | --- | --- | --- | --- |
| 1035 | 1.5.38.8.4 | **ESTRUCTURA PLACA ENTREPISO DEL DISPONIBLE** | 40d | 2024-02-29 | 2024-04-25 |  | 2d |  | 0,00% | 0,00% | 0,00% | 0,00% |
| 1036 | 1.5.38.8.4.1 | Encofrado y Acero de Refuerzo | 25d | 2024-02-29 | 2024-04-05 | 1021, 1031 | 2d | 0d | 0,00% | 0,00% | 0,00% | 0,00% |
| 1037 | 1.5.38.8.4.2 | Concreto | 18d | 2024-04-02 | 2024-04-25 | 1036FS-3d, 1034 | 2d | 0d | 0,00% | 0,00% | 0,00% | 0,00% |
| 1038 | 1.5.38.8.5 | **COLUMNAS DEL DISPONBLE HASTA MEZANINE Y HASTA PLATAFORMA DE ABORDAJE** | 30d | 2024-04-12 | 2024-05-23 |  | 2d |  | 0,00% | 0,00% | 0,00% | 0,00% |
| 1039 | 1.5.38.8.5.1 | Encofrado y Acero de Refuerzo | 28d | 2024-04-12 | 2024-05-21 | 1037SS+8d | 2d | 0d | 0,00% | 0,00% | 0,00% | 0,00% |
| 1040 | 1.5.38.8.5.2 | Concreto para Columnas | 25d | 2024-04-18 | 2024-05-23 | 1039SS+5d | 2d | 0d | 0,00% | 0,00% | 0,00% | 0,00% |
| 1041 | 1.5.38.8.6 | **ESTRUCTURA PLACA ENTREPISO MEZANINE** | 21d | 2024-05-17 | 2024-06-17 |  | 302d |  | 0,00% | 0,00% | 0,00% | 0,00% |
| 1042 | 1.5.38.8.6.1 | Encofrado y Acero de Refuerzo | 12d | 2024-05-17 | 2024-06-04 | 1037FS+15d | 302d | 0d | 0,00% | 0,00% | 0,00% | 0,00% |
| 1043 | 1.5.38.8.6.2 | Concreto | 9d | 2024-06-04 | 2024-06-17 | 1042 | 302d | 67d | 0,00% | 0,00% | 0,00% | 0,00% |
| 1044 | 1.5.38.8.7 | **COLUMNAS MEZANINE** | 13d | 2024-05-09 | 2024-05-28 |  | 2d |  | 0,00% | 0,00% | 0,00% | 0,00% |
| 1045 | 1.5.38.8.7.1 | Acero de Refuerzo | 10d | 2024-05-09 | 2024-05-23 | 1040SS+15d | 2d | 0d | 0,00% | 0,00% | 0,00% | 0,00% |
| 1046 | 1.5.38.8.7.2 | Concreto para Columnas | 8d | 2024-05-17 | 2024-05-28 | 1045SS+5d | 2d | 0d | 0,00% | 0,00% | 0,00% | 0,00% |
| 1047 | 1.5.38.8.8 | **ESTRUCTURA PLACA ENTREPISO PLATAFORMA DE ABORDAJE** | 25d | 2024-05-28 | 2024-07-03 |  | 2d |  | 0,00% | 0,00% | 0,00% | 0,00% |
| 1048 | 1.5.38.8.8.1 | Acero de Refuerzo | 25d | 2024-05-28 | 2024-07-03 | 1046SS+8d, 1040SS+8d | 2d | 0d | 0,00% | 0,00% | 0,00% | 0,00% |
| 1049 | 1.5.38.8.8.2 | Concreto | 18d | 2024-06-05 | 2024-06-29 | 1048SS+5d | 2d | 0d | 0,00% | 0,00% | 0,00% | 0,00% |
| 1050 | 1.5.38.8.9 | **COLUMNAS PLATAFORMA DE ABORDAJE A CUBIERTA** | 21d | 2024-06-26 | 2024-07-25 |  | 2d |  | 0,00% | 0,00% | 0,00% | 0,00% |
| 1051 | 1.5.38.8.9.1 | Acero de Refuerzo | 16d | 2024-06-26 | 2024-07-18 | 1049SS+15d | 2d | 0d | 0,00% | 0,00% | 0,00% | 0,00% |
| 1052 | 1.5.38.8.9.2 | Concreto para Columnas | 16d | 2024-07-04 | 2024-07-25 | 1051SS+5d | 2d | 0d | 0,00% | 0,00% | 0,00% | 0,00% |
| 1053 | 1.5.38.8.10 | **ESTRUCTURA VIGAS DE CUBIERTA** | 18d | 2024-07-17 | 2024-08-12 |  | 2d |  | 0,00% | 0,00% | 0,00% | 0,00% |
| 1054 | 1.5.38.8.10.1 | Acero de Refuerzo | 13d | 2024-07-17 | 2024-08-02 | 1052SS+10d | 2d | 0d | 0,00% | 0,00% | 0,00% | 0,00% |
| 1055 | 1.5.38.8.10.2 | Concreto | 13d | 2024-07-24 | 2024-08-12 | 1054SS+5d | 2d | 0d | 0,00% | 0,00% | 0,00% | 0,00% |
| 1056 | 1.5.38.8.11 | **ESCALERAS** | 18d | 2024-08-12 | 2024-09-05 |  | 11d |  | 0,00% | 0,00% | 0,00% | 0,00% |
| 1057 | 1.5.38.8.11.1 | Acero de Refuerzo | 13d | 2024-08-12 | 2024-08-29 | 1055 | 11d | 0d | 0,00% | 0,00% | 0,00% | 0,00% |
| 1058 | 1.5.38.8.11.2 | Concreto para Escaleras | 13d | 2024-08-20 | 2024-09-05 | 1057SS+5d | 11d | 9d | 0,00% | 0,00% | 0,00% | 0,00% |

| ID | WBS | Task | Type | Duration | Start | Finish | Predecessors | Total slack | Free slack | % Avance Planeado | % avance planeado en costo (texto) | % Completado (décimales) | % Completado en Costo |
| --- | --- | --- | --- | --- | --- | --- | --- | --- | --- | --- | --- | --- | --- |
| 1059 | 1.5.38.8.12 | **ACERO ESTRUCTURAL** |  | 27d | 2024-08-12 | 2024-09-17 |  | 2d |  | 0,00% | 0,00% | 0,00% | 0,00% |
| 1060 | 1.5.38.8.12.1 | **CUBIERTA** |  | 27d | 2024-08-12 | 2024-09-17 |  | 2d |  | 0,00% | 0,00% | 0,00% | 0,00% |
| 1061 | 1.5.38.8.12.1.1 | Acero ASTM |  | 27d | 2024-08-12 | 2024-09-17 | 1055 | 2d | 0d | 0,00% | 0,00% | 0,00% | 0,00% |
| 1062 | 1.5.38.8.13 | Fin Estructura Estación | milestone | 0d | 2024-09-17 | 2024-09-17 | 1061, 988, 1006, 1009, 1014, 1017, 1024, 1028, 1043, 993, 996, 999 | 235d | 0d | 0,00% | 0,00% | 0,00% | 0,00% |
| 1063 | 1.5.38.9 | **SUMINISTRO Y MONTAJE COMPONENTE ELECTROMECÁNICO** |  | 50d | 2024-09-17 | 2024-11-26 |  | 2d | 0d | 0,00% | 0,00% | 0,00% | 0,00% |
| 1064 | 1.5.38.9.1 | Montaje Mecánico |  | 50d | 2024-09-17 | 2024-11-26 | 15SS+60d, 1058, 1061 | 2d | 0d | 0,00% | 0,00% | 0,00% | 0,00% |
| 1065 | 1.5.38.9.2 | Montaje Eléctrico |  | 42d | 2024-09-27 | 2024-11-26 | 1064FS-42d, 1138FF, 1137FF | 2d | 0d | 0,00% | 0,00% | 0,00% | 0,00% |
| 1066 | 1.5.38.9.3 | Fin montaje Electromecánico | milestone | 0d | 2024-11-26 | 2024-11-26 | 1064, 1065 | 2d |  | 0,00% | 0,00% | 0,00% | 0,00% |
| 1067 | 1.5.38.10 | **CUBIERTA** |  | 36d | 2024-11-26 | 2025-01-15 |  | 174d | 0d | 0,00% | 0,00% | 0,00% | 0,00% |
| 1068 | 1.5.38.10.1 | **PLATAFORMA DE ABORDAJE** |  | 36d | 2024-11-26 | 2025-01-15 |  | 174d |  | 0,00% | 0,00% | 0,00% | 0,00% |
| 1069 | 1.5.38.10.1.1 | Cubierta Lisa Tipo Sándwich Deck En Aluzinc |  | 36d | 2024-11-26 | 2025-01-15 | 1061, 1064 | 174d | 0d | 0,00% | 0,00% | 0,00% | 0,00% |
| 1070 | 1.5.38.10.2 | Fin Instalación de Cubierta para Plataforma de Abordaje | milestone | 0d | 2025-01-15 | 2025-01-15 | 1069 | 174d | 0d | 0,00% | 0,00% | 0,00% | 0,00% |
| 1071 | 1.5.38.11 | **REDES HIDRÁULICAS Y SANITARIAS** |  | 252d | 2024-02-07 | 2025-01-23 |  | 239d | 54d | 0,00% | 0,00% | 0,00% | 0,00% |
| 1072 | 1.5.38.11.1 | **REDES INTERNAS** |  | 142d | 2024-02-13 | 2024-08-30 |  | 344d |  | 0,00% | 0,00% | 0,00% | 0,00% |
| 1073 | 1.5.38.11.1.1 | **SUBNIVEL S1** |  | 31d | 2024-02-13 | 2024-03-26 |  | 455d |  | 0,00% | 0,00% | 0,00% | 0,00% |
| 1074 | 1.5.38.11.1.1.1 | Tubería PVC Sanitaria |  | 31d | 2024-02-13 | 2024-03-26 | 1031SS | 455d | 0d | 0,00% | 0,00% | 0,00% | 0,00% |
| 1075 | 1.5.38.11.1.1.2 | Tubería PVC RDE |  | 31d | 2024-02-13 | 2024-03-26 | 1074SS | 455d | 111d | 0,00% | 0,00% | 0,00% | 0,00% |
| 1076 | 1.5.38.11.1.1.3 | Accesorios |  | 31d | 2024-02-13 | 2024-03-26 | 1074SS | 455d | 111d | 0,00% | 0,00% | 0,00% | 0,00% |
| 1077 | 1.5.38.11.1.2 | **SUBNIVEL 0** |  | 31d | 2024-04-02 | 2024-05-15 |  | 421d |  | 0,00% | 0,00% | 0,00% | 0,00% |
| 1078 | 1.5.38.11.1.2.1 | Tubería PVC Sanitaria |  | 31d | 2024-04-02 | 2024-05-15 | 1037SS | 421d | 0d | 0,00% | 0,00% | 0,00% | 0,00% |
| 1079 | 1.5.38.11.1.2.2 | Tubería PVC RDE |  | 31d | 2024-04-02 | 2024-05-15 | 1078SS | 421d | 77d | 0,00% | 0,00% | 0,00% | 0,00% |
| 1080 | 1.5.38.11.1.2.3 | Accesorios |  | 31d | 2024-04-02 | 2024-05-15 | 1078SS | 421d | 77d | 0,00% | 0,00% | 0,00% | 0,00% |
| 1081 | 1.5.38.11.1.3 | **NIVEL A** |  | 29d | 2024-06-05 | 2024-07-16 |  | 377d |  | 0,00% | 0,00% | 0,00% | 0,00% |
| 1082 | 1.5.38.11.1.3.1 | Tubería PVC Sanitaria |  | 29d | 2024-06-05 | 2024-07-16 | 1049SS | 377d | 0d | 0,00% | 0,00% | 0,00% | 0,00% |
| 1083 | 1.5.38.11.1.3.2 | Tubería PVC RDE |  | 29d | 2024-06-05 | 2024-07-16 | 1082SS | 377d | 33d | 0,00% | 0,00% | 0,00% | 0,00% |
| 1084 | 1.5.38.11.1.3.3 | Accesorios |  | 29d | 2024-06-05 | 2024-07-16 | 1082SS | 377d | 33d | 0,00% | 0,00% | 0,00% | 0,00% |

| ID | WBS | Task | Type | Duration | Start | Finish | Predecessors | Total slack | Free slack | % Avance Planeado | % avance planeado en costo (texto) | % Completado (décimales) | % Completado en Costo |
| --- | --- | --- | --- | --- | --- | --- | --- | --- | --- | --- | --- | --- | --- |
| 1085 | 1.5.38.11.1.4 | **PLATAFORMA DE ABORDAJE** |  | 27d | 2024-07-24 | 2024-08-30 |  | 344d |  | 0,00% | 0,00% | 0,00% | 0,00% |
| 1086 | 1.5.38.11.1.4.1 | Tubería PVC Sanitaria |  | 27d | 2024-07-24 | 2024-08-30 | 1055SS | 344d | 0d | 0,00% | 0,00% | 0,00% | 0,00% |
| 1087 | 1.5.38.11.1.4.2 | Tubería PVC RDE |  | 27d | 2024-07-24 | 2024-08-30 | 1086SS | 344d | 0d | 0,00% | 0,00% | 0,00% | 0,00% |
| 1088 | 1.5.38.11.1.4.3 | Accesorios |  | 27d | 2024-07-24 | 2024-08-30 | 1086SS | 344d | 0d | 0,00% | 0,00% | 0,00% | 0,00% |
| 1089 | 1.5.38.11.2 | FIN REDES HIDRÁULICAS Y SANITARIAS | milestone | 0d | 2024-08-30 | 2024-08-30 | 1075, 1076, 1079, 1080, 1083, 1084, 1087, 1088 | 344d |  | 0,00% | 0,00% | 0,00% | 0,00% |
| 1090 | 1.5.38.11.3 | **REDES EXTERNAS** |  | 252d | 2024-02-07 | 2025-01-23 |  | 239d |  | 0,00% | 0,00% | 0,00% | 0,00% |
| 1091 | 1.5.38.11.3.1 | **Redes de Acueducto** |  | 57d | 2024-02-07 | 2024-04-25 |  | 434d |  | 0,00% | 0,00% | 0,00% | 0,00% |
| 1092 | 1.5.38.11.3.1.1 | Excavación manual para redes |  | 53d | 2024-02-07 | 2024-04-19 | 1194SS+5d | 434d | 0d | 0,00% | 0,00% | 0,00% | 0,00% |
| 1093 | 1.5.38.11.3.1.2 | Instalación de Tubería, incluye accesorios. |  | 53d | 2024-02-09 | 2024-04-23 | 1092SS+2d | 434d | 0d | 0,00% | 0,00% | 0,00% | 0,00% |
| 1094 | 1.5.38.11.3.1.3 | Rellenos para redes |  | 53d | 2024-02-12 | 2024-04-25 | 1093SS+2d | 434d | 260d | 0,00% | 0,00% | 0,00% | 0,00% |
| 1095 | 1.5.38.11.3.2 | **Redes de Alcantarillado** |  | 69d | 2024-10-18 | 2025-01-23 |  | 197d |  | 0,00% | 0,00% | 0,00% | 0,00% |
| 1096 | 1.5.38.11.3.2.1 | Excavación manual para redes |  | 65d | 2024-10-18 | 2025-01-17 | 2130SS, 1199SS, 270SS | 197d | 0d | 0,00% | 0,00% | 0,00% | 0,00% |
| 1097 | 1.5.38.11.3.2.2 | Instalación de Tubería, incluye accesorios. |  | 65d | 2024-10-22 | 2025-01-21 | 1096SS+2d | 197d | 0d | 0,00% | 0,00% | 0,00% | 0,00% |
| 1098 | 1.5.38.11.3.2.3 | Rellenos para redes |  | 65d | 2024-10-24 | 2025-01-23 | 1097SS+2d | 197d | 0d | 0,00% | 0,00% | 0,00% | 0,00% |
| 1099 | 1.5.38.11.3.2.4 | Instalación de canal monolítico |  | 10d | 2025-01-08 | 2025-01-21 | 1097FF | 241d |  | 0,00% | 0,00% | 0,00% | 0,00% |
| 1100 | 1.5.38.12 | **REDES ELÉCTRICAS, VOZ Y DATOS** |  | 304d | 2024-02-09 | 2025-04-05 |  | 90d | 0d | 0,00% | 0,00% | 0,00% | 0,00% |
| 1101 | 1.5.38.12.1 | **REDES INTERNAS** |  | 267d | 2024-04-02 | 2025-04-05 |  | 93d |  | 0,00% | 0,00% | 0,00% | 0,00% |
| 1102 | 1.5.38.12.1.1 | **SUBNIVEL S1** |  | 60d | 2025-01-16 | 2025-04-05 |  | 185d |  | 0,00% | 0,00% | 0,00% | 0,00% |
| 1103 | 1.5.38.12.1.1.1 | Tubería Conduit |  | 31d | 2025-01-16 | 2025-02-25 | 1031SS, 1128 | 185d | 0d | 0,00% | 0,00% | 0,00% | 0,00% |
| 1104 | 1.5.38.12.1.1.2 | Tubería Galvanizada |  | 31d | 2025-01-16 | 2025-02-25 | 1103SS | 185d | 0d | 0,00% | 0,00% | 0,00% | 0,00% |
| 1105 | 1.5.38.12.1.1.3 | Accesorios |  | 31d | 2025-01-16 | 2025-02-25 | 1103SS, 1104SS | 185d | 0d | 0,00% | 0,00% | 0,00% | 0,00% |
| 1106 | 1.5.38.12.1.1.4 | Cableado |  | 22d | 2025-02-26 | 2025-03-27 | 1105 | 185d | 0d | 0,00% | 0,00% | 0,00% | 0,00% |
| 1107 | 1.5.38.12.1.1.5 | Instalación de Aparatos Electricos |  | 7d | 2025-03-27 | 2025-04-05 | 1106 | 185d | 0d | 0,00% | 0,00% | 0,00% | 0,00% |
| 1108 | 1.5.38.12.1.2 | **SUBNIVEL 0** |  | 60d | 2024-04-02 | 2024-06-25 |  | 112d |  | 0,00% | 0,00% | 0,00% | 0,00% |
| 1109 | 1.5.38.12.1.2.1 | Tubería Conduit |  | 31d | 2024-04-02 | 2024-05-15 | 1037SS | 112d | 0d | 0,00% | 0,00% | 0,00% | 0,00% |
| 1110 | 1.5.38.12.1.2.2 | Tubería Galvanizada |  | 31d | 2024-04-02 | 2024-05-15 | 1109SS | 112d | 0d | 0,00% | 0,00% | 0,00% | 0,00% |
| 1111 | 1.5.38.12.1.2.3 | Accesorios |  | 31d | 2024-04-02 | 2024-05-15 | 1110SS, 1109SS | 392d | 0d | 0,00% | 0,00% | 0,00% | 0,00% |
| 1112 | 1.5.38.12.1.2.4 | Cableado |  | 22d | 2024-05-15 | 2024-06-14 | 1111 | 392d | 0d | 0,00% | 0,00% | 0,00% | 0,00% |
| 1113 | 1.5.38.12.1.2.5 | Instalación de Aparatos Electricos |  | 7d | 2024-06-15 | 2024-06-25 | 1112 | 392d | 207d | 0,00% | 0,00% | 0,00% | 0,00% |

| ID | WBS | Task | Type | Duration | Start | Finish | Predecessors | Total slack | Free slack | % Avance Planeado | % avance planeado en costo (texto) | % Completado (décimales) | % Completado en Costo |
| --- | --- | --- | --- | --- | --- | --- | --- | --- | --- | --- | --- | --- | --- |
| 1114 | 1.5.38.12.1.3 | **NIVEL A** |  | 58d | 2024-06-05 | 2024-08-26 |  | 47d |  | 0,00% | 0,00% | 0,00% | 0,00% |
| 1115 | 1.5.38.12.1.3.1 | Tubería Conduit |  | 29d | 2024-06-05 | 2024-07-16 | 1049SS | 47d | 0d | 0,00% | 0,00% | 0,00% | 0,00% |
| 1116 | 1.5.38.12.1.3.2 | Tubería Galvanizada |  | 29d | 2024-06-05 | 2024-07-16 | 1115SS | 68d | 0d | 0,00% | 0,00% | 0,00% | 0,00% |
| 1117 | 1.5.38.12.1.3.3 | Accesorios |  | 29d | 2024-06-05 | 2024-07-16 | 1115SS, 1116SS | 348d | 0d | 0,00% | 0,00% | 0,00% | 0,00% |
| 1118 | 1.5.38.12.1.3.4 | Cableado |  | 22d | 2024-07-16 | 2024-08-15 | 1117 | 348d | 0d | 0,00% | 0,00% | 0,00% | 0,00% |
| 1119 | 1.5.38.12.1.3.5 | Instalación de Aparatos Electricos |  | 7d | 2024-08-15 | 2024-08-26 | 1118 | 348d | 163d | 0,00% | 0,00% | 0,00% | 0,00% |
| 1120 | 1.5.38.12.1.4 | **PLATAFORMA DE ABORDAJE** |  | 56d | 2024-07-24 | 2024-10-08 |  | 35d |  | 0,00% | 0,00% | 0,00% | 0,00% |
| 1121 | 1.5.38.12.1.4.1 | Tubería Conduit |  | 27d | 2024-07-24 | 2024-08-30 | 1055SS | 35d | 0d | 0,00% | 0,00% | 0,00% | 0,00% |
| 1122 | 1.5.38.12.1.4.2 | Tubería Galvanizada |  | 27d | 2024-07-24 | 2024-08-30 | 1121SS | 35d | 0d | 0,00% | 0,00% | 0,00% | 0,00% |
| 1123 | 1.5.38.12.1.4.3 | Accesorios |  | 27d | 2024-07-24 | 2024-08-30 | 1121SS, 1122SS | 315d | 0d | 0,00% | 0,00% | 0,00% | 0,00% |
| 1124 | 1.5.38.12.1.4.4 | Cableado |  | 22d | 2024-08-30 | 2024-09-28 | 1123 | 315d | 0d | 0,00% | 0,00% | 0,00% | 0,00% |
| 1125 | 1.5.38.12.1.4.5 | Instalación de Aparatos Electricos |  | 7d | 2024-09-30 | 2024-10-08 | 1124 | 315d | 130d | 0,00% | 0,00% | 0,00% | 0,00% |
| 1126 | 1.5.38.12.2 | FIN REDES INTERNAS | milestone | 0d | 2025-04-05 | 2025-04-05 | 1107, 1113, 1119, 1125, 1129, 1135 | 185d |  | 0,00% | 0,00% | 0,00% | 0,00% |
| 1127 | 1.5.38.12.3 | **APANTALLAMIENTO** |  | 36d | 2024-11-26 | 2025-01-15 |  | 185d |  | 0,00% | 0,00% | 0,00% | 0,00% |
| 1128 | 1.5.38.12.3.1 | Pararrayos Tipo Punta De Franklin |  | 36d | 2024-11-26 | 2025-01-15 | 1070FF | 185d | 0d | 0,00% | 0,00% | 0,00% | 0,00% |
| 1129 | 1.5.38.12.3.2 | Cable De Cobre Desnudo |  | 36d | 2024-11-26 | 2025-01-15 | 1128FF | 245d | 60d | 0,00% | 0,00% | 0,00% | 0,00% |
| 1130 | 1.5.38.12.4 | **REDES EXTERNAS** |  | 175d | 2024-02-09 | 2024-10-09 |  | 90d |  | 0,00% | 0,00% | 0,00% | 0,00% |
| 1131 | 1.5.38.12.4.1 | **ILUMINACIÓN EXTERIOR** |  | 82d | 2024-04-15 | 2024-08-08 |  | 80d |  | 0,00% | 0,00% | 0,00% | 0,00% |
| 1132 | 1.5.38.12.4.1.1 | Tubería Eléctrica PVC |  | 53d | 2024-04-15 | 2024-06-28 | 1194 | 80d | 0d | 0,00% | 0,00% | 0,00% | 0,00% |
| 1133 | 1.5.38.12.4.1.2 | Accesorios |  | 53d | 2024-04-15 | 2024-06-28 | 1132SS | 360d | 0d | 0,00% | 0,00% | 0,00% | 0,00% |
| 1134 | 1.5.38.12.4.1.3 | Cableado |  | 22d | 2024-06-28 | 2024-07-29 | 1133 | 360d | 0d | 0,00% | 0,00% | 0,00% | 0,00% |
| 1135 | 1.5.38.12.4.1.4 | Instalación de Aparatos Electricos |  | 7d | 2024-07-30 | 2024-08-08 | 1134 | 360d | 175d | 0,00% | 0,00% | 0,00% | 0,00% |
| 1136 | 1.5.38.12.4.2 | **SISTEMA DE ALIMENTACIÓN Y POTENCIA** |  | 175d | 2024-02-09 | 2024-10-09 |  | 35d |  | 0,00% | 0,00% | 0,00% | 0,00% |
| 1137 | 1.5.38.12.4.2.1 | Suministro de Subestación Eléctrica |  | 90d | 2024-02-09 | 2024-06-14 | 49FS+150d | 90d | 55d | 0,00% | 0,00% | 0,00% | 0,00% |
| 1138 | 1.5.38.12.4.2.2 | Montaje Subestación Eléctrica |  | 30d | 2024-08-30 | 2024-10-09 | 1132, 1172, 1137, 1122, 1116, 1110 | 35d | 33d | 0,00% | 0,00% | 0,00% | 0,00% |

| ID | WBS | Task | Type | Duration | Start | Finish | Predecessors | Total slack | Free slack | % Avance Planeado | % avance planeado en costo (texto) | % Completado (décimales) | % Completado en Costo |
| --- | --- | --- | --- | --- | --- | --- | --- | --- | --- | --- | --- | --- | --- |
| 1139 | 1.5.38.13 | **ELEVADORES ESTACIÓN: COSTADO NORTE Y SUR** |  | 424d | 2023-09-11 | 2025-04-23 |  | 174d | 0d | 0,00% | 0,00% | 0,00% | 0,00% |
| 1140 | 1.5.38.13.1 | Fabricación, Importación, Transporte y Nacionalización |  | 150d | 2023-09-11 | 2024-04-06 | 2FS+179d | 349d | 114d | 0,00% | 0,00% | 0,00% | 0,00% |
| 1141 | 1.5.38.13.2 | Obras Civiles y Trabajos Preparatorios |  | 3d | 2024-09-13 | 2024-09-17 | 1140, 1062FF | 235d | 0d | 0,00% | 0,00% | 0,00% | 0,00% |
| 1142 | 1.5.38.13.3 | Toma de las Medidas del Pozo. Estudio y Análisis de las Medidas. Organización de Almacén y Traslado de Materiales |  | 5d | 2024-09-11 | 2024-09-17 | 1141FF | 235d | 61d | 0,00% | 0,00% | 0,00% | 0,00% |
| 1143 | 1.5.38.13.4 | Izaje de Guías de Carro y CWT. Instalación de Brackets y Primer Tramo de Guías. Instalación de Amortiguadores y Elementos de PIT |  | 25d | 2024-12-10 | 2025-01-15 | 1142, 1062, 1070FF | 174d | 0d | 0,00% | 0,00% | 0,00% | 0,00% |
| 1144 | 1.5.38.13.5 | Ensamble de Chasis de Cabina, CWT, Armado de Cabina e Izaje de Última Parada, Puesta en MSK |  | 10d | 2025-01-16 | 2025-01-29 | 1143 | 174d | 0d | 0,00% | 0,00% | 0,00% | 0,00% |
| 1145 | 1.5.38.13.6 | Instalación de Soportes de Guías, Rectificación y Alineación |  | 13d | 2025-01-29 | 2025-02-14 | 1144 | 174d | 0d | 0,00% | 0,00% | 0,00% | 0,00% |
| 1146 | 1.5.38.13.7 | Ensamble e Instalación de los Marcos y Puertas de Entrada de Piso |  | 13d | 2025-02-14 | 2025-03-04 | 1145 | 174d | 0d | 0,00% | 0,00% | 0,00% | 0,00% |
| 1147 | 1.5.38.13.8 | Elaboración de Remates Frontales y Acabados de los Mismos, Instalación de Cajas para Botoneras e Indicadores. |  | 15d | 2025-02-14 | 2025-03-06 | 1146SS | 174d | 0d | 0,00% | 0,00% | 0,00% | 0,00% |
| 1148 | 1.5.38.13.9 | Instalación de Cableado de Pozo y Botoneras, Conexiones e Instalación de Cable Viajero |  | 13d | 2025-03-06 | 2025-03-25 | 1147, 1138, 1137 | 174d | 0d | 0,00% | 0,00% | 0,00% | 0,00% |
| 1149 | 1.5.38.13.10 | Ensamble de Cabina, Instalación de Accesorios y Conexiones |  | 10d | 2025-03-25 | 2025-04-07 | 1148 | 174d | 0d | 0,00% | 0,00% | 0,00% | 0,00% |
| 1150 | 1.5.38.13.11 | Inspeccion Mecánica y de Calidad |  | 3d | 2025-04-08 | 2025-04-10 | 1149 | 174d | 0d | 0,00% | 0,00% | 0,00% | 0,00% |
| 1151 | 1.5.38.13.12 | Ajuste y Configuración |  | 7d | 2025-04-08 | 2025-04-16 | 1150SS | 174d | 0d | 0,00% | 0,00% | 0,00% | 0,00% |
| 1152 | 1.5.38.13.13 | Certificación NTC 5926-1 |  | 3d | 2025-04-16 | 2025-04-23 | 1151 | 174d |  | 0,00% | 0,00% | 0,00% | 0,00% |
| 1153 | 1.5.38.13.14 | Protocolos, Limpieza, Entrega |  | 3d | 2025-04-16 | 2025-04-23 | 1151 | 174d | 0d | 0,00% | 0,00% | 0,00% | 0,00% |
| 1154 | 1.5.38.13.15 | Fin de Fabricación, Instlación de Elevador | milestone | 0d | 2025-04-23 | 2025-04-23 | 1153 | 174d | 0d | 0,00% | 0,00% | 0,00% | 0,00% |
| 1155 | 1.5.38.14 | **MAMPOSTERÍA, PAÑETES Y ACABADOS** |  | 53d | 2024-06-05 | 2024-08-17 |  | 47d |  | 0,00% | 0,00% | 0,00% | 0,00% |
| 1156 | 1.5.38.14.1 | **NIVEL A** |  | 18d | 2024-06-05 | 2024-06-29 |  | 47d |  | 0,00% | 0,00% | 0,00% | 0,00% |
| 1157 | 1.5.38.14.1.1 | Mampostería En Bloque De Concreto 15X20X40 De Dos Perforaciones |  | 18d | 2024-06-05 | 2024-06-29 | 1115SS | 47d | 0d | 0,00% | 0,00% | 0,00% | 0,00% |
| 1158 | 1.5.38.14.1.2 | Muro en ladrillo tolete |  | 18d | 2024-06-05 | 2024-06-29 | 1157SS | 388d | 214d | 0,00% | 0,00% | 0,00% | 0,00% |
| 1159 | 1.5.38.14.2 | **PLATAFORMA DE ABORDAJE** |  | 18d | 2024-07-24 | 2024-08-17 |  | 353d |  | 0,00% | 0,00% | 0,00% | 0,00% |
| 1160 | 1.5.38.14.2.1 | Mampostería En Bloque De Concreto 15X20X40 De Dos Perforaciones |  | 18d | 2024-07-24 | 2024-08-17 | 1121SS | 353d | 0d | 0,00% | 0,00% | 0,00% | 0,00% |
| 1161 | 1.5.38.14.2.2 | Muro en ladrillo tolete |  | 18d | 2024-07-24 | 2024-08-17 | 1160SS | 353d | 179d | 0,00% | 0,00% | 0,00% | 0,00% |
| 1162 | 1.5.38.14.3 | PAÑETES, ESTUCO, PINTURA Y ENCHAPES |  | 27d | 2024-07-02 | 2024-08-06 | 1157 | 197d | 0d | 0,00% | 0,00% | 0,00% | 0,00% |

| ID | WBS | Task | Type | Duration | Start | Finish | Predecessors | Total slack | Free slack | % Avance Planeado | % avance planeado en costo (texto) | % Completado (décimales) | % Completado en Costo |
| --- | --- | --- | --- | --- | --- | --- | --- | --- | --- | --- | --- | --- | --- |
| 1163 | 1.5.38.15 | **ACCESORIOS Y ADECUACIÓN** |  | 18d | 2024-08-14 | 2024-09-07 |  | 311d | 164d | 0,00% | 0,00% | 0,00% | 0,00% |
| 1164 | 1.5.38.15.1 | Sanitarios |  | 18d | 2024-08-14 | 2024-09-07 | 1169 | 311d | 0d | 0,00% | 0,00% | 0,00% | 0,00% |
| 1165 | 1.5.38.15.2 | Lavamanos |  | 18d | 2024-08-14 | 2024-09-07 | 1169 | 338d | 164d | 0,00% | 0,00% | 0,00% | 0,00% |
| 1166 | 1.5.38.15.3 | Gabinetes |  | 18d | 2024-08-14 | 2024-09-07 | 1169 | 338d | 164d | 0,00% | 0,00% | 0,00% | 0,00% |
| 1167 | 1.5.38.15.4 | Mesones |  | 18d | 2024-08-14 | 2024-09-07 | 1169 | 338d | 164d | 0,00% | 0,00% | 0,00% | 0,00% |
| 1168 | 1.5.38.16 | **PISOS** |  | 40d | 2024-06-19 | 2024-08-14 |  | 47d |  | 0,00% | 0,00% | 0,00% | 0,00% |
| 1169 | 1.5.38.16.1 | Piso en Concreto de 3.000 PSI |  | 40d | 2024-06-19 | 2024-08-14 | 1157SS+10d | 47d | 0d | 0,00% | 0,00% | 0,00% | 0,00% |
| 1170 | 1.5.38.16.2 | Baldosa en Granito Pulido |  | 40d | 2024-06-19 | 2024-08-14 | 1169SS | 47d | 0d | 0,00% | 0,00% | 0,00% | 0,00% |
| 1171 | 1.5.38.16.3 | Piso en Granito |  | 40d | 2024-06-19 | 2024-08-14 | 1169SS | 47d | 0d | 0,00% | 0,00% | 0,00% | 0,00% |
| 1172 | 1.5.38.16.4 | Fin Pisos | milestone | 0d | 2024-08-14 | 2024-08-14 | 1169, 1170, 1171 | 47d | 12d | 0,00% | 0,00% | 0,00% | 0,00% |
| 1173 | 1.5.38.17 | **EQUIPOS ESPECIALES** |  | 27d | 2024-07-02 | 2024-08-06 |  | 361d | 176d | 0,00% | 0,00% | 0,00% | 0,00% |
| 1174 | 1.5.38.17.1 | Sistema de Aire Acondicionado |  | 27d | 2024-07-02 | 2024-08-06 | 1157 | 361d | 187d | 0,00% | 0,00% | 0,00% | 0,00% |
| 1175 | 1.5.38.17.2 | Insonorización Espacios |  | 27d | 2024-07-02 | 2024-08-06 | 1157 | 361d | 187d | 0,00% | 0,00% | 0,00% | 0,00% |
| 1176 | 1.5.38.18 | **CARPINTERÍA METÁLICA** |  | 50d | 2024-08-06 | 2024-10-15 |  | 311d | 137d | 0,00% | 0,00% | 0,00% | 0,00% |
| 1177 | 1.5.38.18.1 | Ventanas en Aluminio |  | 27d | 2024-08-06 | 2024-09-12 | 1162 | 334d | 160d | 0,00% | 0,00% | 0,00% | 0,00% |
| 1178 | 1.5.38.18.2 | Cortasol Tipo Panel |  | 27d | 2024-08-06 | 2024-09-12 | 1162 | 334d | 160d | 0,00% | 0,00% | 0,00% | 0,00% |
| 1179 | 1.5.38.18.3 | Puertas |  | 27d | 2024-08-06 | 2024-09-12 | 1162 | 334d | 160d | 0,00% | 0,00% | 0,00% | 0,00% |
| 1180 | 1.5.38.18.4 | Pasamanos |  | 27d | 2024-08-06 | 2024-09-12 | 1162 | 334d | 160d | 0,00% | 0,00% | 0,00% | 0,00% |
| 1181 | 1.5.38.18.5 | Divisiones |  | 27d | 2024-09-09 | 2024-10-15 | 1164 | 311d | 137d | 0,00% | 0,00% | 0,00% | 0,00% |
| 1182 | 1.5.38.19 | **FACHADAS** |  | 53d | 2024-08-06 | 2024-10-18 |  | 197d | 134d | 0,00% | 0,00% | 0,00% | 0,00% |
| 1183 | 1.5.38.19.1 | Fachada Lamina de Aluzinc |  | 31d | 2024-08-06 | 2024-09-18 | 1162 | 197d | 0d | 0,00% | 0,00% | 0,00% | 0,00% |
| 1184 | 1.5.38.19.2 | Estructura de Soporte |  | 22d | 2024-09-18 | 2024-10-18 | 1183 | 308d | 0d | 0,00% | 0,00% | 0,00% | 0,00% |
| 1185 | 1.5.38.19.3 | Accesorios |  | 22d | 2024-09-18 | 2024-10-18 | 1184SS | 308d | 134d | 0,00% | 0,00% | 0,00% | 0,00% |
| 1186 | 1.5.38.19.4 | Fachaleta Screen Panel |  | 22d | 2024-09-18 | 2024-10-18 | 1183 | 197d | 0d | 0,00% | 0,00% | 0,00% | 0,00% |

| ID | WBS | Task | Type | Duration | Start | Finish | Predecessors | Total slack | Free slack | % Avance Planeado | % avance planeado en costo (texto) | % Completado (décimales) | % Completado en Costo |
| --- | --- | --- | --- | --- | --- | --- | --- | --- | --- | --- | --- | --- | --- |
| 1187 | 1.5.38.20 | **RED CONTRA INCENDIOS** |  | 35d | 2024-08-06 | 2024-09-24 |  | 326d | 141d | 0,00% | 0,00% | 0,00% | 0,00% |
| 1188 | 1.5.38.20.1 | Tubería |  | 15d | 2024-08-06 | 2024-08-28 | 1162 | 326d | 0d | 0,00% | 0,00% | 0,00% | 0,00% |
| 1189 | 1.5.38.20.2 | Cableado |  | 13d | 2024-08-09 | 2024-08-28 | 1188SS+2d | 326d | 0d | 0,00% | 0,00% | 0,00% | 0,00% |
| 1190 | 1.5.38.20.3 | Bombas |  | 9d | 2024-08-28 | 2024-09-09 | 1188, 1189 | 326d | 0d | 0,00% | 0,00% | 0,00% | 0,00% |
| 1191 | 1.5.38.20.4 | Sensores y accesorios |  | 7d | 2024-09-10 | 2024-09-18 | 1190 | 326d | 0d | 0,00% | 0,00% | 0,00% | 0,00% |
| 1192 | 1.5.38.20.5 | Pruebas |  | 4d | 2024-09-18 | 2024-09-24 | 1191 | 326d | 152d | 0,00% | 0,00% | 0,00% | 0,00% |
| 1193 | 1.5.38.21 | **URBANISMO Y ESPACIO PÚBLICO** |  | 98d | 2024-01-31 | 2024-06-17 |  | 80d |  | 0,00% | 0,00% | 0,00% | 0,00% |
| 1194 | 1.5.38.21.1 | Rellenos y Bases |  | 54d | 2024-01-31 | 2024-04-15 | 1019, 1002 | 80d | 0d | 0,00% | 0,00% | 0,00% | 0,00% |
| 1195 | 1.5.38.21.2 | Áreas en adoquín y concreto estampado |  | 26d | 2024-04-15 | 2024-05-21 | 1194 | 287d | 0d | 0,00% | 0,00% | 0,00% | 0,00% |
| 1196 | 1.5.38.21.3 | Áreas en Gramoquin |  | 26d | 2024-04-15 | 2024-05-21 | 1194 | 351d | 0d | 0,00% | 0,00% | 0,00% | 0,00% |
| 1197 | 1.5.38.21.4 | Mobiliario Urbano |  | 18d | 2024-05-22 | 2024-06-17 | 1195 | 287d | 90d | 0,00% | 0,00% | 0,00% | 0,00% |
| 1198 | 1.5.38.22 | **PAVIMENTOS** |  | 72d | 2024-10-18 | 2025-01-28 |  | 197d | 39d | 0,00% | 0,00% | 0,00% | 0,00% |
| 1199 | 1.5.38.22.1 | Demoliciones y excavaciones |  | 24d | 2024-10-18 | 2024-11-21 | 1197, 1186 | 197d | 0d | 0,00% | 0,00% | 0,00% | 0,00% |
| 1200 | 1.5.38.22.2 | Estructura de vía |  | 24d | 2024-10-25 | 2024-11-28 | 1199SS+5d | 237d | 40d | 0,00% | 0,00% | 0,00% | 0,00% |
| 1201 | 1.5.38.22.3 | Capa de Rodadura |  | 10d | 2025-01-15 | 2025-01-28 | 1200FF+3d, 1098FF+3d | 197d | 0d | 0,00% | 0,00% | 0,00% | 0,00% |
| 1202 | 1.5.38.22.4 | Fin Pavimentos | milestone | 0d | 2025-01-28 | 2025-01-28 | 1201 | 197d | 0d | 0,00% | 0,00% | 0,00% | 0,00% |
| 1203 | 1.5.38.23 | **SEÑALIZACIÓN Y DEMARCACIÓN VIAL** |  | 35d | 2025-02-03 | 2025-03-19 |  | 197d | 0d | 0,00% | 0,00% | 0,00% | 0,00% |
| 1204 | 1.5.38.23.1 | Demarcación vial. Incluye líneas continuas, discontinuas, flechas y demás pictogramas. |  | 25d | 2025-02-03 | 2025-03-06 | 1202FS+4d | 197d | 0d | 0,00% | 0,00% | 0,00% | 0,00% |
| 1205 | 1.5.38.23.2 | Instalación de tachas y estoperoles |  | 10d | 2025-02-08 | 2025-02-21 | 1204SS+5d | 217d | 20d | 0,00% | 0,00% | 0,00% | 0,00% |
| 1206 | 1.5.38.23.3 | Instalación de señales definitivas |  | 10d | 2025-03-06 | 2025-03-19 | 1204 | 197d | 0d | 0,00% | 0,00% | 0,00% | 0,00% |
| 1207 | 1.5.38.23.4 | Fin señalización y Demarcación Vial | milestone | 0d | 2025-03-19 | 2025-03-19 | 1205, 1206 | 197d |  | 0,00% | 0,00% | 0,00% | 0,00% |
| 1208 | 1.5.38.24 | **PAISAJISMO** |  | 65d | 2024-05-22 | 2024-08-21 |  | 351d | 154d | 0,00% | 0,00% | 0,00% | 0,00% |
| 1209 | 1.5.38.24.1 | Plantación de especies nativas |  | 65d | 2024-05-22 | 2024-08-21 | 1196 | 351d | 0d | 0,00% | 0,00% | 0,00% | 0,00% |
| 1210 | 1.5.38.24.2 | Colocación Grama |  | 65d | 2024-05-22 | 2024-08-21 | 1209SS | 351d | 177d | 0,00% | 0,00% | 0,00% | 0,00% |
| 1211 | 1.5.38.25 | Fin Estación Motriz Intermedia La Victoria | milestone | 0d | 2025-04-23 | 2025-04-23 | 982, 985, 989, 1021, 1062, 1066, 1070, 1094, 1138, 1154, 1161, 1162, 1167, 1171, 1175, 1181, 1186, 1192, 1197, 1210, 1137, 1019, 1158, 1165, 1166, 1174, 1177, 1178, 1179, 1180, 1185, 1202 | 174d |  | 0,00% | 0,00% | 0,00% | 0,00% |
| 1212 | 1.5.38.26 | Estación La Victoria: Hito de Aprobación Para Pago Preliminares y Cimentación | milestone | 0d | 2024-02-09 | 2024-02-09 | 978, 984, 986, 1003, 1020, 990 | 488d |  | 0,00% | 0,00% | 0,00% | 0,00% |
| 1213 | 1.5.38.27 | Estación La Victoria: Hito de Aprobación Para Pago Superestructura | milestone | 0d | 2025-01-15 | 2025-01-15 | 1025, 1067 | 245d |  | 0,00% | 0,00% | 0,00% | 0,00% |
| 1214 | 1.5.38.28 | Estación La Victoria: Hito de Aprobación Para Pago Arquitectura, Acabados y Elevadores | milestone | 0d | 2025-04-23 | 2025-04-23 | 1139, 1155, 1163, 1168, 1176, 1182 | 174d |  | 0,00% | 0,00% | 0,00% | 0,00% |
| 1215 | 1.5.38.29 | Estación La Victoria: Hito de Aprobación Para Pago Redes | milestone | 0d | 2025-04-05 | 2025-04-05 | 1022, 1071, 1100, 1187, 1173 | 185d |  | 0,00% | 0,00% | 0,00% | 0,00% |
| 1216 | 1.5.38.30 | Estación La Victoria: Hito de Aprobación Para Pago Urbanismo, Paisajismo y Pavimentos | milestone | 0d | 2025-03-19 | 2025-03-19 | 1193, 1198, 1208, 1203 | 197d |  | 0,00% | 0,00% | 0,00% | 0,00% |
| 1217 | 1.5.38.31 | Estación La Victoria: Hito de Aprobación Para Pago Componente Electromecánico | milestone | 0d | 2024-11-26 | 2024-11-26 | 1063 | 281d |  | 0,00% | 0,00% | 0,00% | 0,00% |

| ID | WBS | Task | Type | Duration | Start | Finish | Predecessors | Total slack | Free slack | % Avance Planeado | % avance planeado en costo (texto) | % Completado (décimales) | % Completado en Costo |
| --- | --- | --- | --- | --- | --- | --- | --- | --- | --- | --- | --- | --- | --- |
| 1218 | 1.5.39 | **EMPALME No 1 BUCLE 20 DE JULIO - LA VICTORIA-ALTAMIRA. HALADO - AJUSTE MECÁNICO - HALADO Y EMPALME -AJUSTE ELÉCTRICO** |  | 81d | 2024-11-28 | 2025-03-18 |  | 0d |  | 0,00% | 0,00% | 0,00% | 0,00% |
| 1219 | 1.5.39.1 | Cable Piloto |  | 33d | 2024-11-28 | 2025-01-14 | 172, 1066, 963 | 0d |  | 0,00% | 0,00% | 0,00% | 0,00% |
| 1220 | 1.5.39.2 | Cable Portador de la Línea de Seguridad |  | 16d | 2025-01-15 | 2025-02-04 | 1219 | 0d |  | 0,00% | 0,00% | 0,00% | 0,00% |
| 1221 | 1.5.39.3 | Cable Portador Tractor |  | 16d | 2025-02-05 | 2025-02-25 | 1220 | 198d | 0d | 0,00% | 0,00% | 0,00% | 0,00% |
| 1222 | 1.5.39.4 | Multiconductores de la Línea de Seguridad |  | 16d | 2025-02-26 | 2025-03-18 | 1221 | 198d | 0d | 0,00% | 0,00% | 0,00% | 0,00% |
| 1223 | 1.5.39.5 | Fin Empalme No. 2 Bucle La Victoria - Altamira | milestone | 0d | 2025-03-18 | 2025-03-18 | 1222 | 198d |  | 0,00% | 0,00% | 0,00% | 0,00% |
| 1224 | 1.5.40 | Bucle 20 de Julio - La Victoria: Hito de Aprobación Para Pago Empalme No.1 | milestone | 0d | 2025-03-18 | 2025-03-18 | 1218 | 198d |  | 0,00% | 0,00% | 0,00% | 0,00% |
| 1225 | 1.5.41 | Entrega de predios por parte de IDU al constructor | milestone | 0d | 2023-07-13 | 2023-07-13 | 47 | 416d | 0d | 0,00% | 0,00% | 0,00% | 0,00% |
| 1226 | 1.5.42 | **PERMISOS** |  | 0d | 2023-07-13 | 2023-07-13 |  | 549d |  | 0,00% | 0,00% | 0,00% | 0,00% |
| 1227 | 1.5.42.1 | Trabajo Nocturno | milestone | 0d | 2023-07-13 | 2023-07-13 | 1225 | 549d | 133d | 0,00% | 0,00% | 0,00% | 0,00% |
| 1228 | 1.5.42.2 | Comunicaciones | milestone | 0d | 2023-07-13 | 2023-07-13 | 1225 | 549d | 133d | 0,00% | 0,00% | 0,00% | 0,00% |
| 1229 | 1.5.42.3 | Energía (baja Tensión) | milestone | 0d | 2023-07-13 | 2023-07-13 | 1225 | 549d | 133d | 0,00% | 0,00% | 0,00% | 0,00% |
| 1230 | 1.5.43 | **TORRE 12 y 13** |  | 153d | 2023-11-21 | 2024-06-24 |  | 186d |  | 0,00% | 0,00% | 0,00% | 0,00% |
| 1231 | 1.5.43.1 | TRASLADO DE REDES |  | 45d | 2024-01-18 | 2024-03-16 | 1225FS+133d, 1227, 1228, 1229 | 416d | 0d | 0,00% | 0,00% | 0,00% | 0,00% |
| 1232 | 1.5.43.2 | **PRELIMINARES DE OBRA, MOVIMIENTO DE TIERRAS Y RELLENOS** |  | 13d | 2024-01-19 | 2024-02-05 |  | 466d | 26d | 0,00% | 0,00% | 0,00% | 0,00% |
| 1233 | 1.5.43.2.1 | Replanteo General |  | 6d | 2024-01-19 | 2024-01-26 | 1231SS+1d | 466d | 0d | 0,00% | 0,00% | 0,00% | 0,00% |
| 1234 | 1.5.43.2.2 | Cerramiento y Señalización |  | 7d | 2024-01-26 | 2024-02-05 | 1233 | 492d | 26d | 0,00% | 0,00% | 0,00% | 0,00% |
| 1235 | 1.5.43.2.3 | Tala de Especies |  | 7d | 2024-01-26 | 2024-02-05 | 1233 | 492d | 26d | 0,00% | 0,00% | 0,00% | 0,00% |
| 1236 | 1.5.43.3 | **MOVIMIENTO DE TIERRAS** |  | 29d | 2024-02-01 | 2024-03-11 |  | 466d | 0d | 0,00% | 0,00% | 0,00% | 0,00% |
| 1237 | 1.5.43.3.1 | Excavación Meca nica En Material Común |  | 27d | 2024-02-01 | 2024-03-07 | 1233FS+4d | 466d | 0d | 0,00% | 0,00% | 0,00% | 0,00% |
| 1238 | 1.5.43.3.2 | Nivelación y Compactación de Subrasante |  | 2d | 2024-03-07 | 2024-03-11 | 1237 | 466d | 0d | 0,00% | 0,00% | 0,00% | 0,00% |
| 1239 | 1.5.43.3.3 | Transporte y Disposición Final de Escombros en Sitio Autorizado |  | 23d | 2024-02-01 | 2024-03-01 | 1237SS | 472d | 6d | 0,00% | 0,00% | 0,00% | 0,00% |
| 1240 | 1.5.43.4 | **CIMENTACIÓN** |  | 25d | 2023-11-21 | 2023-12-26 |  | 186d | 55d | 0,00% | 0,00% | 0,00% | 0,00% |
| 1241 | 1.5.43.4.1 | **CONSTRUCCIÓN PILOTES** |  | 7d | 2023-11-21 | 2023-11-30 |  | 186d |  | 0,00% | 0,00% | 0,00% | 0,00% |
| 1242 | 1.5.43.4.1.1 | Excavación para Pilotes |  | 5d | 2023-11-21 | 2023-11-28 | 944FS+1d | 186d | 0d | 0,00% | 0,00% | 0,00% | 0,00% |
| 1243 | 1.5.43.4.1.2 | Acero de Refuerzo |  | 3d | 2023-11-24 | 2023-11-29 | 1242FS-2d | 470d | 0d | 0,00% | 0,00% | 0,00% | 0,00% |
| 1244 | 1.5.43.4.1.3 | Concreto |  | 3d | 2023-11-27 | 2023-11-30 | 1243FS-2d | 470d | 0d | 0,00% | 0,00% | 0,00% | 0,00% |
| 1245 | 1.5.43.4.2 | Descabece de Pilotes |  | 2d | 2023-11-30 | 2023-12-02 | 1244 | 470d | 0d | 0,00% | 0,00% | 0,00% | 0,00% |

| ID | WBS | Task | Type | Duration | Start | Finish | Predecessors | Total slack | Free slack | % Avance Planeado | % avance planeado en costo (texto) | % Completado (décimales) | % Completado en Costo |
| --- | --- | --- | --- | --- | --- | --- | --- | --- | --- | --- | --- | --- | --- |
| 1246 | 1.5.43.4.3 | **CONSTRUCCIÓN DADOS DE CIMENTACIÓN** |  | 6d | 2023-12-04 | 2023-12-12 |  | 470d |  | 0,00% | 0,00% | 0,00% | 0,00% |
| 1247 | 1.5.43.4.3.1 | Acero de Refuerzo |  | 3d | 2023-12-04 | 2023-12-06 | 1245 | 470d | 0d | 0,00% | 0,00% | 0,00% | 0,00% |
| 1248 | 1.5.43.4.3.2 | Concreto |  | 3d | 2023-12-07 | 2023-12-12 | 1247 | 470d | 0d | 0,00% | 0,00% | 0,00% | 0,00% |
| 1249 | 1.5.43.4.4 | **PEDESTAL** |  | 10d | 2023-12-12 | 2023-12-26 |  | 470d |  | 0,00% | 0,00% | 0,00% | 0,00% |
| 1250 | 1.5.43.4.4.1 | Acero de Refuerzo |  | 5d | 2023-12-12 | 2023-12-19 | 1248 | 470d | 0d | 0,00% | 0,00% | 0,00% | 0,00% |
| 1251 | 1.5.43.4.4.2 | Concreto |  | 5d | 2023-12-19 | 2023-12-26 | 1250 | 470d | 0d | 0,00% | 0,00% | 0,00% | 0,00% |
| 1252 | 1.5.43.5 | **RELLENOS** |  | 4d | 2023-12-27 | 2024-01-02 |  | 470d | 51d | 0,00% | 0,00% | 0,00% | 0,00% |
| 1253 | 1.5.43.5.1 | Relleno De Material Seleccionado |  | 4d | 2023-12-27 | 2024-01-02 | 1251 | 470d | 0d | 0,00% | 0,00% | 0,00% | 0,00% |
| 1254 | 1.5.43.6 | **PUESTA A TIERRA** |  | 2d | 2024-01-02 | 2024-01-04 |  | 470d | 99d | 0,00% | 0,00% | 0,00% | 0,00% |
| 1255 | 1.5.43.6.1 | Instalación Cable de Cobre |  | 1d | 2024-01-02 | 2024-01-03 | 1253 | 470d | 0d | 0,00% | 0,00% | 0,00% | 0,00% |
| 1256 | 1.5.43.6.2 | Varilla COOPER WELD 5/8" x 2.44m. |  | 1d | 2024-01-03 | 2024-01-04 | 1255 | 470d | 0d | 0,00% | 0,00% | 0,00% | 0,00% |
| 1257 | 1.5.43.6.3 | Fin Puesta a Tierra | milestone | 0d | 2024-01-04 | 2024-01-04 | 1255, 1256 | 470d | 54d | 0,00% | 0,00% | 0,00% | 0,00% |
| 1258 | 1.5.43.7 | **MONTAJE ELECTROMECÁNICO** |  | 10d | 2024-06-11 | 2024-06-24 |  | 393d | 0d | 0,00% | 0,00% | 0,00% | 0,00% |
| 1259 | 1.5.43.7.1 | Montaje Mecánico |  | 5d | 2024-06-11 | 2024-06-17 | 961, 1251, 1309 | 393d | 0d | 0,00% | 0,00% | 0,00% | 0,00% |
| 1260 | 1.5.43.7.2 | Montaje Eléctrico |  | 5d | 2024-06-17 | 2024-06-24 | 1259 | 393d | 0d | 0,00% | 0,00% | 0,00% | 0,00% |
| 1261 | 1.5.43.7.3 | Fin montaje Electromecánico | milestone | 0d | 2024-06-24 | 2024-06-24 | 1259, 1260 | 393d |  | 0,00% | 0,00% | 0,00% | 0,00% |
| 1262 | 1.5.43.8 | **CERTIFICACIONES RETIE Y RETILAP** |  | 45d | 2024-03-18 | 2024-05-21 |  | 416d | 0d | 0,00% | 0,00% | 0,00% | 0,00% |
| 1263 | 1.5.43.8.1 | Certificación RETIE |  | 45d | 2024-03-18 | 2024-05-21 | 1257, 1231 | 416d | 0d | 0,00% | 0,00% | 0,00% | 0,00% |
| 1264 | 1.5.43.8.2 | Certificación RETILAP |  | 45d | 2024-03-18 | 2024-05-21 | 1263SS | 416d | 0d | 0,00% | 0,00% | 0,00% | 0,00% |
| 1265 | 1.5.43.8.3 | Fin Certificaciones RETIE Y RETILAP | milestone | 0d | 2024-05-21 | 2024-05-21 | 1264 | 416d |  | 0,00% | 0,00% | 0,00% | 0,00% |
| 1266 | 1.5.43.9 | FIN TORRE 12 | milestone | 0d | 2024-03-11 | 2024-03-11 | 1234, 1235, 1238, 1239 | 466d |  | 0,00% | 0,00% | 0,00% | 0,00% |
| 1267 | 1.5.43.10 | Torre 12 y 13: Hito de Aprobación Para Pago Preliminares y Cimentación | milestone | 0d | 2024-03-11 | 2024-03-11 | 1232, 1236, 1240, 1252 | 466d |  | 0,00% | 0,00% | 0,00% | 0,00% |
| 1268 | 1.5.43.11 | Torre 12 y 13: Hito de Aprobación Para Pago Redes | milestone | 0d | 2024-05-21 | 2024-05-21 | 1231, 1254, 1262 | 416d |  | 0,00% | 0,00% | 0,00% | 0,00% |
| 1269 | 1.5.43.12 | Torre 12 y 13: Hito de Aprobación Para Pago Electromecánico | milestone | 0d | 2024-06-24 | 2024-06-24 | 1258 | 393d |  | 0,00% | 0,00% | 0,00% | 0,00% |
| 1270 | 1.5.44 | Entrega de predios por parte de IDU al constructor | milestone | 0d | 2023-09-14 | 2023-09-14 | 47FS+45d | 228d | 0d | 0,00% | 0,00% | 0,00% | 0,00% |

| ID | WBS | Task | Type | Duration | Start | Finish | Predecessors | Total slack | Free slack | % Avance Planeado | % avance planeado en costo (texto) | % Completado (décimales) | % Completado en Costo |
| --- | --- | --- | --- | --- | --- | --- | --- | --- | --- | --- | --- | --- | --- |
| 1271 | 1.5.45 | **PERMISOS** |  | 0d | 2023-09-14 | 2023-09-14 |  | 228d |  | 0,00% | 0,00% | 0,00% | 0,00% |
| 1272 | 1.5.45.1 | Trabajo Nocturno | milestone | 0d | 2023-09-14 | 2023-09-14 | 1270 | 480d | 100d | 0,00% | 0,00% | 0,00% | 0,00% |
| 1273 | 1.5.45.2 | Comunicaciones | milestone | 0d | 2023-09-14 | 2023-09-14 | 1270 | 480d | 100d | 0,00% | 0,00% | 0,00% | 0,00% |
| 1274 | 1.5.45.3 | Energía (baja Tensión) | milestone | 0d | 2023-09-14 | 2023-09-14 | 1270 | 480d | 100d | 0,00% | 0,00% | 0,00% | 0,00% |
| 1275 | 1.5.45.4 | Gestión Interinstitucional IDRD | milestone | 0d | 2023-09-14 | 2023-09-14 | 1270 | 480d | 100d | 0,00% | 0,00% | 0,00% | 0,00% |
| 1276 | 1.5.45.5 | PMT | milestone | 0d | 2023-09-14 | 2023-09-14 | 1270 | 228d | 0d | 0,00% | 0,00% | 0,00% | 0,00% |
| 1277 | 1.5.46 | **TORRE 14** |  | 160d | 2023-11-29 | 2024-07-11 |  | 186d |  | 0,00% | 0,00% | 0,00% | 0,00% |
| 1278 | 1.5.46.1 | TRASLADO DE REDES |  | 45d | 2024-02-02 | 2024-04-05 | 1270FS+100d, 1272, 1273, 1274, 1275, 1276 | 380d | 0d | 0,00% | 0,00% | 0,00% | 0,00% |
| 1279 | 1.5.46.2 | **PRELIMINARES DE OBRA, MOVIMIENTO DE TIERRAS Y RELLENOS** |  | 49d | 2024-02-14 | 2024-04-23 |  | 436d | 56d | 0,00% | 0,00% | 0,00% | 0,00% |
| 1280 | 1.5.46.2.1 | Replanteo General |  | 6d | 2024-02-14 | 2024-02-22 | 1278SS+9d | 436d | 0d | 0,00% | 0,00% | 0,00% | 0,00% |
| 1281 | 1.5.46.2.2 | Cerramiento y Señalización |  | 7d | 2024-02-22 | 2024-03-01 | 1280 | 472d | 18d | 0,00% | 0,00% | 0,00% | 0,00% |
| 1282 | 1.5.46.2.3 | Tala de Especies |  | 7d | 2024-02-22 | 2024-03-01 | 1280 | 436d | 0d | 0,00% | 0,00% | 0,00% | 0,00% |
| 1283 | 1.5.46.2.4 | **DEMOLICIONES** |  | 36d | 2024-03-02 | 2024-04-23 |  | 436d | 56d | 0,00% | 0,00% | 0,00% | 0,00% |
| 1284 | 1.5.46.2.4.1 | Demoliciones de construcciones existentes |  | 36d | 2024-03-02 | 2024-04-23 | 1282 | 436d | 0d | 0,00% | 0,00% | 0,00% | 0,00% |
| 1285 | 1.5.46.2.4.2 | Fin demoliciones | milestone | 0d | 2024-04-23 | 2024-04-23 | 1284 | 436d |  | 0,00% | 0,00% | 0,00% | 0,00% |
| 1286 | 1.5.46.3 | **MOVIMIENTO DE TIERRAS** |  | 25d | 2024-02-22 | 2024-03-27 |  | 454d | 74d | 0,00% | 0,00% | 0,00% | 0,00% |
| 1287 | 1.5.46.3.1 | Excavación Mecánica En Material Común |  | 23d | 2024-02-22 | 2024-03-22 | 1280 | 454d | 0d | 0,00% | 0,00% | 0,00% | 0,00% |
| 1288 | 1.5.46.3.2 | Nivelación y Compactación de Subrasante |  | 2d | 2024-03-23 | 2024-03-27 | 1287 | 454d | 0d | 0,00% | 0,00% | 0,00% | 0,00% |
| 1289 | 1.5.46.3.3 | Transporte y Disposición Final de Escombros en Sitio Autorizado |  | 20d | 2024-02-22 | 2024-03-19 | 1287SS | 459d | 5d | 0,00% | 0,00% | 0,00% | 0,00% |
| 1290 | 1.5.46.4 | **CIMENTACIÓN** |  | 25d | 2023-11-29 | 2024-01-04 |  | 186d | 135d | 0,00% | 0,00% | 0,00% | 0,00% |
| 1291 | 1.5.46.4.1 | **CONSTRUCCIÓN CAISSONS** |  | 7d | 2023-11-29 | 2023-12-07 |  | 186d |  | 0,00% | 0,00% | 0,00% | 0,00% |
| 1292 | 1.5.46.4.1.1 | Excavación para Pilotes |  | 5d | 2023-11-29 | 2023-12-05 | 1242FS+1d | 186d | 0d | 0,00% | 0,00% | 0,00% | 0,00% |
| 1293 | 1.5.46.4.1.2 | Acero de Refuerzo |  | 3d | 2023-12-04 | 2023-12-06 | 1292FS-2d | 186d | 0d | 0,00% | 0,00% | 0,00% | 0,00% |
| 1294 | 1.5.46.4.1.3 | Concreto |  | 3d | 2023-12-05 | 2023-12-07 | 1293FS-2d | 186d | 0d | 0,00% | 0,00% | 0,00% | 0,00% |
| 1295 | 1.5.46.4.2 | Descabece de Pilotes |  | 2d | 2023-12-09 | 2023-12-12 | 1294 | 186d | 0d | 0,00% | 0,00% | 0,00% | 0,00% |

| ID | WBS | Task | Type | Duration | Start | Finish | Predecessors | Total slack | Free slack | % Avance Planeado | % avance planeado en costo (texto) | % Completado (décimales) | % Completado en Costo |
| --- | --- | --- | --- | --- | --- | --- | --- | --- | --- | --- | --- | --- | --- |
| 1296 | 1.5.46.4.3 | **CONSTRUCCIÓN DADOS DE CIMENTACIÓN** |  | 6d | 2023-12-12 | 2023-12-20 |  | 186d |  | 0,00% | 0,00% | 0,00% | 0,00% |
| 1297 | 1.5.46.4.3.1 | Acero de Refuerzo |  | 3d | 2023-12-12 | 2023-12-15 | 1295 | 186d | 0d | 0,00% | 0,00% | 0,00% | 0,00% |
| 1298 | 1.5.46.4.3.2 | Concreto |  | 3d | 2023-12-15 | 2023-12-20 | 1297 | 186d | 0d | 0,00% | 0,00% | 0,00% | 0,00% |
| 1299 | 1.5.46.4.4 | **PEDESTAL** |  | 10d | 2023-12-20 | 2024-01-04 |  | 186d |  | 0,00% | 0,00% | 0,00% | 0,00% |
| 1300 | 1.5.46.4.4.1 | Acero de Refuerzo |  | 5d | 2023-12-20 | 2023-12-27 | 1298 | 186d | 0d | 0,00% | 0,00% | 0,00% | 0,00% |
| 1301 | 1.5.46.4.4.2 | Concreto |  | 5d | 2023-12-28 | 2024-01-04 | 1300 | 186d | 0d | 0,00% | 0,00% | 0,00% | 0,00% |
| 1302 | 1.5.46.5 | **RELLENOS** |  | 4d | 2024-01-04 | 2024-01-11 |  | 439d | 131d | 0,00% | 0,00% | 0,00% | 0,00% |
| 1303 | 1.5.46.5.1 | Relleno De Material Seleccionado |  | 4d | 2024-01-04 | 2024-01-11 | 1301 | 439d | 0d | 0,00% | 0,00% | 0,00% | 0,00% |
| 1304 | 1.5.46.6 | **PUESTA A TIERRA** |  | 2d | 2024-01-11 | 2024-01-13 |  | 440d | 105d | 0,00% | 0,00% | 0,00% | 0,00% |
| 1305 | 1.5.46.6.1 | Instalación Cable de Cobre |  | 1d | 2024-01-11 | 2024-01-12 | 1303 | 440d | 0d | 0,00% | 0,00% | 0,00% | 0,00% |
| 1306 | 1.5.46.6.2 | Varilla COOPER WELD 5/8" x 2.44m. |  | 1d | 2024-01-12 | 2024-01-13 | 1305 | 440d | 0d | 0,00% | 0,00% | 0,00% | 0,00% |
| 1307 | 1.5.46.6.3 | Fin Puesta a Tierra | milestone | 0d | 2024-01-13 | 2024-01-13 | 1305, 1306 | 440d | 60d | 0,00% | 0,00% | 0,00% | 0,00% |
| 1308 | 1.5.46.7 | **MONTAJE ELECTROMECÁNICO** |  | 10d | 2024-01-04 | 2024-01-18 |  | 186d | 0d | 0,00% | 0,00% | 0,00% | 0,00% |
| 1309 | 1.5.46.7.1 | Montaje Mecánico |  | 5d | 2024-01-04 | 2024-01-12 | 1301 | 186d | 0d | 0,00% | 0,00% | 0,00% | 0,00% |
| 1310 | 1.5.46.7.2 | Montaje Eléctrico |  | 5d | 2024-01-12 | 2024-01-18 | 1309 | 433d | 0d | 0,00% | 0,00% | 0,00% | 0,00% |
| 1311 | 1.5.46.7.3 | Fin montaje Electromecánico | milestone | 0d | 2024-01-18 | 2024-01-18 | 1309, 1310 | 433d | 0d | 0,00% | 0,00% | 0,00% | 0,00% |
| 1312 | 1.5.46.8 | **ALUMBRADO PÚBLICO DE TORRE** |  | 5d | 2024-01-19 | 2024-01-25 |  | 433d | 96d | 0,00% | 0,00% | 0,00% | 0,00% |
| 1313 | 1.5.46.8.1 | Tubería Eléctrica PVC |  | 5d | 2024-01-19 | 2024-01-25 | 1311, 1303, 1301 | 433d | 0d | 0,00% | 0,00% | 0,00% | 0,00% |
| 1314 | 1.5.46.8.2 | Accesorios |  | 1d | 2024-01-19 | 2024-01-19 | 1313SS | 433d | 0d | 0,00% | 0,00% | 0,00% | 0,00% |
| 1315 | 1.5.46.8.3 | Cableado |  | 1d | 2024-01-20 | 2024-01-22 | 1314 | 433d | 0d | 0,00% | 0,00% | 0,00% | 0,00% |
| 1316 | 1.5.46.8.4 | Instalación de A.P. |  | 1d | 2024-01-22 | 2024-01-23 | 1315 | 433d | 0d | 0,00% | 0,00% | 0,00% | 0,00% |
| 1317 | 1.5.46.8.5 | Fin Alumbrado Público de Torre | milestone | 0d | 2024-01-23 | 2024-01-23 | 1316 | 433d | 53d | 0,00% | 0,00% | 0,00% | 0,00% |
| 1318 | 1.5.46.9 | **CERTIFICACIONES RETIE Y RETILAP** |  | 45d | 2024-04-05 | 2024-06-07 |  | 380d | 0d | 0,00% | 0,00% | 0,00% | 0,00% |
| 1319 | 1.5.46.9.1 | Certificación RETIE |  | 45d | 2024-04-05 | 2024-06-07 | 1317, 1307, 1278 | 380d | 0d | 0,00% | 0,00% | 0,00% | 0,00% |
| 1320 | 1.5.46.9.2 | Certificación RETILAP |  | 45d | 2024-04-05 | 2024-06-07 | 1319SS | 380d | 0d | 0,00% | 0,00% | 0,00% | 0,00% |
| 1321 | 1.5.46.9.3 | Fin Certificaciones RETIE Y RETILAP | milestone | 0d | 2024-06-07 | 2024-06-07 | 1320 | 380d | 0d | 0,00% | 0,00% | 0,00% | 0,00% |

| ID | WBS | Task | Type | Duration | Start | Finish | Predecessors | Total slack | Free slack | % Avance Planeado | % avance planeado en costo (texto) | % Completado (décimales) | % Completado en Costo |
| --- | --- | --- | --- | --- | --- | --- | --- | --- | --- | --- | --- | --- | --- |
| 1322 | 1.5.46.10 | **URBANISMO Y PAISAJISMO** |  | 131d | 2024-01-11 | 2024-07-11 |  | 380d | 0d | 0,00% | 0,00% | 0,00% | 0,00% |
| 1323 | 1.5.46.10.1 | **ESTRUCTURAS DE CONTENCIÓN PARA URBANISMO** |  | 24d | 2024-06-07 | 2024-07-11 |  | 380d | 0d | 0,00% | 0,00% | 0,00% | 0,00% |
| 1324 | 1.5.46.10.1.1 | Construcción de muros en concreto reforzado y mampostería estructural. Incluye otros elementos y construcción de filtro de drenaje tras muro. |  | 24d | 2024-06-07 | 2024-07-11 | 1321 | 380d | 0d | 0,00% | 0,00% | 0,00% | 0,00% |
| 1325 | 1.5.46.10.1.2 | Fin Estructuras de contención para urbanismo | milestone | 0d | 2024-07-11 | 2024-07-11 | 1324 | 380d |  | 0,00% | 0,00% | 0,00% | 0,00% |
| 1326 | 1.5.46.10.2 | **PAISAJISMO** |  | 6d | 2024-01-11 | 2024-01-18 |  | 482d |  | 0,00% | 0,00% | 0,00% | 0,00% |
| 1327 | 1.5.46.10.2.1 | Contenedores de raices, Instalación de grama y hiedras. Incluye tierra negra. |  | 1d | 2024-01-11 | 2024-01-12 | 1303 | 482d | 0d | 0,00% | 0,00% | 0,00% | 0,00% |
| 1328 | 1.5.46.10.2.2 | Especies arboreas |  | 1d | 2024-01-11 | 2024-01-12 | 1327SS | 510d | 56d | 0,00% | 0,00% | 0,00% | 0,00% |
| 1329 | 1.5.46.10.2.3 | Jardines verticales |  | 5d | 2024-01-12 | 2024-01-18 | 1327 | 505d | 51d | 0,00% | 0,00% | 0,00% | 0,00% |
| 1330 | 1.5.46.10.3 | **URBANISMO** |  | 29d | 2024-01-11 | 2024-02-19 |  | 482d |  | 0,00% | 0,00% | 0,00% | 0,00% |
| 1331 | 1.5.46.10.3.1 | Instalación de prefabricados. Incluye cañuelas, sardineles, bordillos, pisos en adoquín, tabletas y concreto escobeado. |  | 24d | 2024-01-11 | 2024-02-12 | 1327SS | 482d | 0d | 0,00% | 0,00% | 0,00% | 0,00% |
| 1332 | 1.5.46.10.3.2 | Mobiliario y elementos independientes |  | 5d | 2024-02-12 | 2024-02-19 | 1331 | 482d | 28d | 0,00% | 0,00% | 0,00% | 0,00% |
| 1333 | 1.5.46.11 | FIN TORRE 14 | milestone | 0d | 2024-03-27 | 2024-03-27 | 1281, 1282, 1288, 1289, 1328, 1329, 1332 | 454d |  | 0,00% | 0,00% | 0,00% | 0,00% |
| 1334 | 1.5.46.12 | Torre 14: Hito de Aprobación Para Pago Preliminares, demoliciones, excavación y Cimentación | milestone | 0d | 2024-07-11 | 2024-07-11 | 1279, 1286, 1290, 1302, 1322, 1283, 1323 | 380d |  | 0,00% | 0,00% | 0,00% | 0,00% |
| 1335 | 1.5.46.13 | Torre 14: Hito de Aprobación Para Pago Redes | milestone | 0d | 2024-06-07 | 2024-06-07 | 1278, 1304, 1312, 1318 | 404d |  | 0,00% | 0,00% | 0,00% | 0,00% |
| 1336 | 1.5.46.14 | Torre 14: Hito de Aprobación Para Pago Electromecánico | milestone | 0d | 2024-01-18 | 2024-01-18 | 1308 | 505d |  | 0,00% | 0,00% | 0,00% | 0,00% |
| 1337 | 1.5.47 | Entrega de predios por parte de IDU al constructor | milestone | 0d | 2023-07-13 | 2023-07-13 | 47 | 469d | 0d | 0,00% | 0,00% | 0,00% | 0,00% |
| 1338 | 1.5.48 | **PERMISOS** |  | 0d | 2023-07-13 | 2023-07-13 |  | 549d |  | 0,00% | 0,00% | 0,00% | 0,00% |
| 1339 | 1.5.48.1 | Trabajo Nocturno | milestone | 0d | 2023-07-13 | 2023-07-13 | 1337 | 549d | 80d | 0,00% | 0,00% | 0,00% | 0,00% |
| 1340 | 1.5.48.2 | Silvicultura les | milestone | 0d | 2023-07-13 | 2023-07-13 | 1337 | 549d | 80d | 0,00% | 0,00% | 0,00% | 0,00% |
| 1341 | 1.5.48.3 | Energía (baja Tensión) | milestone | 0d | 2023-07-13 | 2023-07-13 | 1337 | 549d | 80d | 0,00% | 0,00% | 0,00% | 0,00% |
| 1342 | 1.5.48.4 | Gestión Interinstitucional IDRD | milestone | 0d | 2023-07-13 | 2023-07-13 | 1337 | 549d | 80d | 0,00% | 0,00% | 0,00% | 0,00% |
| 1343 | 1.5.48.5 | Gestión Comunidad Recuperación Espacio Público | milestone | 0d | 2023-07-13 | 2023-07-13 | 1337 | 549d | 80d | 0,00% | 0,00% | 0,00% | 0,00% |
| 1344 | 1.5.48.6 | PMT | milestone | 0d | 2023-07-13 | 2023-07-13 | 1337 | 549d | 80d | 0,00% | 0,00% | 0,00% | 0,00% |
| 1345 | 1.5.49 | **TORRE 15** |  | 128d | 2023-09-12 | 2024-03-06 |  | 241d |  | 0,00% | 0,00% | 0,00% | 0,00% |
| 1346 | 1.5.49.1 | TRASLADO DE REDES |  | 45d | 2023-11-01 | 2024-01-05 | 1337FS+80d, 1339, 1340, 1341, 1342, 1343, 1344 | 469d | 0d | 0,00% | 0,00% | 0,00% | 0,00% |

| ID | WBS | Task | Type | Duration | Start | Finish | Predecessors | Total slack | Free slack | % Avance Planeado | % avance planeado en costo (texto) | % Completado (décimales) | % Completado en Costo |
| --- | --- | --- | --- | --- | --- | --- | --- | --- | --- | --- | --- | --- | --- |
| 1347 | 1.5.49.2 | **PRELIMINARES DE OBRA, MOVIMIENTO DE TIERRAS Y RELLENOS** |  | 57d | 2023-11-08 | 2024-01-29 |  | 477d | 21d | 0,00% | 0,00% | 0,00% | 0,00% |
| 1348 | 1.5.49.2.1 | Replanteo General |  | 6d | 2023-11-08 | 2023-11-16 | 1346SS+4d | 477d | 0d | 0,00% | 0,00% | 0,00% | 0,00% |
| 1349 | 1.5.49.2.2 | Cerramiento y Señalización |  | 7d | 2023-11-17 | 2023-11-27 | 1348 | 542d | 15d | 0,00% | 0,00% | 0,00% | 0,00% |
| 1350 | 1.5.49.2.3 | Tala de Especies |  | 7d | 2023-11-17 | 2023-11-27 | 1348 | 498d | 0d | 0,00% | 0,00% | 0,00% | 0,00% |
| 1351 | 1.5.49.2.4 | **DEMOLICIONES** |  | 44d | 2023-11-27 | 2024-01-29 |  | 498d | 21d | 0,00% | 0,00% | 0,00% | 0,00% |
| 1352 | 1.5.49.2.4.1 | Demoliciones de construcciones existentes |  | 44d | 2023-11-27 | 2024-01-29 | 1350 | 498d | 0d | 0,00% | 0,00% | 0,00% | 0,00% |
| 1353 | 1.5.49.2.4.2 | Fin demoliciones | milestone | 0d | 2024-01-29 | 2024-01-29 | 1352 | 498d |  | 0,00% | 0,00% | 0,00% | 0,00% |
| 1354 | 1.5.49.3 | **MOVIMIENTO DE TIERRAS** |  | 22d | 2023-11-17 | 2023-12-18 |  | 477d | 50d | 0,00% | 0,00% | 0,00% | 0,00% |
| 1355 | 1.5.49.3.1 | Excavación Mecánica En Material Común |  | 20d | 2023-11-17 | 2023-12-14 | 1348 | 477d | 0d | 0,00% | 0,00% | 0,00% | 0,00% |
| 1356 | 1.5.49.3.2 | Nivelación y Compactación de Subrasante |  | 2d | 2023-12-14 | 2023-12-18 | 1355 | 527d | 0d | 0,00% | 0,00% | 0,00% | 0,00% |
| 1357 | 1.5.49.3.3 | Transporte y Disposición Final de Escombros en Sitio Autorizado |  | 20d | 2023-11-17 | 2023-12-14 | 1355SS | 529d | 2d | 0,00% | 0,00% | 0,00% | 0,00% |
| 1358 | 1.5.49.4 | **CIMENTACIÓN** |  | 25d | 2023-09-12 | 2023-10-13 |  | 241d | 95d | 0,00% | 0,00% | 0,00% | 0,00% |
| 1359 | 1.5.49.4.1 | **CONSTRUCCIÓN PILOTES** |  | 7d | 2023-09-12 | 2023-09-20 |  | 241d |  | 0,00% | 0,00% | 0,00% | 0,00% |
| 1360 | 1.5.49.4.1.1 | Excavación para Pilotes |  | 5d | 2023-09-12 | 2023-09-18 | 1927FS+1d | 241d | 0d | 0,00% | 0,00% | 0,00% | 0,00% |
| 1361 | 1.5.49.4.1.2 | Acero de Refuerzo |  | 3d | 2023-09-15 | 2023-09-19 | 1360FS-2d | 248d | 0d | 0,00% | 0,00% | 0,00% | 0,00% |
| 1362 | 1.5.49.4.1.3 | Concreto |  | 3d | 2023-09-16 | 2023-09-20 | 1361FS-2d | 248d | 0d | 0,00% | 0,00% | 0,00% | 0,00% |
| 1363 | 1.5.49.4.2 | Descabece de Pilotes |  | 2d | 2023-09-20 | 2023-09-22 | 1362 | 248d | 0d | 0,00% | 0,00% | 0,00% | 0,00% |
| 1364 | 1.5.49.4.3 | **CONSTRUCCIÓN DADOS DE CIMENTACIÓN** |  | 6d | 2023-09-22 | 2023-09-30 |  | 248d |  | 0,00% | 0,00% | 0,00% | 0,00% |
| 1365 | 1.5.49.4.3.1 | Acero de Refuerzo |  | 3d | 2023-09-22 | 2023-09-27 | 1363 | 248d | 0d | 0,00% | 0,00% | 0,00% | 0,00% |
| 1366 | 1.5.49.4.3.2 | Concreto |  | 3d | 2023-09-27 | 2023-09-30 | 1365 | 248d | 0d | 0,00% | 0,00% | 0,00% | 0,00% |
| 1367 | 1.5.49.4.4 | **PEDESTAL** |  | 10d | 2023-10-02 | 2023-10-13 |  | 248d |  | 0,00% | 0,00% | 0,00% | 0,00% |
| 1368 | 1.5.49.4.4.1 | Acero de Refuerzo |  | 5d | 2023-10-02 | 2023-10-06 | 1366 | 248d | 0d | 0,00% | 0,00% | 0,00% | 0,00% |
| 1369 | 1.5.49.4.4.2 | Concreto |  | 5d | 2023-10-07 | 2023-10-13 | 1368 | 248d | 0d | 0,00% | 0,00% | 0,00% | 0,00% |
| 1370 | 1.5.49.5 | **RELLENOS** |  | 4d | 2023-10-13 | 2023-10-20 |  | 514d | 91d | 0,00% | 0,00% | 0,00% | 0,00% |
| 1371 | 1.5.49.5.1 | Relleno De Material Seleccionado |  | 4d | 2023-10-13 | 2023-10-20 | 1369 | 514d | 0d | 0,00% | 0,00% | 0,00% | 0,00% |

| ID | WBS | Task | Type | Duration | Start | Finish | Predecessors | Total slack | Free slack | % Avance Planeado | % avance planeado en costo (texto) | % Completado (décimales) | % Completado en Costo |
| --- | --- | --- | --- | --- | --- | --- | --- | --- | --- | --- | --- | --- | --- |
| 1372 | 1.5.49.6 | **PUESTA A TIERRA** |  | 2d | 2023-10-20 | 2023-10-23 |  | 514d | 97d | 0,00% | 0,00% | 0,00% | 0,00% |
| 1373 | 1.5.49.6.1 | Instalación Cable de Cobre |  | 1d | 2023-10-20 | 2023-10-21 | 1371 | 514d | 0d | 0,00% | 0,00% | 0,00% | 0,00% |
| 1374 | 1.5.49.6.2 | Varilla COOPER WELD 5/8" x 2.44m. |  | 1d | 2023-10-23 | 2023-10-23 | 1373 | 514d | 0d | 0,00% | 0,00% | 0,00% | 0,00% |
| 1375 | 1.5.49.6.3 | Fin Puesta a Tierra | milestone | 0d | 2023-10-23 | 2023-10-23 | 1373, 1374 | 514d | 0d | 0,00% | 0,00% | 0,00% | 0,00% |
| 1376 | 1.5.49.7 | **MONTAJE ELECTROMECÁNICO** |  | 10d | 2024-01-12 | 2024-01-25 |  | 186d | 0d | 0,00% | 0,00% | 0,00% | 0,00% |
| 1377 | 1.5.49.7.1 | Montaje Mecánico |  | 5d | 2024-01-12 | 2024-01-18 | 1309, 1369 | 186d | 0d | 0,00% | 0,00% | 0,00% | 0,00% |
| 1378 | 1.5.49.7.2 | Montaje Eléctrico |  | 5d | 2024-01-19 | 2024-01-25 | 1377 | 500d | 0d | 0,00% | 0,00% | 0,00% | 0,00% |
| 1379 | 1.5.49.7.3 | Fin montaje Electromecánico | milestone | 0d | 2024-01-25 | 2024-01-25 | 1377, 1378 | 500d |  | 0,00% | 0,00% | 0,00% | 0,00% |
| 1380 | 1.5.49.8 | **ALIMENTACIÓN ELÉCTRICA** |  | 7d | 2023-10-24 | 2023-11-01 |  | 514d | 90d | 0,00% | 0,00% | 0,00% | 0,00% |
| 1381 | 1.5.49.8.1 | Instalacion de tuberia PVC |  | 5d | 2023-10-24 | 2023-10-30 | 1375, 1371, 1369 | 514d | 0d | 0,00% | 0,00% | 0,00% | 0,00% |
| 1382 | 1.5.49.8.2 | Cableado |  | 1d | 2023-10-30 | 2023-10-31 | 1381 | 514d | 0d | 0,00% | 0,00% | 0,00% | 0,00% |
| 1383 | 1.5.49.8.3 | Instalación de Medidor |  | 1d | 2023-10-31 | 2023-11-01 | 1382 | 514d | 0d | 0,00% | 0,00% | 0,00% | 0,00% |
| 1384 | 1.5.49.8.4 | Fin Alimentación Eléctrica | milestone | 0d | 2023-11-01 | 2023-11-01 | 1383 | 514d | 45d | 0,00% | 0,00% | 0,00% | 0,00% |
| 1385 | 1.5.49.9 | **ALUMBRADO PÚBLICO DE TORRE** |  | 5d | 2023-10-24 | 2023-10-30 |  | 518d | 92d | 0,00% | 0,00% | 0,00% | 0,00% |
| 1386 | 1.5.49.9.1 | Tubería Eléctrica PVC |  | 5d | 2023-10-24 | 2023-10-30 | 1381SS | 518d | 0d | 0,00% | 0,00% | 0,00% | 0,00% |
| 1387 | 1.5.49.9.2 | Accesorios |  | 1d | 2023-10-24 | 2023-10-24 | 1386SS | 518d | 0d | 0,00% | 0,00% | 0,00% | 0,00% |
| 1388 | 1.5.49.9.3 | Cableado |  | 1d | 2023-10-25 | 2023-10-25 | 1387 | 518d | 0d | 0,00% | 0,00% | 0,00% | 0,00% |
| 1389 | 1.5.49.9.4 | Instalación de A.P. |  | 1d | 2023-10-26 | 2023-10-26 | 1388 | 518d | 0d | 0,00% | 0,00% | 0,00% | 0,00% |
| 1390 | 1.5.49.9.5 | Fin Alumbrado Público de Torre | milestone | 0d | 2023-10-26 | 2023-10-26 | 1389 | 518d | 49d | 0,00% | 0,00% | 0,00% | 0,00% |
| 1391 | 1.5.49.10 | **CERTIFICACIONES RETIE Y RETILAP** |  | 45d | 2024-01-05 | 2024-03-06 |  | 469d | 0d | 0,00% | 0,00% | 0,00% | 0,00% |
| 1392 | 1.5.49.10.1 | Certificación RETIE |  | 45d | 2024-01-05 | 2024-03-06 | 1390, 1384, 1375, 1346 | 469d | 0d | 0,00% | 0,00% | 0,00% | 0,00% |
| 1393 | 1.5.49.10.2 | Certificación RETILAP |  | 45d | 2024-01-05 | 2024-03-06 | 1392SS | 469d | 0d | 0,00% | 0,00% | 0,00% | 0,00% |
| 1394 | 1.5.49.10.3 | Fin Certificaciones RETIE Y RETILAP | milestone | 0d | 2024-03-06 | 2024-03-06 | 1393 | 469d |  | 0,00% | 0,00% | 0,00% | 0,00% |
| 1395 | 1.5.49.11 | **REDES HIDRÁULICAS EXTERNAS** |  | 7d | 2023-11-17 | 2023-11-27 |  | 477d | 73d | 0,00% | 0,00% | 0,00% | 0,00% |
| 1396 | 1.5.49.11.1 | **RED DE ALCANTARILLADO** |  | 7d | 2023-11-17 | 2023-11-27 |  | 477d |  | 0,00% | 0,00% | 0,00% | 0,00% |
| 1397 | 1.5.49.11.1.1 | Excavación manual para redes y canal monolítico |  | 5d | 2023-11-17 | 2023-11-23 | 1355SS | 477d | 0d | 0,00% | 0,00% | 0,00% | 0,00% |
| 1398 | 1.5.49.11.1.2 | Instalación de tubería, incluye accesorios. |  | 2d | 2023-11-21 | 2023-11-23 | 1397SS+3d | 542d | 0d | 0,00% | 0,00% | 0,00% | 0,00% |
| 1399 | 1.5.49.11.1.3 | Rellenos para redes y canal |  | 3d | 2023-11-22 | 2023-11-27 | 1398SS+1d | 542d | 15d | 0,00% | 0,00% | 0,00% | 0,00% |
| 1400 | 1.5.49.11.1.4 | Instalación de canal monolítico |  | 2d | 2023-11-21 | 2023-11-23 | 1397SS+3d | 477d | 0d | 0,00% | 0,00% | 0,00% | 0,00% |

| ID | WBS | Task | Type | Duration | Start | Finish | Predecessors | Total slack | Free slack | % Avance Planeado | % avance planeado en costo (texto) | % Completado (décimales) | % Completado en Costo |
| --- | --- | --- | --- | --- | --- | --- | --- | --- | --- | --- | --- | --- | --- |
| 1401 | 1.5.49.12 | **URBANISMO Y PAISAJISMO** |  | 91d | 2023-10-20 | 2024-02-24 |  | 477d | 0d | 0,00% | 0,00% | 0,00% | 0,00% |
| 1402 | 1.5.49.12.1 | **ESTRUCTURAS DE CONTENCIÓN PARA URBANISMO** |  | 67d | 2023-11-23 | 2024-02-24 |  | 477d | 0d | 0,00% | 0,00% | 0,00% | 0,00% |
| 1403 | 1.5.49.12.1.1 | Construcción de muros en concreto reforzado y mampostería estructural. Incluye otros elementos y construcción de filtro de drenaje tras muro. |  | 38d | 2023-11-23 | 2024-01-17 | 1400 | 477d | 0d | 0,00% | 0,00% | 0,00% | 0,00% |
| 1404 | 1.5.49.12.1.2 | Construcción de escaleras. |  | 15d | 2024-02-06 | 2024-02-24 | 1403FS+14d | 477d | 0d | 0,00% | 0,00% | 0,00% | 0,00% |
| 1405 | 1.5.49.12.1.3 | Fin Estructuras de contención para urbanismo | milestone | 0d | 2024-02-24 | 2024-02-24 | 1404 | 477d |  | 0,00% | 0,00% | 0,00% | 0,00% |
| 1406 | 1.5.49.12.2 | **PAISAJISMO** |  | 15d | 2023-10-20 | 2023-11-10 |  | 529d |  | 0,00% | 0,00% | 0,00% | 0,00% |
| 1407 | 1.5.49.12.2.1 | Contenedores de raices, Instalación de grama y hiedras. Incluye tierra negra. |  | 5d | 2023-10-20 | 2023-10-26 | 1371 | 529d | 0d | 0,00% | 0,00% | 0,00% | 0,00% |
| 1408 | 1.5.49.12.2.2 | Especies arboreas |  | 1d | 2023-10-20 | 2023-10-21 | 1407SS | 567d | 40d | 0,00% | 0,00% | 0,00% | 0,00% |
| 1409 | 1.5.49.12.2.3 | Jardines horizontales y verticales |  | 10d | 2023-10-27 | 2023-11-10 | 1407 | 553d | 26d | 0,00% | 0,00% | 0,00% | 0,00% |
| 1410 | 1.5.49.12.3 | **URBANISMO** |  | 39d | 2023-10-20 | 2023-12-14 |  | 529d |  | 0,00% | 0,00% | 0,00% | 0,00% |
| 1411 | 1.5.49.12.3.1 | Instalación de prefabricados. Incluye cañuelas, sardineles, bordillos, pisos en adoquín, tabletas y concreto escobeado. |  | 27d | 2023-10-20 | 2023-11-28 | 1407SS | 529d | 0d | 0,00% | 0,00% | 0,00% | 0,00% |
| 1412 | 1.5.49.12.3.2 | Mobiliario y elementos independientes |  | 12d | 2023-11-28 | 2023-12-14 | 1411 | 529d | 2d | 0,00% | 0,00% | 0,00% | 0,00% |
| 1413 | 1.5.49.13 | FIN TORRE 15 | milestone | 0d | 2023-12-18 | 2023-12-18 | 1349, 1350, 1356, 1357, 1399, 1400, 1408, 1409, 1412 | 527d |  | 0,00% | 0,00% | 0,00% | 0,00% |
| 1414 | 1.5.49.14 | Torre 15: Hito de Aprobación Para Pago Preliminares, Demoliones, Excavación y Cimentación | milestone | 0d | 2024-02-24 | 2024-02-24 | 1347, 1354, 1358, 1370, 1401, 1351, 1402 | 477d |  | 0,00% | 0,00% | 0,00% | 0,00% |
| 1415 | 1.5.49.15 | Torre 15: Hito de Aprobación Para Pago Redes | milestone | 0d | 2024-03-06 | 2024-03-06 | 1346, 1372, 1380, 1385, 1391, 1395 | 469d |  | 0,00% | 0,00% | 0,00% | 0,00% |
| 1416 | 1.5.49.16 | Torre 15: Hito de Aprobación Para Pago Electromecánico | milestone | 0d | 2024-01-25 | 2024-01-25 | 1376 | 500d |  | 0,00% | 0,00% | 0,00% | 0,00% |
| 1417 | 1.5.50 | Entrega de predios por parte de IDU al constructor | milestone | 0d | 2023-08-11 | 2023-08-11 | 47FS+20d | 509d | 0d | 0,00% | 0,00% | 0,00% | 0,00% |
| 1418 | 1.5.51 | **PERMISOS** |  | 0d | 2023-08-11 | 2023-08-11 |  | 529d |  | 0,00% | 0,00% | 0,00% | 0,00% |
| 1419 | 1.5.51.1 | Trabajo Nocturno | milestone | 0d | 2023-08-11 | 2023-08-11 | 1417 | 529d | 20d | 0,00% | 0,00% | 0,00% | 0,00% |
| 1420 | 1.5.51.2 | Comunicaciones | milestone | 0d | 2023-08-11 | 2023-08-11 | 1417 | 529d | 20d | 0,00% | 0,00% | 0,00% | 0,00% |
| 1421 | 1.5.51.3 | Energía (baja Tensión) | milestone | 0d | 2023-08-11 | 2023-08-11 | 1417 | 529d | 20d | 0,00% | 0,00% | 0,00% | 0,00% |
| 1422 | 1.5.52 | **TORRE 16** |  | 156d | 2023-09-08 | 2024-04-12 |  | 249d |  | 0,00% | 0,00% | 0,00% | 0,00% |
| 1423 | 1.5.52.1 | TRASLADO DE REDES |  | 45d | 2023-09-08 | 2023-11-09 | 1417FS+20d, 1419, 1420, 1421 | 509d | 0d | 0,00% | 0,00% | 0,00% | 0,00% |
| 1424 | 1.5.52.2 | **PRELIMINARES DE OBRA, MOVIMIENTO DE TIERRAS Y RELLENOS** |  | 9d | 2023-11-14 | 2023-11-24 |  | 521d | 22d | 0,00% | 0,00% | 0,00% | 0,00% |
| 1425 | 1.5.52.2.1 | Replanteo General |  | 4d | 2023-11-14 | 2023-11-17 | 1423FS+2d | 521d | 0d | 0,00% | 0,00% | 0,00% | 0,00% |
| 1426 | 1.5.52.2.2 | Cerramiento y Señalización |  | 5d | 2023-11-18 | 2023-11-24 | 1425 | 543d | 22d | 0,00% | 0,00% | 0,00% | 0,00% |
| 1427 | 1.5.52.2.3 | Tala de Especies |  | 5d | 2023-11-18 | 2023-11-24 | 1425 | 543d | 22d | 0,00% | 0,00% | 0,00% | 0,00% |

| ID | WBS | Task | Type | Duration | Start | Finish | Predecessors | Total slack | Free slack | % Avance Planeado | % avance planeado en costo (texto) | % Completado (décimales) | % Completado en Costo |
| --- | --- | --- | --- | --- | --- | --- | --- | --- | --- | --- | --- | --- | --- |
| 1428 | 1.5.52.3 | **MOVIMIENTO DE TIERRAS** |  | 22d | 2023-11-24 | 2023-12-26 |  | 521d | 0d | 0,00% | 0,00% | 0,00% | 0,00% |
| 1429 | 1.5.52.3.1 | Excavación Mecánica En Material Común |  | 20d | 2023-11-24 | 2023-12-22 | 1425FS+5d | 521d | 0d | 0,00% | 0,00% | 0,00% | 0,00% |
| 1430 | 1.5.52.3.2 | Nivelación y Compactación de Subrasante |  | 2d | 2023-12-22 | 2023-12-26 | 1429 | 521d | 0d | 0,00% | 0,00% | 0,00% | 0,00% |
| 1431 | 1.5.52.3.3 | Transporte y Disposición Final de Escombros en Sitio Autorizado |  | 20d | 2023-11-24 | 2023-12-22 | 1429SS | 523d | 2d | 0,00% | 0,00% | 0,00% | 0,00% |
| 1432 | 1.5.52.4 | **CIMENTACIÓN** |  | 25d | 2023-09-19 | 2023-10-23 |  | 241d | 45d | 0,00% | 0,00% | 0,00% | 0,00% |
| 1433 | 1.5.52.4.1 | **CONSTRUCCIÓN PILOTES** |  | 7d | 2023-09-19 | 2023-09-28 |  | 241d |  | 0,00% | 0,00% | 0,00% | 0,00% |
| 1434 | 1.5.52.4.1.1 | Excavación para Pilotes |  | 5d | 2023-09-19 | 2023-09-26 | 1360FS+1d | 241d | 0d | 0,00% | 0,00% | 0,00% | 0,00% |
| 1435 | 1.5.52.4.1.2 | Acero de Refuerzo |  | 3d | 2023-09-22 | 2023-09-27 | 1434FS-2d | 247d | 0d | 0,00% | 0,00% | 0,00% | 0,00% |
| 1436 | 1.5.52.4.1.3 | Concreto |  | 3d | 2023-09-25 | 2023-09-28 | 1435FS-2d | 247d | 0d | 0,00% | 0,00% | 0,00% | 0,00% |
| 1437 | 1.5.52.4.2 | Descabece de Pilotes |  | 2d | 2023-09-28 | 2023-09-30 | 1436 | 247d | 0d | 0,00% | 0,00% | 0,00% | 0,00% |
| 1438 | 1.5.52.4.3 | **CONSTRUCCIÓN DADOS DE CIMENTACIÓN** |  | 6d | 2023-10-02 | 2023-10-09 |  | 247d |  | 0,00% | 0,00% | 0,00% | 0,00% |
| 1439 | 1.5.52.4.3.1 | Acero de Refuerzo |  | 3d | 2023-10-02 | 2023-10-04 | 1437 | 247d | 0d | 0,00% | 0,00% | 0,00% | 0,00% |
| 1440 | 1.5.52.4.3.2 | Concreto |  | 3d | 2023-10-05 | 2023-10-09 | 1439 | 247d | 0d | 0,00% | 0,00% | 0,00% | 0,00% |
| 1441 | 1.5.52.4.4 | **PEDESTAL** |  | 10d | 2023-10-09 | 2023-10-23 |  | 247d |  | 0,00% | 0,00% | 0,00% | 0,00% |
| 1442 | 1.5.52.4.4.1 | Acero de Refuerzo |  | 5d | 2023-10-09 | 2023-10-17 | 1440 | 247d | 0d | 0,00% | 0,00% | 0,00% | 0,00% |
| 1443 | 1.5.52.4.4.2 | Concreto |  | 5d | 2023-10-17 | 2023-10-23 | 1442 | 247d | 0d | 0,00% | 0,00% | 0,00% | 0,00% |
| 1444 | 1.5.52.5 | **RELLENOS** |  | 4d | 2023-10-24 | 2023-10-27 |  | 510d | 41d | 0,00% | 0,00% | 0,00% | 0,00% |
| 1445 | 1.5.52.5.1 | Relleno De Material Seleccionado |  | 4d | 2023-10-24 | 2023-10-27 | 1443 | 510d | 0d | 0,00% | 0,00% | 0,00% | 0,00% |
| 1446 | 1.5.52.6 | **PUESTA A TIERRA** |  | 2d | 2023-10-28 | 2023-10-31 |  | 515d | 117d | 0,00% | 0,00% | 0,00% | 0,00% |
| 1447 | 1.5.52.6.1 | Instalación Cable de Cobre |  | 1d | 2023-10-28 | 2023-10-30 | 1445 | 515d | 0d | 0,00% | 0,00% | 0,00% | 0,00% |
| 1448 | 1.5.52.6.2 | Varilla COOPER WELD 5/8" x 2.44m. |  | 1d | 2023-10-30 | 2023-10-31 | 1447 | 515d | 0d | 0,00% | 0,00% | 0,00% | 0,00% |
| 1449 | 1.5.52.6.3 | Fin Puesta a Tierra | milestone | 0d | 2023-10-31 | 2023-10-31 | 1447, 1448 | 515d | 72d | 0,00% | 0,00% | 0,00% | 0,00% |
| 1450 | 1.5.52.7 | **MONTAJE ELECTROMECÁNICO** |  | 10d | 2024-01-19 | 2024-02-01 |  | 186d | 0d | 0,00% | 0,00% | 0,00% | 0,00% |
| 1451 | 1.5.52.7.1 | Montaje Mecánico |  | 5d | 2024-01-19 | 2024-01-25 | 1377, 1443 | 186d | 0d | 0,00% | 0,00% | 0,00% | 0,00% |
| 1452 | 1.5.52.7.2 | Montaje Eléctrico |  | 5d | 2024-01-25 | 2024-02-01 | 1451 | 443d | 0d | 0,00% | 0,00% | 0,00% | 0,00% |
| 1453 | 1.5.52.7.3 | Fin montaje Electromecánico | milestone | 0d | 2024-02-01 | 2024-02-01 | 1451, 1452 | 443d | 0d | 0,00% | 0,00% | 0,00% | 0,00% |

| ID | WBS | Task | Type | Duration | Start | Finish | Predecessors | Total slack | Free slack | % Avance Planeado | % avance planeado en costo (texto) | % Completado (décimales) | % Completado en Costo |
| --- | --- | --- | --- | --- | --- | --- | --- | --- | --- | --- | --- | --- | --- |
| 1454 | 1.5.52.8 | **ALIMENTACIÓN ELÉCTRICA** |  | 7d | 2024-02-01 | 2024-02-09 |  | 443d | 45d | 0,00% | 0,00% | 0,00% | 0,00% |
| 1455 | 1.5.52.8.1 | Instalacion de tuberia PVC |  | 5d | 2024-02-01 | 2024-02-07 | 1453, 1445, 1443 | 443d | 0d | 0,00% | 0,00% | 0,00% | 0,00% |
| 1456 | 1.5.52.8.2 | Cableado |  | 1d | 2024-02-08 | 2024-02-08 | 1455 | 443d | 0d | 0,00% | 0,00% | 0,00% | 0,00% |
| 1457 | 1.5.52.8.3 | Instalación de Medidor |  | 1d | 2024-02-09 | 2024-02-09 | 1456 | 443d | 0d | 0,00% | 0,00% | 0,00% | 0,00% |
| 1458 | 1.5.52.8.4 | Fin Alimentación Eléctrica | milestone | 0d | 2024-02-09 | 2024-02-09 | 1457 | 443d | 0d | 0,00% | 0,00% | 0,00% | 0,00% |
| 1459 | 1.5.52.9 | **CERTIFICACIONES RETIE Y RETILAP** |  | 45d | 2024-02-10 | 2024-04-12 |  | 443d | 0d | 0,00% | 0,00% | 0,00% | 0,00% |
| 1460 | 1.5.52.9.1 | Certificación RETIE |  | 45d | 2024-02-10 | 2024-04-12 | 1458, 1449, 1423 | 443d | 0d | 0,00% | 0,00% | 0,00% | 0,00% |
| 1461 | 1.5.52.9.2 | Certificación RETILAP |  | 45d | 2024-02-10 | 2024-04-12 | 1460SS | 443d | 0d | 0,00% | 0,00% | 0,00% | 0,00% |
| 1462 | 1.5.52.9.3 | Fin Certificaciones RETIE Y RETILAP | milestone | 0d | 2024-04-12 | 2024-04-12 | 1461 | 443d |  | 0,00% | 0,00% | 0,00% | 0,00% |
| 1463 | 1.5.52.10 | FIN TORRE 16 | milestone | 0d | 2023-12-26 | 2023-12-26 | 1426, 1427, 1430, 1431 | 521d |  | 0,00% | 0,00% | 0,00% | 0,00% |
| 1464 | 1.5.52.11 | Torre 16: Hito de Aprobación Para Pago Preliminares y Cimentación | milestone | 0d | 2023-12-26 | 2023-12-26 | 1424, 1428, 1432, 1444 | 521d |  | 0,00% | 0,00% | 0,00% | 0,00% |
| 1465 | 1.5.52.12 | Torre 16: Hito de Aprobación Para Pago Redes | milestone | 0d | 2024-04-12 | 2024-04-12 | 1423, 1446, 1454, 1459 | 443d |  | 0,00% | 0,00% | 0,00% | 0,00% |
| 1466 | 1.5.52.13 | Torre 16: Hito de Aprobación Para Pago Electromecánico | milestone | 0d | 2024-02-01 | 2024-02-01 | 1450 | 495d |  | 0,00% | 0,00% | 0,00% | 0,00% |
| 1467 | 1.5.53 | Entrega de predios por parte de IDU al constructor |  | 1d | 2023-08-26 | 2023-08-28 | 47FS+30d | 463d | 0d | 0,00% | 0,00% | 0,00% | 0,00% |
| 1468 | 1.5.54 | **PERMISOS** |  | 0d | 2023-08-28 | 2023-08-28 |  | 483d |  | 0,00% | 0,00% | 0,00% | 0,00% |
| 1469 | 1.5.54.1 | Trabajo Nocturno | milestone | 0d | 2023-08-28 | 2023-08-28 | 1467 | 483d | 20d | 0,00% | 0,00% | 0,00% | 0,00% |
| 1470 | 1.5.54.2 | Silviculturales | milestone | 0d | 2023-08-28 | 2023-08-28 | 1467 | 483d | 20d | 0,00% | 0,00% | 0,00% | 0,00% |
| 1471 | 1.5.54.3 | Coordinación Acueducto y Alcantarillado | milestone | 0d | 2023-08-28 | 2023-08-28 | 1467 | 483d | 20d | 0,00% | 0,00% | 0,00% | 0,00% |
| 1472 | 1.5.54.4 | PMT | milestone | 0d | 2023-08-28 | 2023-08-28 | 1467 | 483d | 20d | 0,00% | 0,00% | 0,00% | 0,00% |
| 1473 | 1.5.55 | **TORRE 17** |  | 150d | 2023-09-22 | 2024-04-19 |  | 244d |  | 0,00% | 0,00% | 0,00% | 0,00% |
| 1474 | 1.5.55.1 | TRASLADO DE REDES |  | 45d | 2023-09-22 | 2023-11-24 | 1467FS+20d, 1469, 1470, 1471, 1472 | 463d | 0d | 0,00% | 0,00% | 0,00% | 0,00% |
| 1475 | 1.5.55.2 | **PRELIMINARES DE OBRA, MOVIMIENTO DE TIERRAS Y RELLENOS** |  | 19d | 2023-11-24 | 2023-12-21 |  | 463d | 61d | 0,00% | 0,00% | 0,00% | 0,00% |
| 1476 | 1.5.55.2.1 | Replanteo General |  | 4d | 2023-11-24 | 2023-11-30 | 1474 | 463d | 0d | 0,00% | 0,00% | 0,00% | 0,00% |
| 1477 | 1.5.55.2.2 | Cerramiento y Señalización |  | 5d | 2023-11-30 | 2023-12-06 | 1476 | 534d | 22d | 0,00% | 0,00% | 0,00% | 0,00% |
| 1478 | 1.5.55.2.3 | Tala de Especies |  | 5d | 2023-11-30 | 2023-12-06 | 1476 | 524d | 0d | 0,00% | 0,00% | 0,00% | 0,00% |

| ID | WBS | Task | Type | Duration | Start | Finish | Predecessors | Total slack | Free slack | % Avance Planeado | % avance planeado en costo (texto) | % Completado (décimales) | % Completado en Costo |
| --- | --- | --- | --- | --- | --- | --- | --- | --- | --- | --- | --- | --- | --- |
| 1479 | 1.5.55.2.4 | **DEMOLICIONES** |  | 10d | 2023-12-07 | 2023-12-21 |  | 524d | 61d | 0,00% | 0,00% | 0,00% | 0,00% |
| 1480 | 1.5.55.2.4.1 | Demoliciones de construcciones existentes |  | 10d | 2023-12-07 | 2023-12-21 | 1478 | 524d | 0d | 0,00% | 0,00% | 0,00% | 0,00% |
| 1481 | 1.5.55.2.4.2 | Fin demoliciones | milestone | 0d | 2023-12-21 | 2023-12-21 | 1480 | 524d |  | 0,00% | 0,00% | 0,00% | 0,00% |
| 1482 | 1.5.55.3 | **MOVIMIENTO DE TIERRAS** |  | 22d | 2023-12-07 | 2024-01-10 |  | 463d | 49d | 0,00% | 0,00% | 0,00% | 0,00% |
| 1483 | 1.5.55.3.1 | Excavación Mecánica En Material Común |  | 20d | 2023-12-07 | 2024-01-05 | 1476FS+5d | 463d | 0d | 0,00% | 0,00% | 0,00% | 0,00% |
| 1484 | 1.5.55.3.2 | Nivelación Y Compactación De Subrasante |  | 2d | 2024-01-05 | 2024-01-10 | 1483 | 512d | 0d | 0,00% | 0,00% | 0,00% | 0,00% |
| 1485 | 1.5.55.3.3 | Transporte y Disposición Final de Escombros en Sitio Autorizado |  | 20d | 2023-12-07 | 2024-01-05 | 1483SS | 514d | 2d | 0,00% | 0,00% | 0,00% | 0,00% |
| 1486 | 1.5.55.4 | **CIMENTACIÓN** |  | 25d | 2023-09-27 | 2023-10-31 |  | 241d | 97d | 0,00% | 0,00% | 0,00% | 0,00% |
| 1487 | 1.5.55.4.1 | **CONSTRUCCIÓN CAISSONS** |  | 7d | 2023-09-27 | 2023-10-05 |  | 241d |  | 0,00% | 0,00% | 0,00% | 0,00% |
| 1488 | 1.5.55.4.1.1 | Excavación para Pilotes |  | 5d | 2023-09-27 | 2023-10-03 | 1434FS+1d | 241d | 0d | 0,00% | 0,00% | 0,00% | 0,00% |
| 1489 | 1.5.55.4.1.2 | Acero de Refuerzo |  | 3d | 2023-10-02 | 2023-10-04 | 1488FS-2d | 246d | 0d | 0,00% | 0,00% | 0,00% | 0,00% |
| 1490 | 1.5.55.4.1.3 | Concreto |  | 3d | 2023-10-03 | 2023-10-05 | 1489FS-2d | 246d | 0d | 0,00% | 0,00% | 0,00% | 0,00% |
| 1491 | 1.5.55.4.2 | Descabece de Pilotes |  | 2d | 2023-10-06 | 2023-10-09 | 1490 | 246d | 0d | 0,00% | 0,00% | 0,00% | 0,00% |
| 1492 | 1.5.55.4.3 | **CONSTRUCCIÓN DADOS DE CIMENTACIÓN** |  | 6d | 2023-10-09 | 2023-10-18 |  | 246d |  | 0,00% | 0,00% | 0,00% | 0,00% |
| 1493 | 1.5.55.4.3.1 | Acero de Refuerzo |  | 3d | 2023-10-09 | 2023-10-12 | 1491 | 246d | 0d | 0,00% | 0,00% | 0,00% | 0,00% |
| 1494 | 1.5.55.4.3.2 | Concreto |  | 3d | 2023-10-12 | 2023-10-18 | 1493 | 246d | 0d | 0,00% | 0,00% | 0,00% | 0,00% |
| 1495 | 1.5.55.4.4 | **PEDESTAL** |  | 10d | 2023-10-18 | 2023-10-31 |  | 246d |  | 0,00% | 0,00% | 0,00% | 0,00% |
| 1496 | 1.5.55.4.4.1 | Acero de Refuerzo |  | 5d | 2023-10-18 | 2023-10-24 | 1494 | 246d | 0d | 0,00% | 0,00% | 0,00% | 0,00% |
| 1497 | 1.5.55.4.4.2 | Concreto |  | 5d | 2023-10-25 | 2023-10-31 | 1496 | 246d | 0d | 0,00% | 0,00% | 0,00% | 0,00% |
| 1498 | 1.5.55.5 | **RELLENOS** |  | 4d | 2023-10-31 | 2023-11-07 |  | 504d | 93d | 0,00% | 0,00% | 0,00% | 0,00% |
| 1499 | 1.5.55.5.1 | Relleno De Material Seleccionado |  | 4d | 2023-10-31 | 2023-11-07 | 1497 | 504d | 0d | 0,00% | 0,00% | 0,00% | 0,00% |
| 1500 | 1.5.55.6 | **PUESTA A TIERRA** |  | 2d | 2023-11-07 | 2023-11-09 |  | 509d | 116d | 0,00% | 0,00% | 0,00% | 0,00% |
| 1501 | 1.5.55.6.1 | Instalación Cable de Cobre |  | 1d | 2023-11-07 | 2023-11-08 | 1499 | 509d | 0d | 0,00% | 0,00% | 0,00% | 0,00% |
| 1502 | 1.5.55.6.2 | Varilla COOPER WELD 5/8" x 2.44m. |  | 1d | 2023-11-08 | 2023-11-09 | 1501 | 509d | 0d | 0,00% | 0,00% | 0,00% | 0,00% |
| 1503 | 1.5.55.6.3 | Fin Puesta a Tierra | milestone | 0d | 2023-11-09 | 2023-11-09 | 1501, 1502 | 509d | 71d | 0,00% | 0,00% | 0,00% | 0,00% |

| ID | WBS | Task | Type | Duration | Start | Finish | Predecessors | Total slack | Free slack | % Avance Planeado | % avance planeado en costo (texto) | % Completado (décimales) | % Completado en Costo |
| --- | --- | --- | --- | --- | --- | --- | --- | --- | --- | --- | --- | --- | --- |
| 1504 | 1.5.55.7 | **MONTAJE ELECTROMECÁNICO** |  | 10d | 2024-01-25 | 2024-02-07 |  | 186d | 0d | 0,00% | 0,00% | 0,00% | 0,00% |
| 1505 | 1.5.55.7.1 | Montaje Mecánico |  | 5d | 2024-01-25 | 2024-02-01 | 1497, 1451 | 186d | 0d | 0,00% | 0,00% | 0,00% | 0,00% |
| 1506 | 1.5.55.7.2 | Montaje Eléctrico |  | 5d | 2024-02-01 | 2024-02-07 | 1505 | 438d | 0d | 0,00% | 0,00% | 0,00% | 0,00% |
| 1507 | 1.5.55.7.3 | Fin montaje Electromecánico | milestone | 0d | 2024-02-07 | 2024-02-07 | 1505, 1506 | 438d | 0d | 0,00% | 0,00% | 0,00% | 0,00% |
| 1508 | 1.5.55.8 | **ALIMENTACIÓN ELÉCTRICA** |  | 7d | 2024-02-08 | 2024-02-16 |  | 438d | 45d | 0,00% | 0,00% | 0,00% | 0,00% |
| 1509 | 1.5.55.8.1 | Instalacion de tuberia PVC |  | 5d | 2024-02-08 | 2024-02-14 | 1507, 1499, 1497 | 438d | 0d | 0,00% | 0,00% | 0,00% | 0,00% |
| 1510 | 1.5.55.8.2 | Cableado |  | 1d | 2024-02-14 | 2024-02-15 | 1509 | 438d | 0d | 0,00% | 0,00% | 0,00% | 0,00% |
| 1511 | 1.5.55.8.3 | Instalación de Medidor |  | 1d | 2024-02-15 | 2024-02-16 | 1510 | 438d | 0d | 0,00% | 0,00% | 0,00% | 0,00% |
| 1512 | 1.5.55.8.4 | Fin Alimentación Eléctrica | milestone | 0d | 2024-02-16 | 2024-02-16 | 1511 | 438d | 0d | 0,00% | 0,00% | 0,00% | 0,00% |
| 1513 | 1.5.55.9 | **ALUMBRADO PÚBLICO DE TORRE** |  | 5d | 2024-02-08 | 2024-02-14 |  | 442d | 47d | 0,00% | 0,00% | 0,00% | 0,00% |
| 1514 | 1.5.55.9.1 | Tubería Eléctrica PVC |  | 5d | 2024-02-08 | 2024-02-14 | 1509SS | 442d | 0d | 0,00% | 0,00% | 0,00% | 0,00% |
| 1515 | 1.5.55.9.2 | Accesorios |  | 1d | 2024-02-08 | 2024-02-08 | 1514SS | 442d | 0d | 0,00% | 0,00% | 0,00% | 0,00% |
| 1516 | 1.5.55.9.3 | Cableado |  | 1d | 2024-02-09 | 2024-02-09 | 1515 | 442d | 0d | 0,00% | 0,00% | 0,00% | 0,00% |
| 1517 | 1.5.55.9.4 | Instalación de A.P. |  | 1d | 2024-02-10 | 2024-02-12 | 1516 | 442d | 0d | 0,00% | 0,00% | 0,00% | 0,00% |
| 1518 | 1.5.55.9.5 | Fin Alumbrado Público de Torre | milestone | 0d | 2024-02-12 | 2024-02-12 | 1517 | 442d | 4d | 0,00% | 0,00% | 0,00% | 0,00% |
| 1519 | 1.5.55.10 | **CERTIFICACIONES RETIE Y RETILAP** |  | 45d | 2024-02-16 | 2024-04-19 |  | 438d | 0d | 0,00% | 0,00% | 0,00% | 0,00% |
| 1520 | 1.5.55.10.1 | Certificación RETIE |  | 45d | 2024-02-16 | 2024-04-19 | 1512, 1518, 1503, 1474 | 438d | 0d | 0,00% | 0,00% | 0,00% | 0,00% |
| 1521 | 1.5.55.10.2 | Certificación RETILAP |  | 45d | 2024-02-16 | 2024-04-19 | 1520SS | 438d | 0d | 0,00% | 0,00% | 0,00% | 0,00% |
| 1522 | 1.5.55.10.3 | Fin Certificaciones RETIE Y RETILAP | milestone | 0d | 2024-04-19 | 2024-04-19 | 1521 | 438d |  | 0,00% | 0,00% | 0,00% | 0,00% |
| 1523 | 1.5.55.11 | **REDES HIDRÁULICAS EXTERNAS** |  | 7d | 2023-12-07 | 2023-12-18 |  | 463d | 89d | 0,00% | 0,00% | 0,00% | 0,00% |
| 1524 | 1.5.55.11.1 | **RED DE ALCANTARILLADO** |  | 7d | 2023-12-07 | 2023-12-18 |  | 463d |  | 0,00% | 0,00% | 0,00% | 0,00% |
| 1525 | 1.5.55.11.1.1 | Excavación manual para redes y canal monolítico |  | 5d | 2023-12-07 | 2023-12-14 | 1483SS | 463d | 0d | 0,00% | 0,00% | 0,00% | 0,00% |
| 1526 | 1.5.55.11.1.2 | Instalación de tubería, incluye accesorios. |  | 2d | 2023-12-12 | 2023-12-14 | 1525SS+3d | 527d | 0d | 0,00% | 0,00% | 0,00% | 0,00% |
| 1527 | 1.5.55.11.1.3 | Rellenos para redes y canal |  | 3d | 2023-12-13 | 2023-12-18 | 1526SS+1d | 527d | 15d | 0,00% | 0,00% | 0,00% | 0,00% |
| 1528 | 1.5.55.11.1.4 | Instalación de canal monolítico |  | 2d | 2023-12-12 | 2023-12-14 | 1525SS+3d | 463d | 0d | 0,00% | 0,00% | 0,00% | 0,00% |

| ID | WBS | Task | Type | Duration | Start | Finish | Predecessors | Total slack | Free slack | % Avance Planeado | % avance planeado en costo (texto) | % Completado (décimales) | % Completado en Costo |
| --- | --- | --- | --- | --- | --- | --- | --- | --- | --- | --- | --- | --- | --- |
| 1529 | 1.5.55.12 | **URBANISMO Y PAISAJISMO** |  | 93d | 2023-11-07 | 2024-03-14 |  | 463d | 0d | 0,00% | 0,00% | 0,00% | 0,00% |
| 1530 | 1.5.55.12.1 | **ESTRUCTURAS DE CONTENCIÓN PARA URBANISMO** |  | 66d | 2023-12-14 | 2024-03-14 |  | 463d | 0d | 0,00% | 0,00% | 0,00% | 0,00% |
| 1531 | 1.5.55.12.1.1 | Construcción de muros en concreto reforzado y mampostería estructural. Incluye otros elementos y construcción de filtro de drenaje tras muro. |  | 42d | 2023-12-14 | 2024-02-12 | 1528 | 463d | 0d | 0,00% | 0,00% | 0,00% | 0,00% |
| 1532 | 1.5.55.12.1.2 | Construcción de escaleras. |  | 10d | 2024-03-01 | 2024-03-14 | 1531FS+14d | 463d | 0d | 0,00% | 0,00% | 0,00% | 0,00% |
| 1533 | 1.5.55.12.1.3 | Fin Estructuras de contención para urbanismo | milestone | 0d | 2024-03-14 | 2024-03-14 | 1532 | 463d |  | 0,00% | 0,00% | 0,00% | 0,00% |
| 1534 | 1.5.55.12.2 | **PAISAJISMO** |  | 3d | 2023-11-07 | 2023-11-10 |  | 538d |  | 0,00% | 0,00% | 0,00% | 0,00% |
| 1535 | 1.5.55.12.2.1 | Contenedores de raices, Instalación de grama y hiedras. Incluye tierra negra. |  | 1d | 2023-11-07 | 2023-11-08 | 1499 | 538d | 0d | 0,00% | 0,00% | 0,00% | 0,00% |
| 1536 | 1.5.55.12.2.2 | Jardines horizontales |  | 2d | 2023-11-08 | 2023-11-10 | 1535 | 553d | 41d | 0,00% | 0,00% | 0,00% | 0,00% |
| 1537 | 1.5.55.12.3 | **URBANISMO** |  | 18d | 2023-11-07 | 2023-12-01 |  | 538d |  | 0,00% | 0,00% | 0,00% | 0,00% |
| 1538 | 1.5.55.12.3.1 | Instalación de prefabricados. Incluye cañuelas, sardineles, bordillos, pisos en adoquín, tabletas y concreto escobeado. |  | 10d | 2023-11-07 | 2023-11-21 | 1535SS | 538d | 0d | 0,00% | 0,00% | 0,00% | 0,00% |
| 1539 | 1.5.55.12.3.2 | Mobiliario y elementos independientes |  | 8d | 2023-11-21 | 2023-12-01 | 1538 | 538d | 26d | 0,00% | 0,00% | 0,00% | 0,00% |
| 1540 | 1.5.55.13 | FIN TORRE 17 | milestone | 0d | 2024-01-10 | 2024-01-10 | 1477, 1478, 1484, 1485, 1527, 1528, 1536, 1539 | 512d |  | 0,00% | 0,00% | 0,00% | 0,00% |
| 1541 | 1.5.55.14 | Torre 17: Hito de Aprobación Para Pago Preliminares, Demoliones, Excavación y Cimentación | milestone | 0d | 2024-03-14 | 2024-03-14 | 1475, 1482, 1486, 1498, 1529, 1479, 1530 | 463d |  | 0,00% | 0,00% | 0,00% | 0,00% |
| 1542 | 1.5.55.15 | Torre 17: Hito de Aprobación Para Pago Redes | milestone | 0d | 2024-04-19 | 2024-04-19 | 1474, 1500, 1508, 1513, 1519, 1523 | 438d |  | 0,00% | 0,00% | 0,00% | 0,00% |
| 1543 | 1.5.55.16 | Torre 17: Hito de Aprobación Para Pago Electromecánico | milestone | 0d | 2024-02-07 | 2024-02-07 | 1504 | 490d |  | 0,00% | 0,00% | 0,00% | 0,00% |
| 1544 | 1.5.56 | Entrega de predios por parte de IDU al constructor | milestone | 0d | 2023-07-13 | 2023-07-13 | 47 | 464d | 0d | 0,00% | 0,00% | 0,00% | 0,00% |
| 1545 | 1.5.57 | **PERMISOS** |  | 0d | 2023-07-13 | 2023-07-13 |  | 520d |  | 0,00% | 0,00% | 0,00% | 0,00% |
| 1546 | 1.5.57.1 | Trabajo Nocturno | milestone | 0d | 2023-07-13 | 2023-07-13 | 1544 | 520d | 56d | 0,00% | 0,00% | 0,00% | 0,00% |
| 1547 | 1.5.57.2 | Comunicaciones | milestone | 0d | 2023-07-13 | 2023-07-13 | 1544 | 520d | 56d | 0,00% | 0,00% | 0,00% | 0,00% |
| 1548 | 1.5.57.3 | Energía (baja Tensión) | milestone | 0d | 2023-07-13 | 2023-07-13 | 1544 | 520d | 56d | 0,00% | 0,00% | 0,00% | 0,00% |
| 1549 | 1.5.57.4 | PMT | milestone | 0d | 2023-07-13 | 2023-07-13 | 1544 | 520d | 56d | 0,00% | 0,00% | 0,00% | 0,00% |
| 1550 | 1.5.58 | **TORRE 18** |  | 150d | 2023-09-29 | 2024-04-26 |  | 245d |  | 0,00% | 0,00% | 0,00% | 0,00% |
| 1551 | 1.5.58.1 | TRASLADO DE REDES |  | 45d | 2023-09-29 | 2023-12-01 | 1544FS+56d, 1546, 1547, 1548, 1549 | 464d | 0d | 0,00% | 0,00% | 0,00% | 0,00% |
| 1552 | 1.5.58.2 | **PRELIMINARES DE OBRA, MOVIMIENTO DE TIERRAS Y RELLENOS** |  | 19d | 2023-12-01 | 2023-12-28 |  | 464d | 55d | 0,00% | 0,00% | 0,00% | 0,00% |
| 1553 | 1.5.58.2.1 | Replanteo General |  | 4d | 2023-12-01 | 2023-12-06 | 1551 | 464d | 0d | 0,00% | 0,00% | 0,00% | 0,00% |
| 1554 | 1.5.58.2.2 | Cerramiento y Señalización |  | 5d | 2023-12-07 | 2023-12-14 | 1553 | 529d | 22d | 0,00% | 0,00% | 0,00% | 0,00% |
| 1555 | 1.5.58.2.3 | Tala de Especies |  | 5d | 2023-12-07 | 2023-12-14 | 1553 | 519d | 0d | 0,00% | 0,00% | 0,00% | 0,00% |

| ID | WBS | Task | Type | Duration | Start | Finish | Predecessors | Total slack | Free slack | % Avance Planeado | % avance planeado en costo (texto) | % Completado (décimales) | % Completado en Costo |
| --- | --- | --- | --- | --- | --- | --- | --- | --- | --- | --- | --- | --- | --- |
| 1556 | 1.5.58.2.4 | **DEMOLICIONES** |  | 10d | 2023-12-14 | 2023-12-28 |  | 519d | 55d | 0,00% | 0,00% | 0,00% | 0,00% |
| 1557 | 1.5.58.2.4.1 | Demoliciones de construcciones existentes |  | 10d | 2023-12-14 | 2023-12-28 | 1555 | 519d | 0d | 0,00% | 0,00% | 0,00% | 0,00% |
| 1558 | 1.5.58.2.4.2 | Fin demoliciones | milestone | 0d | 2023-12-28 | 2023-12-28 | 1557 | 519d |  | 0,00% | 0,00% | 0,00% | 0,00% |
| 1559 | 1.5.58.3 | **MOVIMIENTO DE TIERRAS** |  | 22d | 2023-12-14 | 2024-01-16 |  | 464d | 43d | 0,00% | 0,00% | 0,00% | 0,00% |
| 1560 | 1.5.58.3.1 | Excavación Mecánica En Material Común |  | 20d | 2023-12-14 | 2024-01-13 | 1553FS+5d | 464d | 0d | 0,00% | 0,00% | 0,00% | 0,00% |
| 1561 | 1.5.58.3.2 | Nivelación y Compactación de Subrasante |  | 2d | 2024-01-15 | 2024-01-16 | 1560 | 507d | 0d | 0,00% | 0,00% | 0,00% | 0,00% |
| 1562 | 1.5.58.3.3 | Transporte y Disposición Final de Escombros en Sitio Autorizado |  | 20d | 2023-12-14 | 2024-01-13 | 1560SS | 509d | 2d | 0,00% | 0,00% | 0,00% | 0,00% |
| 1563 | 1.5.58.4 | **CIMENTACIÓN** |  | 25d | 2023-10-05 | 2023-11-09 |  | 241d | 90d | 0,00% | 0,00% | 0,00% | 0,00% |
| 1564 | 1.5.58.4.1 | **CONSTRUCCIÓN PILOTES** |  | 7d | 2023-10-05 | 2023-10-13 |  | 241d |  | 0,00% | 0,00% | 0,00% | 0,00% |
| 1565 | 1.5.58.4.1.1 | Excavación para Pilotes |  | 5d | 2023-10-05 | 2023-10-11 | 1488FS+1d | 241d | 0d | 0,00% | 0,00% | 0,00% | 0,00% |
| 1566 | 1.5.58.4.1.2 | Acero de Refuerzo |  | 3d | 2023-10-09 | 2023-10-12 | 1565FS-2d | 245d | 0d | 0,00% | 0,00% | 0,00% | 0,00% |
| 1567 | 1.5.58.4.1.3 | Concreto |  | 3d | 2023-10-10 | 2023-10-13 | 1566FS-2d | 245d | 0d | 0,00% | 0,00% | 0,00% | 0,00% |
| 1568 | 1.5.58.4.2 | Descabece de Pilotes |  | 2d | 2023-10-13 | 2023-10-18 | 1567 | 245d | 0d | 0,00% | 0,00% | 0,00% | 0,00% |
| 1569 | 1.5.58.4.3 | **CONSTRUCCIÓN DADOS DE CIMENTACIÓN** |  | 6d | 2023-10-18 | 2023-10-25 |  | 245d |  | 0,00% | 0,00% | 0,00% | 0,00% |
| 1570 | 1.5.58.4.3.1 | Acero de Refuerzo |  | 3d | 2023-10-18 | 2023-10-21 | 1568 | 245d | 0d | 0,00% | 0,00% | 0,00% | 0,00% |
| 1571 | 1.5.58.4.3.2 | Concreto |  | 3d | 2023-10-23 | 2023-10-25 | 1570 | 245d | 0d | 0,00% | 0,00% | 0,00% | 0,00% |
| 1572 | 1.5.58.4.4 | **PEDESTAL** |  | 10d | 2023-10-26 | 2023-11-09 |  | 245d |  | 0,00% | 0,00% | 0,00% | 0,00% |
| 1573 | 1.5.58.4.4.1 | Acero de Refuerzo |  | 5d | 2023-10-26 | 2023-11-01 | 1571 | 245d | 0d | 0,00% | 0,00% | 0,00% | 0,00% |
| 1574 | 1.5.58.4.4.2 | Concreto |  | 5d | 2023-11-01 | 2023-11-09 | 1573 | 245d | 0d | 0,00% | 0,00% | 0,00% | 0,00% |
| 1575 | 1.5.58.5 | **RELLENOS** |  | 4d | 2023-11-09 | 2023-11-15 |  | 498d | 86d | 0,00% | 0,00% | 0,00% | 0,00% |
| 1576 | 1.5.58.5.1 | Relleno De Material Seleccionado |  | 4d | 2023-11-09 | 2023-11-15 | 1574 | 498d | 0d | 0,00% | 0,00% | 0,00% | 0,00% |
| 1577 | 1.5.58.6 | **PUESTA A TIERRA** |  | 2d | 2023-11-16 | 2023-11-17 |  | 503d | 115d | 0,00% | 0,00% | 0,00% | 0,00% |
| 1578 | 1.5.58.6.1 | Instalación Cable de Cobre |  | 1d | 2023-11-16 | 2023-11-16 | 1576 | 503d | 0d | 0,00% | 0,00% | 0,00% | 0,00% |
| 1579 | 1.5.58.6.2 | Varilla COOPER WELD 5/8" x 2.44m. |  | 1d | 2023-11-17 | 2023-11-17 | 1578 | 503d | 0d | 0,00% | 0,00% | 0,00% | 0,00% |
| 1580 | 1.5.58.6.3 | Fin Puesta a Tierra | milestone | 0d | 2023-11-17 | 2023-11-17 | 1578, 1579 | 503d | 70d | 0,00% | 0,00% | 0,00% | 0,00% |

| ID | WBS | Task | Type | Duration | Start | Finish | Predecessors | Total slack | Free slack | % Avance Planeado | % avance planeado en costo (texto) | % Completado (décimales) | % Completado en Costo |
| --- | --- | --- | --- | --- | --- | --- | --- | --- | --- | --- | --- | --- | --- |
| 1581 | 1.5.58.7 | **MONTAJE ELECTROMECÁNICO** |  | 10d | 2024-02-01 | 2024-02-14 |  | 186d | 0d | 0,00% | 0,00% | 0,00% | 0,00% |
| 1582 | 1.5.58.7.1 | Montaje Mecánico |  | 5d | 2024-02-01 | 2024-02-07 | 1505, 1574 | 186d | 0d | 0,00% | 0,00% | 0,00% | 0,00% |
| 1583 | 1.5.58.7.2 | Montaje Eléctrico |  | 5d | 2024-02-08 | 2024-02-14 | 1582 | 433d | 0d | 0,00% | 0,00% | 0,00% | 0,00% |
| 1584 | 1.5.58.7.3 | Fin montaje Electromecánico | milestone | 0d | 2024-02-14 | 2024-02-14 | 1582, 1583 | 433d | 0d | 0,00% | 0,00% | 0,00% | 0,00% |
| 1585 | 1.5.58.8 | **ALIMENTACIÓN ELÉCTRICA** |  | 7d | 2024-02-14 | 2024-02-23 |  | 433d | 45d | 0,00% | 0,00% | 0,00% | 0,00% |
| 1586 | 1.5.58.8.1 | Instalacion de tuberia PVC |  | 5d | 2024-02-14 | 2024-02-21 | 1584, 1576, 1574 | 433d | 0d | 0,00% | 0,00% | 0,00% | 0,00% |
| 1587 | 1.5.58.8.2 | Cableado |  | 1d | 2024-02-21 | 2024-02-22 | 1586 | 433d | 0d | 0,00% | 0,00% | 0,00% | 0,00% |
| 1588 | 1.5.58.8.3 | Instalación de Medidor |  | 1d | 2024-02-22 | 2024-02-23 | 1587 | 433d | 0d | 0,00% | 0,00% | 0,00% | 0,00% |
| 1589 | 1.5.58.8.4 | Fin Alimentación Eléctrica | milestone | 0d | 2024-02-23 | 2024-02-23 | 1588 | 433d | 0d | 0,00% | 0,00% | 0,00% | 0,00% |
| 1590 | 1.5.58.9 | **ALUMBRADO PÚBLICO DE TORRE** |  | 5d | 2024-02-14 | 2024-02-21 |  | 437d | 47d | 0,00% | 0,00% | 0,00% | 0,00% |
| 1591 | 1.5.58.9.1 | Tubería Eléctrica PVC |  | 5d | 2024-02-14 | 2024-02-21 | 1586SS | 437d | 0d | 0,00% | 0,00% | 0,00% | 0,00% |
| 1592 | 1.5.58.9.2 | Accesorios |  | 1d | 2024-02-14 | 2024-02-15 | 1591SS | 437d | 0d | 0,00% | 0,00% | 0,00% | 0,00% |
| 1593 | 1.5.58.9.3 | Cableado |  | 1d | 2024-02-15 | 2024-02-16 | 1592 | 437d | 0d | 0,00% | 0,00% | 0,00% | 0,00% |
| 1594 | 1.5.58.9.4 | Instalación de A.P. |  | 1d | 2024-02-16 | 2024-02-19 | 1593 | 437d | 0d | 0,00% | 0,00% | 0,00% | 0,00% |
| 1595 | 1.5.58.9.5 | Fin Alumbrado Público de Torre | milestone | 0d | 2024-02-19 | 2024-02-19 | 1594 | 437d | 4d | 0,00% | 0,00% | 0,00% | 0,00% |
| 1596 | 1.5.58.10 | **CERTIFICACIONES RETIE Y RETILAP** |  | 45d | 2024-02-23 | 2024-04-26 |  | 433d | 0d | 0,00% | 0,00% | 0,00% | 0,00% |
| 1597 | 1.5.58.10.1 | Certificación RETIE |  | 45d | 2024-02-23 | 2024-04-26 | 1589, 1595, 1580, 1551 | 433d | 0d | 0,00% | 0,00% | 0,00% | 0,00% |
| 1598 | 1.5.58.10.2 | Certificación RETILAP |  | 45d | 2024-02-23 | 2024-04-26 | 1597SS | 433d | 0d | 0,00% | 0,00% | 0,00% | 0,00% |
| 1599 | 1.5.58.10.3 | Fin Certificaciones RETIE Y RETILAP | milestone | 0d | 2024-04-26 | 2024-04-26 | 1598 | 433d |  | 0,00% | 0,00% | 0,00% | 0,00% |
| 1600 | 1.5.58.11 | **REDES HIDRÁULICAS EXTERNAS** |  | 7d | 2023-12-14 | 2023-12-23 |  | 464d | 89d | 0,00% | 0,00% | 0,00% | 0,00% |
| 1601 | 1.5.58.11.1 | **RED DE ALCANTARILLADO** |  | 7d | 2023-12-14 | 2023-12-23 |  | 464d |  | 0,00% | 0,00% | 0,00% | 0,00% |
| 1602 | 1.5.58.11.1.1 | Excavación manual para redes y canal monolítico |  | 5d | 2023-12-14 | 2023-12-21 | 1560SS | 464d | 0d | 0,00% | 0,00% | 0,00% | 0,00% |
| 1603 | 1.5.58.11.1.2 | Instalación de tubería, incluye accesorios. |  | 2d | 2023-12-19 | 2023-12-21 | 1602SS+3d | 522d | 0d | 0,00% | 0,00% | 0,00% | 0,00% |
| 1604 | 1.5.58.11.1.3 | Rellenos para redes y canal |  | 3d | 2023-12-20 | 2023-12-23 | 1603SS+1d | 522d | 15d | 0,00% | 0,00% | 0,00% | 0,00% |
| 1605 | 1.5.58.11.1.4 | Instalación de canal monolítico |  | 2d | 2023-12-19 | 2023-12-21 | 1602SS+3d | 464d | 0d | 0,00% | 0,00% | 0,00% | 0,00% |

| ID | WBS | Task | Type | Duration | Start | Finish | Predecessors | Total slack | Free slack | % Avance Planeado | % avance planeado en costo (texto) | % Completado (décimales) | % Completado en Costo |
| --- | --- | --- | --- | --- | --- | --- | --- | --- | --- | --- | --- | --- | --- |
| 1606 | 1.5.58.12 | **URBANISMO Y PAISAJISMO** |  | 86d | 2023-11-16 | 2024-03-13 |  | 464d | 0d | 0,00% | 0,00% | 0,00% | 0,00% |
| 1607 | 1.5.58.12.1 | **ESTRUCTURAS DE CONTENCIÓN PARA URBANISMO** |  | 60d | 2023-12-21 | 2024-03-13 |  | 464d | 0d | 0,00% | 0,00% | 0,00% | 0,00% |
| 1608 | 1.5.58.12.1.1 | Construcción de muros en concreto reforzado y mampostería estructural. Incluye otros elementos y construcción de filtro de drenaje tras muro. |  | 40d | 2023-12-21 | 2024-02-15 | 1605 | 464d | 0d | 0,00% | 0,00% | 0,00% | 0,00% |
| 1609 | 1.5.58.12.1.2 | Construcción de escaleras y rampas. |  | 6d | 2024-03-05 | 2024-03-13 | 1608FS+14d | 464d | 0d | 0,00% | 0,00% | 0,00% | 0,00% |
| 1610 | 1.5.58.12.1.3 | Fin Estructuras de contención para urbanismo | milestone | 0d | 2024-03-13 | 2024-03-13 | 1609 | 464d |  | 0,00% | 0,00% | 0,00% | 0,00% |
| 1611 | 1.5.58.12.2 | **PAISAJISMO** |  | 4d | 2023-11-16 | 2023-11-21 |  | 535d |  | 0,00% | 0,00% | 0,00% | 0,00% |
| 1612 | 1.5.58.12.2.1 | Contenedores de raices, Instalación de grama y hiedras. Incluye tierra negra. |  | 1d | 2023-11-16 | 2023-11-16 | 1576 | 535d | 0d | 0,00% | 0,00% | 0,00% | 0,00% |
| 1613 | 1.5.58.12.2.2 | Jardines horizontales |  | 3d | 2023-11-17 | 2023-11-21 | 1612 | 546d | 39d | 0,00% | 0,00% | 0,00% | 0,00% |
| 1614 | 1.5.58.12.3 | **URBANISMO** |  | 15d | 2023-11-16 | 2023-12-05 |  | 535d |  | 0,00% | 0,00% | 0,00% | 0,00% |
| 1615 | 1.5.58.12.3.1 | Instalación de prefabricados. Incluye cañuelas, sardineles, bordillos, pisos en adoquín, tabletas y concreto escobeado. |  | 8d | 2023-11-16 | 2023-11-27 | 1612SS | 535d | 0d | 0,00% | 0,00% | 0,00% | 0,00% |
| 1616 | 1.5.58.12.3.2 | Mobiliario y elementos independientes |  | 7d | 2023-11-27 | 2023-12-05 | 1615 | 535d | 28d | 0,00% | 0,00% | 0,00% | 0,00% |
| 1617 | 1.5.58.13 | FIN TORRE 18 | milestone | 0d | 2024-01-16 | 2024-01-16 | 1554, 1555, 1561, 1562, 1604, 1605, 1613, 1616 | 507d |  | 0,00% | 0,00% | 0,00% | 0,00% |
| 1618 | 1.5.58.14 | Torre 18: Hito de Aprobación Para Pago Preliminares, Demoliones, Excavación y Cimentación | milestone | 0d | 2024-03-13 | 2024-03-13 | 1552, 1559, 1563, 1575, 1606, 1556, 1607 | 464d |  | 0,00% | 0,00% | 0,00% | 0,00% |
| 1619 | 1.5.58.15 | Torre 18: Hito de Aprobación Para Pago Redes | milestone | 0d | 2024-04-26 | 2024-04-26 | 1551, 1577, 1585, 1590, 1596, 1600 | 433d |  | 0,00% | 0,00% | 0,00% | 0,00% |
| 1620 | 1.5.58.16 | Torre 18: Hito de Aprobación Para Pago Electromecánico | milestone | 0d | 2024-02-14 | 2024-02-14 | 1581 | 485d |  | 0,00% | 0,00% | 0,00% | 0,00% |
| 1621 | 1.5.59 | Entrega de predios por parte de IDU al constructor |  | 1d | 2023-07-14 | 2023-07-14 | 47 | 447d | 0d | 0,00% | 0,00% | 0,00% | 0,00% |
| 1622 | 1.5.60 | **PERMISOS** |  | 0d | 2023-07-14 | 2023-07-14 |  | 507d |  | 0,00% | 0,00% | 0,00% | 0,00% |
| 1623 | 1.5.60.1 | Trabajo Nocturno | milestone | 0d | 2023-07-14 | 2023-07-14 | 1621 | 507d | 60d | 0,00% | 0,00% | 0,00% | 0,00% |
| 1624 | 1.5.60.2 | Energía (Media Tensión) | milestone | 0d | 2023-07-14 | 2023-07-14 | 1621 | 507d | 60d | 0,00% | 0,00% | 0,00% | 0,00% |
| 1625 | 1.5.60.3 | Idiger | milestone | 0d | 2023-07-14 | 2023-07-14 | 1621 | 507d | 60d | 0,00% | 0,00% | 0,00% | 0,00% |
| 1626 | 1.5.60.4 | PMT | milestone | 0d | 2023-07-14 | 2023-07-14 | 1621 | 507d | 60d | 0,00% | 0,00% | 0,00% | 0,00% |
| 1627 | 1.5.61 | **TORRE 19** |  | 150d | 2023-10-06 | 2024-05-03 |  | 246d |  | 0,00% | 0,00% | 0,00% | 0,00% |
| 1628 | 1.5.61.1 | TRASLADO DE REDES |  | 45d | 2023-10-06 | 2023-12-07 | 1621FS+60d, 1623, 1624, 1625, 1626 | 447d | 0d | 0,00% | 0,00% | 0,00% | 0,00% |
| 1629 | 1.5.61.2 | **PRELIMINARES DE OBRA, MOVIMIENTO DE TIERRAS Y RELLENOS** |  | 29d | 2023-12-09 | 2024-01-19 |  | 447d | 57d | 0,00% | 0,00% | 0,00% | 0,00% |
| 1630 | 1.5.61.2.1 | Replanteo General |  | 4d | 2023-12-09 | 2023-12-14 | 1628 | 447d | 0d | 0,00% | 0,00% | 0,00% | 0,00% |
| 1631 | 1.5.61.2.2 | Cerramiento y Señalización |  | 5d | 2023-12-14 | 2023-12-21 | 1630 | 524d | 22d | 0,00% | 0,00% | 0,00% | 0,00% |
| 1632 | 1.5.61.2.3 | Tala de Especies |  | 5d | 2023-12-14 | 2023-12-21 | 1630 | 504d | 0d | 0,00% | 0,00% | 0,00% | 0,00% |

| ID | WBS | Task | Type | Duration | Start | Finish | Predecessors | Total slack | Free slack | Constraint | % Avance Planeado | % avance planeado en costo (texto) | % Completado (décimales) | % Completado en Costo |
| --- | --- | --- | --- | --- | --- | --- | --- | --- | --- | --- | --- | --- | --- | --- |
| 1633 | 1.5.61.2.4 | **DEMOLICIONES** |  | 20d | 2023-12-21 | 2024-01-19 |  | 504d | 57d |  | 0,00% | 0,00% | 0,00% | 0,00% |
| 1634 | 1.5.61.2.4.1 | Demoliciones de construcciones existentes |  | 20d | 2023-12-21 | 2024-01-19 | 1632 | 504d | 0d |  | 0,00% | 0,00% | 0,00% | 0,00% |
| 1635 | 1.5.61.2.4.2 | Fin demoliciones | milestone | 0d | 2024-01-19 | 2024-01-19 | 1634 | 504d |  |  | 0,00% | 0,00% | 0,00% | 0,00% |
| 1636 | 1.5.61.3 | **MOVIMIENTO DE TIERRAS** |  | 22d | 2023-12-21 | 2024-01-23 |  | 447d | 55d |  | 0,00% | 0,00% | 0,00% | 0,00% |
| 1637 | 1.5.61.3.1 | Excavación Mecánica En Material Común |  | 20d | 2023-12-21 | 2024-01-19 | 1630FS+5d | 447d | 0d |  | 0,00% | 0,00% | 0,00% | 0,00% |
| 1638 | 1.5.61.3.2 | Nivelación y Compactación de Subrasante |  | 2d | 2024-01-20 | 2024-01-23 | 1637 | 502d | 0d |  | 0,00% | 0,00% | 0,00% | 0,00% |
| 1639 | 1.5.61.3.3 | Transporte y Disposición Final de Escombros en Sitio Autorizado |  | 20d | 2023-12-21 | 2024-01-19 | 1637SS | 504d | 2d | finish no earlier than 2023-12-19 | 0,00% | 0,00% | 0,00% | 0,00% |
| 1640 | 1.5.61.4 | **CIMENTACIÓN** |  | 25d | 2023-10-12 | 2023-11-17 |  | 241d | 101d |  | 0,00% | 0,00% | 0,00% | 0,00% |
| 1641 | 1.5.61.4.1 | **CONSTRUCCIÓN PILOTES** |  | 7d | 2023-10-12 | 2023-10-23 |  | 241d |  |  | 0,00% | 0,00% | 0,00% | 0,00% |
| 1642 | 1.5.61.4.1.1 | Excavación para Pilotes |  | 5d | 2023-10-12 | 2023-10-20 | 1565FS+1d | 241d | 0d |  | 0,00% | 0,00% | 0,00% | 0,00% |
| 1643 | 1.5.61.4.1.2 | Acero de Refuerzo |  | 3d | 2023-10-18 | 2023-10-21 | 1642FS-2d | 244d | 0d |  | 0,00% | 0,00% | 0,00% | 0,00% |
| 1644 | 1.5.61.4.1.3 | Concreto |  | 3d | 2023-10-19 | 2023-10-23 | 1643FS-2d | 244d | 0d |  | 0,00% | 0,00% | 0,00% | 0,00% |
| 1645 | 1.5.61.4.2 | Descabece de Pilotes |  | 2d | 2023-10-24 | 2023-10-25 | 1644 | 244d | 0d |  | 0,00% | 0,00% | 0,00% | 0,00% |
| 1646 | 1.5.61.4.3 | **CONSTRUCCIÓN DADOS DE CIMENTACIÓN** |  | 6d | 2023-10-26 | 2023-11-02 |  | 244d |  |  | 0,00% | 0,00% | 0,00% | 0,00% |
| 1647 | 1.5.61.4.3.1 | Acero de Refuerzo |  | 3d | 2023-10-26 | 2023-10-30 | 1645 | 244d | 0d |  | 0,00% | 0,00% | 0,00% | 0,00% |
| 1648 | 1.5.61.4.3.2 | Concreto |  | 3d | 2023-10-30 | 2023-11-02 | 1647 | 244d | 0d |  | 0,00% | 0,00% | 0,00% | 0,00% |
| 1649 | 1.5.61.4.4 | **PEDESTAL** |  | 10d | 2023-11-02 | 2023-11-17 |  | 244d |  |  | 0,00% | 0,00% | 0,00% | 0,00% |
| 1650 | 1.5.61.4.4.1 | Acero de Refuerzo |  | 5d | 2023-11-02 | 2023-11-10 | 1648 | 244d | 0d |  | 0,00% | 0,00% | 0,00% | 0,00% |
| 1651 | 1.5.61.4.4.2 | Concreto |  | 5d | 2023-11-10 | 2023-11-17 | 1650 | 244d | 0d |  | 0,00% | 0,00% | 0,00% | 0,00% |
| 1652 | 1.5.61.5 | **RELLENOS** |  | 4d | 2023-11-18 | 2023-11-23 |  | 492d | 97d |  | 0,00% | 0,00% | 0,00% | 0,00% |
| 1653 | 1.5.61.5.1 | Relleno De Material Seleccionado |  | 4d | 2023-11-18 | 2023-11-23 | 1651 | 492d | 0d |  | 0,00% | 0,00% | 0,00% | 0,00% |
| 1654 | 1.5.61.6 | **PUESTA A TIERRA** |  | 2d | 2023-11-23 | 2023-11-27 |  | 497d | 114d |  | 0,00% | 0,00% | 0,00% | 0,00% |
| 1655 | 1.5.61.6.1 | Instalación Cable de Cobre |  | 1d | 2023-11-23 | 2023-11-24 | 1653 | 497d | 0d |  | 0,00% | 0,00% | 0,00% | 0,00% |
| 1656 | 1.5.61.6.2 | Varilla COOPER WELD 5/8" x 2.44m. |  | 1d | 2023-11-24 | 2023-11-27 | 1655 | 497d | 0d |  | 0,00% | 0,00% | 0,00% | 0,00% |
| 1657 | 1.5.61.6.3 | Fin Puesta a Tierra | milestone | 0d | 2023-11-27 | 2023-11-27 | 1655, 1656 | 497d | 69d |  | 0,00% | 0,00% | 0,00% | 0,00% |

| ID | WBS | Task | Type | Duration | Start | Finish | Predecessors | Total slack | Free slack | % Avance Planeado | % avance planeado en costo (texto) | % Completado (décimales) | % Completado en Costo |
| --- | --- | --- | --- | --- | --- | --- | --- | --- | --- | --- | --- | --- | --- |
| 1658 | 1.5.61.7 | **MONTAJE ELECTROMECÁNICO** |  | 10d | 2024-02-08 | 2024-02-21 |  | 186d | 0d | 0,00% | 0,00% | 0,00% | 0,00% |
| 1659 | 1.5.61.7.1 | Montaje Mecánico |  | 5d | 2024-02-08 | 2024-02-14 | 1582, 1651 | 186d | 0d | 0,00% | 0,00% | 0,00% | 0,00% |
| 1660 | 1.5.61.7.2 | Montaje Eléctrico |  | 5d | 2024-02-14 | 2024-02-21 | 1659 | 428d | 0d | 0,00% | 0,00% | 0,00% | 0,00% |
| 1661 | 1.5.61.7.3 | Fin montaje Electromecánico | milestone | 0d | 2024-02-21 | 2024-02-21 | 1659, 1660 | 428d | 0d | 0,00% | 0,00% | 0,00% | 0,00% |
| 1662 | 1.5.61.8 | **ALIMENTACIÓN ELÉCTRICA** |  | 7d | 2024-02-21 | 2024-02-29 |  | 428d | 45d | 0,00% | 0,00% | 0,00% | 0,00% |
| 1663 | 1.5.61.8.1 | Instalacion de tuberia PVC |  | 5d | 2024-02-21 | 2024-02-27 | 1661, 1653, 1651 | 428d | 0d | 0,00% | 0,00% | 0,00% | 0,00% |
| 1664 | 1.5.61.8.2 | Cableado |  | 1d | 2024-02-28 | 2024-02-28 | 1663 | 428d | 0d | 0,00% | 0,00% | 0,00% | 0,00% |
| 1665 | 1.5.61.8.3 | Instalación de Medidor |  | 1d | 2024-02-29 | 2024-02-29 | 1664 | 428d | 0d | 0,00% | 0,00% | 0,00% | 0,00% |
| 1666 | 1.5.61.8.4 | Fin Alimentación Eléctrica | milestone | 0d | 2024-02-29 | 2024-02-29 | 1665 | 428d | 0d | 0,00% | 0,00% | 0,00% | 0,00% |
| 1667 | 1.5.61.9 | **ALUMBRADO PÚBLICO DE TORRE** |  | 5d | 2024-02-21 | 2024-02-27 |  | 432d | 47d | 0,00% | 0,00% | 0,00% | 0,00% |
| 1668 | 1.5.61.9.1 | Tubería Eléctrica PVC |  | 5d | 2024-02-21 | 2024-02-27 | 1663SS | 432d | 0d | 0,00% | 0,00% | 0,00% | 0,00% |
| 1669 | 1.5.61.9.2 | Accesorios |  | 1d | 2024-02-21 | 2024-02-22 | 1668SS | 432d | 0d | 0,00% | 0,00% | 0,00% | 0,00% |
| 1670 | 1.5.61.9.3 | Cableado |  | 1d | 2024-02-22 | 2024-02-23 | 1669 | 432d | 0d | 0,00% | 0,00% | 0,00% | 0,00% |
| 1671 | 1.5.61.9.4 | Instalación de A.P. |  | 1d | 2024-02-23 | 2024-02-24 | 1670 | 432d | 0d | 0,00% | 0,00% | 0,00% | 0,00% |
| 1672 | 1.5.61.9.5 | Fin Alumbrado Público de Torre | milestone | 0d | 2024-02-24 | 2024-02-24 | 1671 | 432d | 4d | 0,00% | 0,00% | 0,00% | 0,00% |
| 1673 | 1.5.61.10 | **CERTIFICACIONES RETIE Y RETILAP** |  | 45d | 2024-03-01 | 2024-05-03 |  | 428d | 0d | 0,00% | 0,00% | 0,00% | 0,00% |
| 1674 | 1.5.61.10.1 | Certificación RETIE |  | 45d | 2024-03-01 | 2024-05-03 | 1666, 1672, 1657, 1628 | 428d | 0d | 0,00% | 0,00% | 0,00% | 0,00% |
| 1675 | 1.5.61.10.2 | Certificación RETILAP |  | 45d | 2024-03-01 | 2024-05-03 | 1674SS | 428d | 0d | 0,00% | 0,00% | 0,00% | 0,00% |
| 1676 | 1.5.61.10.3 | Fin Certificaciones RETIE Y RETILAP | milestone | 0d | 2024-05-03 | 2024-05-03 | 1675 | 428d |  | 0,00% | 0,00% | 0,00% | 0,00% |
| 1677 | 1.5.61.11 | **REDES HIDRÁULICAS EXTERNAS** |  | 7d | 2023-12-21 | 2024-01-02 |  | 447d | 89d | 0,00% | 0,00% | 0,00% | 0,00% |
| 1678 | 1.5.61.11.1 | **RED DE ALCANTARILLADO** |  | 7d | 2023-12-21 | 2024-01-02 |  | 447d |  | 0,00% | 0,00% | 0,00% | 0,00% |
| 1679 | 1.5.61.11.1.1 | Excavación manual para redes y canal monolítico |  | 5d | 2023-12-21 | 2023-12-28 | 1637SS | 447d | 0d | 0,00% | 0,00% | 0,00% | 0,00% |
| 1680 | 1.5.61.11.1.2 | Instalación de tubería, incluye accesorios. |  | 2d | 2023-12-27 | 2023-12-28 | 1679SS+3d | 517d | 0d | 0,00% | 0,00% | 0,00% | 0,00% |
| 1681 | 1.5.61.11.1.3 | Rellenos para redes y canal |  | 3d | 2023-12-28 | 2024-01-02 | 1680SS+1d | 517d | 15d | 0,00% | 0,00% | 0,00% | 0,00% |
| 1682 | 1.5.61.11.1.4 | Instalación de canal monolítico |  | 2d | 2023-12-27 | 2023-12-28 | 1679SS+3d | 447d | 0d | 0,00% | 0,00% | 0,00% | 0,00% |

| ID | WBS | Task | Type | Duration | Start | Finish | Predecessors | Total slack | Free slack | % Avance Planeado | % avance planeado en costo (texto) | % Completado (décimales) | % Completado en Costo |
| --- | --- | --- | --- | --- | --- | --- | --- | --- | --- | --- | --- | --- | --- |
| 1683 | 1.5.61.12 | **URBANISMO Y PAISAJISMO** |  | 97d | 2023-11-23 | 2024-04-08 |  | 447d | 0d | 0,00% | 0,00% | 0,00% | 0,00% |
| 1684 | 1.5.61.12.1 | **ESTRUCTURAS DE CONTENCIÓN PARA URBANISMO** |  | 72d | 2023-12-29 | 2024-04-08 |  | 447d | 0d | 0,00% | 0,00% | 0,00% | 0,00% |
| 1685 | 1.5.61.12.1.1 | Construcción de muros en concreto reforzado y mampostería estructural. Incluye otros elementos y construcción de filtro de drenaje tras muro. |  | 36d | 2023-12-29 | 2024-02-16 | 1682 | 447d | 0d | 0,00% | 0,00% | 0,00% | 0,00% |
| 1686 | 1.5.61.12.1.2 | Construcción de escaleras y rampas. |  | 22d | 2024-03-06 | 2024-04-08 | 1685FS+14d | 447d | 0d | 0,00% | 0,00% | 0,00% | 0,00% |
| 1687 | 1.5.61.12.1.3 | Fin Estructuras de contención para urbanismo | milestone | 0d | 2024-04-08 | 2024-04-08 | 1686 | 447d |  | 0,00% | 0,00% | 0,00% | 0,00% |
| 1688 | 1.5.61.12.2 | **PAISAJISMO** |  | 4d | 2023-11-23 | 2023-11-29 |  | 512d |  | 0,00% | 0,00% | 0,00% | 0,00% |
| 1689 | 1.5.61.12.2.1 | Contenedores de raices, Instalación de grama y hiedras. Incluye tierra negra. |  | 1d | 2023-11-23 | 2023-11-24 | 1653 | 512d | 0d | 0,00% | 0,00% | 0,00% | 0,00% |
| 1690 | 1.5.61.12.2.2 | Especies arboreas |  | 1d | 2023-11-23 | 2023-11-24 | 1689SS | 543d | 41d | 0,00% | 0,00% | 0,00% | 0,00% |
| 1691 | 1.5.61.12.2.3 | Jardines horizontales |  | 3d | 2023-11-24 | 2023-11-29 | 1689 | 540d | 38d | 0,00% | 0,00% | 0,00% | 0,00% |
| 1692 | 1.5.61.12.3 | **URBANISMO** |  | 32d | 2023-11-23 | 2024-01-10 |  | 512d |  | 0,00% | 0,00% | 0,00% | 0,00% |
| 1693 | 1.5.61.12.3.1 | Instalación de prefabricados. Incluye cañuelas, sardineles, bordillos, pisos en adoquín, tabletas y concreto escobeado. |  | 15d | 2023-11-23 | 2023-12-14 | 1689SS | 512d | 0d | 0,00% | 0,00% | 0,00% | 0,00% |
| 1694 | 1.5.61.12.3.2 | Mobiliario y elementos independientes |  | 17d | 2023-12-14 | 2024-01-10 | 1693 | 512d | 10d | 0,00% | 0,00% | 0,00% | 0,00% |
| 1695 | 1.5.61.13 | FIN TORRE 19 | milestone | 0d | 2024-01-23 | 2024-01-23 | 1631, 1632, 1638, 1639, 1681, 1682, 1690, 1691, 1694 | 502d |  | 0,00% | 0,00% | 0,00% | 0,00% |
| 1696 | 1.5.61.14 | Torre 19: Hito de Aprobación Para Pago Preliminares, Demoliones, Excavación y Cimentación | milestone | 0d | 2024-04-08 | 2024-04-08 | 1629, 1636, 1640, 1652, 1683, 1633, 1684 | 447d |  | 0,00% | 0,00% | 0,00% | 0,00% |
| 1697 | 1.5.61.15 | Torre 19: Hito de Aprobación Para Pago Redes | milestone | 0d | 2024-05-03 | 2024-05-03 | 1628, 1654, 1662, 1667, 1673, 1677 | 428d |  | 0,00% | 0,00% | 0,00% | 0,00% |
| 1698 | 1.5.61.16 | Torre 19: Hito de Aprobación Para Pago Electromecánico | milestone | 0d | 2024-02-21 | 2024-02-21 | 1658 | 480d |  | 0,00% | 0,00% | 0,00% | 0,00% |
| 1699 | 1.5.62 | Entrega de predios por parte de IDU al constructor | milestone | 0d | 2023-07-13 | 2023-07-13 | 47 | 418d | 0d | 0,00% | 0,00% | 0,00% | 0,00% |
| 1700 | 1.5.63 | **PERMISOS** |  | 1d | 2023-07-13 | 2023-07-14 |  | 483d |  | 0,00% | 0,00% | 0,00% | 0,00% |
| 1701 | 1.5.63.1 | Trabajo Nocturno | milestone | 0d | 2023-07-13 | 2023-07-13 | 1699 | 484d | 66d | 0,00% | 0,00% | 0,00% | 0,00% |
| 1702 | 1.5.63.2 | Energía (Baja Tensión) |  | 1d | 2023-07-14 | 2023-07-14 | 1699 | 483d | 65d | 0,00% | 0,00% | 0,00% | 0,00% |
| 1703 | 1.5.63.3 | Gestión Interinstitucional IDRD | milestone | 0d | 2023-07-13 | 2023-07-13 | 1699 | 484d | 66d | 0,00% | 0,00% | 0,00% | 0,00% |
| 1704 | 1.5.64 | **TORRE 20** |  | 155d | 2023-10-12 | 2024-05-18 |  | 247d |  | 0,00% | 0,00% | 0,00% | 0,00% |
| 1705 | 1.5.64.1 | TRASLADO DE REDES |  | 45d | 2023-10-12 | 2023-12-15 | 1699FS+66d, 1701, 1702, 1703 | 418d | 0d | 0,00% | 0,00% | 0,00% | 0,00% |
| 1706 | 1.5.64.2 | **PRELIMINARES DE OBRA, MOVIMIENTO DE TIERRAS Y RELLENOS** |  | 19d | 2023-12-15 | 2024-01-13 |  | 418d | 91d | 0,00% | 0,00% | 0,00% | 0,00% |
| 1707 | 1.5.64.2.1 | Replanteo General |  | 4d | 2023-12-15 | 2023-12-21 | 1705 | 418d | 0d | 0,00% | 0,00% | 0,00% | 0,00% |
| 1708 | 1.5.64.2.2 | Cerramiento y Señalización |  | 5d | 2023-12-21 | 2023-12-28 | 1707 | 519d | 22d | 0,00% | 0,00% | 0,00% | 0,00% |
| 1709 | 1.5.64.2.3 | Tala de Especies |  | 5d | 2023-12-21 | 2023-12-28 | 1707 | 509d | 0d | 0,00% | 0,00% | 0,00% | 0,00% |

| ID | WBS | Task | Type | Duration | Start | Finish | Predecessors | Total slack | Free slack | % Avance Planeado | % avance planeado en costo (texto) | % Completado (décimales) | % Completado en Costo |
| --- | --- | --- | --- | --- | --- | --- | --- | --- | --- | --- | --- | --- | --- |
| 1710 | 1.5.64.2.4 | **DEMOLICIONES** |  | 10d | 2023-12-29 | 2024-01-13 |  | 509d | 91d | 0,00% | 0,00% | 0,00% | 0,00% |
| 1711 | 1.5.64.2.4.1 | Demoliciones de construcciones existentes |  | 10d | 2023-12-29 | 2024-01-13 | 1709 | 509d | 0d | 0,00% | 0,00% | 0,00% | 0,00% |
| 1712 | 1.5.64.2.4.2 | Fin demoliciones | milestone | 0d | 2024-01-13 | 2024-01-13 | 1711 | 509d |  | 0,00% | 0,00% | 0,00% | 0,00% |
| 1713 | 1.5.64.3 | **MOVIMIENTO DE TIERRAS** |  | 22d | 2023-12-29 | 2024-01-30 |  | 418d | 79d | 0,00% | 0,00% | 0,00% | 0,00% |
| 1714 | 1.5.64.3.1 | Excavación Mecánica En Material Común |  | 20d | 2023-12-29 | 2024-01-26 | 1707FS+5d | 418d | 0d | 0,00% | 0,00% | 0,00% | 0,00% |
| 1715 | 1.5.64.3.2 | Nivelación y Compactación de Subrasante |  | 2d | 2024-01-26 | 2024-01-30 | 1714 | 497d | 0d | 0,00% | 0,00% | 0,00% | 0,00% |
| 1716 | 1.5.64.3.3 | Transporte y Disposición Final de Escombros en Sitio Autorizado |  | 20d | 2023-12-29 | 2024-01-26 | 1714SS | 499d | 2d | 0,00% | 0,00% | 0,00% | 0,00% |
| 1717 | 1.5.64.4 | **CIMENTACIÓN** |  | 25d | 2023-10-23 | 2023-11-27 |  | 241d | 124d | 0,00% | 0,00% | 0,00% | 0,00% |
| 1718 | 1.5.64.4.1 | **CONSTRUCCIÓN PILOTES** |  | 9d | 2023-10-23 | 2023-11-02 |  | 241d |  | 0,00% | 0,00% | 0,00% | 0,00% |
| 1719 | 1.5.64.4.1.1 | Excavación para Pilotes |  | 5d | 2023-10-23 | 2023-10-27 | 1642FS+1d | 241d | 0d | 0,00% | 0,00% | 0,00% | 0,00% |
| 1720 | 1.5.64.4.1.2 | Acero de Refuerzo |  | 3d | 2023-10-26 | 2023-10-30 | 1719FS-2d | 243d | 0d | 0,00% | 0,00% | 0,00% | 0,00% |
| 1721 | 1.5.64.4.1.3 | Concreto |  | 3d | 2023-10-27 | 2023-10-31 | 1720FS-2d | 243d | 0d | 0,00% | 0,00% | 0,00% | 0,00% |
| 1722 | 1.5.64.4.1.4 | Descabece de Pilotes |  | 2d | 2023-10-31 | 2023-11-02 | 1721 | 243d | 0d | 0,00% | 0,00% | 0,00% | 0,00% |
| 1723 | 1.5.64.4.2 | **CONSTRUCCIÓN DADOS DE CIMENTACIÓN** |  | 6d | 2023-11-02 | 2023-11-11 |  | 243d |  | 0,00% | 0,00% | 0,00% | 0,00% |
| 1724 | 1.5.64.4.2.1 | Acero de Refuerzo |  | 3d | 2023-11-02 | 2023-11-08 | 1722 | 243d | 0d | 0,00% | 0,00% | 0,00% | 0,00% |
| 1725 | 1.5.64.4.2.2 | Concreto |  | 3d | 2023-11-08 | 2023-11-11 | 1724 | 243d | 0d | 0,00% | 0,00% | 0,00% | 0,00% |
| 1726 | 1.5.64.4.3 | **PEDESTAL** |  | 10d | 2023-11-14 | 2023-11-27 |  | 243d |  | 0,00% | 0,00% | 0,00% | 0,00% |
| 1727 | 1.5.64.4.3.1 | Acero de Refuerzo |  | 5d | 2023-11-14 | 2023-11-20 | 1725 | 243d | 0d | 0,00% | 0,00% | 0,00% | 0,00% |
| 1728 | 1.5.64.4.3.2 | Concreto |  | 5d | 2023-11-20 | 2023-11-27 | 1727 | 243d | 0d | 0,00% | 0,00% | 0,00% | 0,00% |
| 1729 | 1.5.64.5 | **RELLENOS** |  | 4d | 2023-11-27 | 2023-12-01 |  | 486d | 120d | 0,00% | 0,00% | 0,00% | 0,00% |
| 1730 | 1.5.64.5.1 | Relleno De Material Seleccionado |  | 4d | 2023-11-27 | 2023-12-01 | 1728 | 486d | 0d | 0,00% | 0,00% | 0,00% | 0,00% |
| 1731 | 1.5.64.6 | **PUESTA A TIERRA** |  | 2d | 2023-12-01 | 2023-12-04 |  | 491d | 113d | 0,00% | 0,00% | 0,00% | 0,00% |
| 1732 | 1.5.64.6.1 | Instalación Cable de Cobre |  | 1d | 2023-12-01 | 2023-12-02 | 1730 | 491d | 0d | 0,00% | 0,00% | 0,00% | 0,00% |
| 1733 | 1.5.64.6.2 | Varilla COOPER WELD 5/8" x 2.44m. |  | 1d | 2023-12-04 | 2023-12-04 | 1732 | 491d | 0d | 0,00% | 0,00% | 0,00% | 0,00% |
| 1734 | 1.5.64.6.3 | Fin Puesta a Tierra | milestone | 0d | 2023-12-04 | 2023-12-04 | 1732, 1733 | 491d | 68d | 0,00% | 0,00% | 0,00% | 0,00% |

| ID | WBS | Task | Type | Duration | Start | Finish | Predecessors | Total slack | Free slack | % Avance Planeado | % avance planeado en costo (texto) | % Completado (décimales) | % Completado en Costo |
| --- | --- | --- | --- | --- | --- | --- | --- | --- | --- | --- | --- | --- | --- |
| 1735 | 1.5.64.7 | **MONTAJE ELECTROMECÁNICO** |  | 10d | 2024-02-14 | 2024-02-27 |  | 186d | 0d | 0,00% | 0,00% | 0,00% | 0,00% |
| 1736 | 1.5.64.7.1 | Montaje Mecánico |  | 5d | 2024-02-14 | 2024-02-21 | 1659, 1728 | 186d | 0d | 0,00% | 0,00% | 0,00% | 0,00% |
| 1737 | 1.5.64.7.2 | Montaje Eléctrico |  | 5d | 2024-02-21 | 2024-02-27 | 1736 | 423d | 0d | 0,00% | 0,00% | 0,00% | 0,00% |
| 1738 | 1.5.64.7.3 | Fin montaje Electromecánico | milestone | 0d | 2024-02-27 | 2024-02-27 | 1736, 1737 | 423d | 0d | 0,00% | 0,00% | 0,00% | 0,00% |
| 1739 | 1.5.64.8 | **ALIMENTACIÓN ELÉCTRICA** |  | 7d | 2024-02-28 | 2024-03-07 |  | 423d | 45d | 0,00% | 0,00% | 0,00% | 0,00% |
| 1740 | 1.5.64.8.1 | Instalacion de tuberia PVC |  | 5d | 2024-02-28 | 2024-03-05 | 1738, 1730, 1728 | 423d | 0d | 0,00% | 0,00% | 0,00% | 0,00% |
| 1741 | 1.5.64.8.2 | Cableado |  | 1d | 2024-03-05 | 2024-03-06 | 1740 | 423d | 0d | 0,00% | 0,00% | 0,00% | 0,00% |
| 1742 | 1.5.64.8.3 | Instalación de Medidor |  | 1d | 2024-03-06 | 2024-03-07 | 1741 | 423d | 0d | 0,00% | 0,00% | 0,00% | 0,00% |
| 1743 | 1.5.64.8.4 | Fin Alimentación Eléctrica | milestone | 0d | 2024-03-07 | 2024-03-07 | 1742 | 423d | 0d | 0,00% | 0,00% | 0,00% | 0,00% |
| 1744 | 1.5.64.9 | **ALUMBRADO PÚBLICO DE TORRE** |  | 5d | 2024-02-28 | 2024-03-05 |  | 427d | 47d | 0,00% | 0,00% | 0,00% | 0,00% |
| 1745 | 1.5.64.9.1 | Tubería Eléctrica PVC |  | 5d | 2024-02-28 | 2024-03-05 | 1740SS | 427d | 0d | 0,00% | 0,00% | 0,00% | 0,00% |
| 1746 | 1.5.64.9.2 | Accesorios |  | 1d | 2024-02-28 | 2024-02-28 | 1745SS | 427d | 0d | 0,00% | 0,00% | 0,00% | 0,00% |
| 1747 | 1.5.64.9.3 | Cableado |  | 1d | 2024-02-29 | 2024-02-29 | 1746 | 427d | 0d | 0,00% | 0,00% | 0,00% | 0,00% |
| 1748 | 1.5.64.9.4 | Instalación de A.P. |  | 1d | 2024-03-01 | 2024-03-01 | 1747 | 427d | 0d | 0,00% | 0,00% | 0,00% | 0,00% |
| 1749 | 1.5.64.9.5 | Fin Alumbrado Público de Torre | milestone | 0d | 2024-03-01 | 2024-03-01 | 1748 | 427d | 4d | 0,00% | 0,00% | 0,00% | 0,00% |
| 1750 | 1.5.64.10 | **CERTIFICACIONES RETIE Y RETILAP** |  | 45d | 2024-03-07 | 2024-05-10 |  | 423d | 0d | 0,00% | 0,00% | 0,00% | 0,00% |
| 1751 | 1.5.64.10.1 | Certificación RETIE |  | 45d | 2024-03-07 | 2024-05-10 | 1705, 1749, 1743, 1734 | 423d | 0d | 0,00% | 0,00% | 0,00% | 0,00% |
| 1752 | 1.5.64.10.2 | Certificación RETILAP |  | 45d | 2024-03-07 | 2024-05-10 | 1751SS | 423d | 0d | 0,00% | 0,00% | 0,00% | 0,00% |
| 1753 | 1.5.64.10.3 | Fin Certificaciones RETIE Y RETILAP | milestone | 0d | 2024-05-10 | 2024-05-10 | 1752 | 423d |  | 0,00% | 0,00% | 0,00% | 0,00% |
| 1754 | 1.5.64.11 | **REDES HIDRÁULICAS EXTERNAS** |  | 7d | 2023-12-29 | 2024-01-10 |  | 418d | 89d | 0,00% | 0,00% | 0,00% | 0,00% |
| 1755 | 1.5.64.11.1 | **RED DE ALCANTARILLADO** |  | 7d | 2023-12-29 | 2024-01-10 |  | 418d |  | 0,00% | 0,00% | 0,00% | 0,00% |
| 1756 | 1.5.64.11.1.1 | Excavación manual para redes y canal monolítico |  | 5d | 2023-12-29 | 2024-01-05 | 1714SS | 418d | 0d | 0,00% | 0,00% | 0,00% | 0,00% |
| 1757 | 1.5.64.11.1.2 | Instalación de tubería, incluye accesorios. |  | 2d | 2024-01-03 | 2024-01-05 | 1756SS+3d | 512d | 0d | 0,00% | 0,00% | 0,00% | 0,00% |
| 1758 | 1.5.64.11.1.3 | Rellenos para redes y canal |  | 3d | 2024-01-04 | 2024-01-10 | 1757SS+1d | 512d | 15d | 0,00% | 0,00% | 0,00% | 0,00% |
| 1759 | 1.5.64.11.1.4 | Instalación de canal monolítico |  | 2d | 2024-01-03 | 2024-01-05 | 1756SS+3d | 418d | 0d | 0,00% | 0,00% | 0,00% | 0,00% |

| ID | WBS | Task | Type | Duration | Start | Finish | Predecessors | Total slack | Free slack | % Avance Planeado | % avance planeado en costo (texto) | % Completado (décimales) | % Completado en Costo |
| --- | --- | --- | --- | --- | --- | --- | --- | --- | --- | --- | --- | --- | --- |
| 1760 | 1.5.64.12 | **URBANISMO Y PAISAJISMO** |  | 120d | 2023-12-01 | 2024-05-18 |  | 418d | 0d | 0,00% | 0,00% | 0,00% | 0,00% |
| 1761 | 1.5.64.12.1 | **ESTRUCTURAS DE CONTENCIÓN PARA URBANISMO** |  | 96d | 2024-01-05 | 2024-05-18 |  | 418d | 0d | 0,00% | 0,00% | 0,00% | 0,00% |
| 1762 | 1.5.64.12.1.1 | Construcción de muros en concreto reforzado y mampostería estructural. Incluye otros elementos y construcción de filtro de drenaje tras muro. |  | 41d | 2024-01-05 | 2024-02-29 | 1759 | 418d | 0d | 0,00% | 0,00% | 0,00% | 0,00% |
| 1763 | 1.5.64.12.1.2 | Construcción de escaleras y gradas para teatrinos. |  | 41d | 2024-03-20 | 2024-05-18 | 1762FS+14d | 418d | 0d | 0,00% | 0,00% | 0,00% | 0,00% |
| 1764 | 1.5.64.12.1.3 | Fin Estructuras de contención para urbanismo | milestone | 0d | 2024-05-18 | 2024-05-18 | 1763 | 418d |  | 0,00% | 0,00% | 0,00% | 0,00% |
| 1765 | 1.5.64.12.2 | **PAISAJISMO** |  | 6d | 2023-12-01 | 2023-12-11 |  | 515d |  | 0,00% | 0,00% | 0,00% | 0,00% |
| 1766 | 1.5.64.12.2.1 | Contenedores de raices, Instalación de grama y hiedras. Incluye tierra negra. |  | 1d | 2023-12-01 | 2023-12-02 | 1730 | 515d | 0d | 0,00% | 0,00% | 0,00% | 0,00% |
| 1767 | 1.5.64.12.2.2 | Jardines verticales |  | 5d | 2023-12-04 | 2023-12-11 | 1766 | 532d | 35d | 0,00% | 0,00% | 0,00% | 0,00% |
| 1768 | 1.5.64.12.3 | **URBANISMO** |  | 23d | 2023-12-01 | 2024-01-04 |  | 515d |  | 0,00% | 0,00% | 0,00% | 0,00% |
| 1769 | 1.5.64.12.3.1 | Instalación de prefabricados. Incluye cañuelas, sardineles, bordillos, pisos en adoquín, tabletas y concreto escobeado. |  | 15d | 2023-12-01 | 2023-12-22 | 1766SS | 515d | 0d | 0,00% | 0,00% | 0,00% | 0,00% |
| 1770 | 1.5.64.12.3.2 | Mobiliario y elementos independientes |  | 8d | 2023-12-22 | 2024-01-04 | 1769 | 515d | 18d | 0,00% | 0,00% | 0,00% | 0,00% |
| 1771 | 1.5.64.13 | FIN TORRE 20 | milestone | 0d | 2024-01-30 | 2024-01-30 | 1708, 1709, 1715, 1716, 1758, 1759, 1767, 1770 | 497d |  | 0,00% | 0,00% | 0,00% | 0,00% |
| 1772 | 1.5.64.14 | Torre 20: Hito de Aprobación Para Pago Preliminares, Demoliones, Excavación y Cimentación | milestone | 0d | 2024-05-18 | 2024-05-18 | 1706, 1713, 1717, 1729, 1760, 1710, 1761 | 418d |  | 0,00% | 0,00% | 0,00% | 0,00% |
| 1773 | 1.5.64.15 | Torre 20: Hito de Aprobación Para Pago Redes | milestone | 0d | 2024-05-10 | 2024-05-10 | 1705, 1731, 1739, 1744, 1750, 1754 | 423d |  | 0,00% | 0,00% | 0,00% | 0,00% |
| 1774 | 1.5.64.16 | Torre 20: Hito de Aprobación Para Pago Electromecánico | milestone | 0d | 2024-02-27 | 2024-02-27 | 1735 | 475d |  | 0,00% | 0,00% | 0,00% | 0,00% |
| 1775 | 1.5.65 | Entrega de predios por parte de IDU al constructor |  | 1d | 2023-07-14 | 2023-07-14 | 47 | 473d | 0d | 0,00% | 0,00% | 0,00% | 0,00% |
| 1776 | 1.5.66 | **PERMISOS** |  | 1d | 2023-07-15 | 2023-07-17 |  | 547d | 74d | 0,00% | 0,00% | 0,00% | 0,00% |
| 1777 | 1.5.66.1 | Trabajo Nocturno |  | 1d | 2023-07-15 | 2023-07-17 | 1775 | 547d |  | 0,00% | 0,00% | 0,00% | 0,00% |
| 1778 | 1.5.66.2 | Silviculturales |  | 1d | 2023-07-15 | 2023-07-17 | 1775 | 547d | 74d | 0,00% | 0,00% | 0,00% | 0,00% |
| 1779 | 1.5.66.3 | Aprobación PMRRA |  | 1d | 2023-07-15 | 2023-07-17 | 1775 | 547d | 74d | 0,00% | 0,00% | 0,00% | 0,00% |
| 1780 | 1.5.66.4 | Permiso de Uso (Accesibilidad) |  | 1d | 2023-07-15 | 2023-07-17 | 1775 | 547d | 74d | 0,00% | 0,00% | 0,00% | 0,00% |
| 1781 | 1.5.67 | **TORRE 21** |  | 141d | 2023-10-27 | 2024-05-14 |  | 243d |  | 0,00% | 0,00% | 0,00% | 0,00% |
| 1782 | 1.5.67.1 | TRASLADO DE REDES |  | 45d | 2023-10-27 | 2023-12-29 | 1775FS+75d, 1776, 1778, 1779, 1780 | 473d | 0d | 0,00% | 0,00% | 0,00% | 0,00% |
| 1783 | 1.5.67.2 | **PRELIMINARES DE OBRA, MOVIMIENTO DE TIERRAS Y RELLENOS** |  | 20d | 2023-12-30 | 2024-01-29 |  | 487d | 11d | 0,00% | 0,00% | 0,00% | 0,00% |
| 1784 | 1.5.67.2.1 | Replanteo General |  | 4d | 2023-12-30 | 2024-01-05 | 1782 | 487d | 0d | 0,00% | 0,00% | 0,00% | 0,00% |
| 1785 | 1.5.67.2.2 | Cerramiento y Señalización |  | 4d | 2024-01-05 | 2024-01-12 | 1784 | 510d | 23d | 0,00% | 0,00% | 0,00% | 0,00% |
| 1786 | 1.5.67.2.3 | Tala de Especies |  | 4d | 2024-01-05 | 2024-01-12 | 1784 | 498d | 0d | 0,00% | 0,00% | 0,00% | 0,00% |

| ID | WBS | Task | Type | Duration | Start | Finish | Predecessors | Total slack | Free slack | % Avance Planeado | % avance planeado en costo (texto) | % Completado (décimales) | % Completado en Costo |
| --- | --- | --- | --- | --- | --- | --- | --- | --- | --- | --- | --- | --- | --- |
| 1787 | 1.5.67.2.4 | **DEMOLICIONES** |  | 12d | 2024-01-12 | 2024-01-29 |  | 498d | 11d | 0,00% | 0,00% | 0,00% | 0,00% |
| 1788 | 1.5.67.2.4.1 | Demoliciones de construcciones existentes |  | 12d | 2024-01-12 | 2024-01-29 | 1786 | 498d | 0d | 0,00% | 0,00% | 0,00% | 0,00% |
| 1789 | 1.5.67.2.4.2 | Fin demoliciones | milestone | 0d | 2024-01-29 | 2024-01-29 | 1788 | 498d |  | 0,00% | 0,00% | 0,00% | 0,00% |
| 1790 | 1.5.67.3 | **MOVIMIENTO DE TIERRAS** |  | 22d | 2024-01-15 | 2024-02-12 |  | 487d | 0d | 0,00% | 0,00% | 0,00% | 0,00% |
| 1791 | 1.5.67.3.1 | Excavación Mecánica En Material Comen |  | 20d | 2024-01-15 | 2024-02-08 | 1784FS+5d | 487d | 0d | 0,00% | 0,00% | 0,00% | 0,00% |
| 1792 | 1.5.67.3.2 | Nivelación y Compactación de Subrasante |  | 2d | 2024-02-09 | 2024-02-12 | 1791 | 487d | 0d | 0,00% | 0,00% | 0,00% | 0,00% |
| 1793 | 1.5.67.3.3 | Transporte 'I Disposición Final de escombros |  | 20d | 2024-01-15 | 2024-02-08 | 1791SS | 489d | 2d | 0,00% | 0,00% | 0,00% | 0,00% |
| 1794 | 1.5.67.4 | **CIMENTACIÓN** |  | 25d | 2023-10-30 | 2023-12-04 |  | 241d | 49d | 0,00% | 0,00% | 0,00% | 0,00% |
| 1795 | 1.5.67.4.1 | **CONSTRUCCIÓN PILOTES** |  | 7d | 2023-10-30 | 2023-11-09 |  | 241d |  | 0,00% | 0,00% | 0,00% | 0,00% |
| 1796 | 1.5.67.4.1.1 | Excavación para Pilotes |  | 5d | 2023-10-30 | 2023-11-07 | 1719FS+1d | 241d | 0d | 0,00% | 0,00% | 0,00% | 0,00% |
| 1797 | 1.5.67.4.1.2 | Acero de Refuerzo |  | 3d | 2023-11-02 | 2023-11-08 | 1796FS-2d | 242d | 0d | 0,00% | 0,00% | 0,00% | 0,00% |
| 1798 | 1.5.67.4.1.3 | Concreto |  | 3d | 2023-11-03 | 2023-11-09 | 1797FS-2d | 242d | 0d | 0,00% | 0,00% | 0,00% | 0,00% |
| 1799 | 1.5.67.4.2 | Descabece de Pilotes |  | 2d | 2023-11-09 | 2023-11-11 | 1798 | 242d | 0d | 0,00% | 0,00% | 0,00% | 0,00% |
| 1800 | 1.5.67.4.3 | **CONSTRUCCIÓN DADOS DE CIMENTACIÓN** |  | 6d | 2023-11-14 | 2023-11-21 |  | 242d |  | 0,00% | 0,00% | 0,00% | 0,00% |
| 1801 | 1.5.67.4.3.1 | Acero de Refuerzo |  | 3d | 2023-11-14 | 2023-11-16 | 1799 | 242d | 0d | 0,00% | 0,00% | 0,00% | 0,00% |
| 1802 | 1.5.67.4.3.2 | Concreto |  | 3d | 2023-11-17 | 2023-11-21 | 1801 | 242d | 0d | 0,00% | 0,00% | 0,00% | 0,00% |
| 1803 | 1.5.67.4.4 | **PEDESTAL** |  | 10d | 2023-11-21 | 2023-12-04 |  | 242d |  | 0,00% | 0,00% | 0,00% | 0,00% |
| 1804 | 1.5.67.4.4.1 | Acero de Refuerzo |  | 5d | 2023-11-21 | 2023-11-28 | 1802 | 242d | 0d | 0,00% | 0,00% | 0,00% | 0,00% |
| 1805 | 1.5.67.4.4.2 | Concreto |  | 5d | 2023-11-28 | 2023-12-04 | 1804 | 242d | 0d | 0,00% | 0,00% | 0,00% | 0,00% |
| 1806 | 1.5.67.5 | **RELLENOS** |  | 4d | 2023-12-05 | 2023-12-11 |  | 484d | 45d | 0,00% | 0,00% | 0,00% | 0,00% |
| 1807 | 1.5.67.5.1 | Relleno De Material Seleccionado |  | 4d | 2023-12-05 | 2023-12-11 | 1805 | 484d | 0d | 0,00% | 0,00% | 0,00% | 0,00% |
| 1808 | 1.5.67.6 | **PUESTA A TIERRA** |  | 2d | 2023-12-11 | 2023-12-13 |  | 485d | 108d | 0,00% | 0,00% | 0,00% | 0,00% |
| 1809 | 1.5.67.6.1 | Instalación Cable de Cobre |  | 1d | 2023-12-11 | 2023-12-12 | 1807 | 485d | 0d | 0,00% | 0,00% | 0,00% | 0,00% |
| 1810 | 1.5.67.6.2 | Varilla COOPER WELD 5/8" x 2.44m. |  | 1d | 2023-12-12 | 2023-12-13 | 1809 | 485d | 0d | 0,00% | 0,00% | 0,00% | 0,00% |
| 1811 | 1.5.67.6.3 | Fin Puesta a Tierra | milestone | 0d | 2023-12-13 | 2023-12-13 | 1809, 1810 | 485d | 63d | 0,00% | 0,00% | 0,00% | 0,00% |

| ID | WBS | Task | Type | Duration | Start | Finish | Predecessors | Total slack | Free slack | % Avance Planeado | % avance planeado en costo (texto) | % Completado (décimales) | % Completado en Costo |
| --- | --- | --- | --- | --- | --- | --- | --- | --- | --- | --- | --- | --- | --- |
| 1812 | 1.5.67.7 | **MONTAJE ELECTROMECÁNICO** |  | 10d | 2024-02-21 | 2024-03-05 |  | 186d | 0d | 0,00% | 0,00% | 0,00% | 0,00% |
| 1813 | 1.5.67.7.1 | Montaje Mecánico |  | 5d | 2024-02-21 | 2024-02-27 | 1736, 1805 | 186d | 0d | 0,00% | 0,00% | 0,00% | 0,00% |
| 1814 | 1.5.67.7.2 | Montaje Eléctrico |  | 5d | 2024-02-28 | 2024-03-05 | 1813 | 422d | 0d | 0,00% | 0,00% | 0,00% | 0,00% |
| 1815 | 1.5.67.7.3 | Fin montaje Electromecánico | milestone | 0d | 2024-03-05 | 2024-03-05 | 1813, 1814 | 422d | 0d | 0,00% | 0,00% | 0,00% | 0,00% |
| 1816 | 1.5.67.8 | **ALUMBRADO PÚBLICO DE TORRE** |  | 5d | 2024-03-05 | 2024-03-12 |  | 422d | 43d | 0,00% | 0,00% | 0,00% | 0,00% |
| 1817 | 1.5.67.8.1 | Tubería Eléctrica PVC |  | 5d | 2024-03-05 | 2024-03-12 | 1815, 1807, 1805 | 422d | 0d | 0,00% | 0,00% | 0,00% | 0,00% |
| 1818 | 1.5.67.8.2 | Accesorios |  | 1d | 2024-03-05 | 2024-03-06 | 1817SS | 422d | 0d | 0,00% | 0,00% | 0,00% | 0,00% |
| 1819 | 1.5.67.8.3 | Cableado |  | 1d | 2024-03-06 | 2024-03-07 | 1818 | 422d | 0d | 0,00% | 0,00% | 0,00% | 0,00% |
| 1820 | 1.5.67.8.4 | Instalación de A.P. |  | 1d | 2024-03-07 | 2024-03-08 | 1819 | 422d | 0d | 0,00% | 0,00% | 0,00% | 0,00% |
| 1821 | 1.5.67.8.5 | Fin Alumbrado Público de Torre | milestone | 0d | 2024-03-08 | 2024-03-08 | 1820 | 422d | 0d | 0,00% | 0,00% | 0,00% | 0,00% |
| 1822 | 1.5.67.9 | **CERTIFICACIONES RETIE Y RETILAP** |  | 45d | 2024-03-08 | 2024-05-14 |  | 422d | 0d | 0,00% | 0,00% | 0,00% | 0,00% |
| 1823 | 1.5.67.9.1 | Certificación RETIE |  | 45d | 2024-03-08 | 2024-05-14 | 1821, 1811, 1782 | 422d | 0d | 0,00% | 0,00% | 0,00% | 0,00% |
| 1824 | 1.5.67.9.2 | Certificación RETILAP |  | 45d | 2024-03-08 | 2024-05-14 | 1823SS | 422d | 0d | 0,00% | 0,00% | 0,00% | 0,00% |
| 1825 | 1.5.67.9.3 | Fin Certificaciones RETIE Y RETILAP | milestone | 0d | 2024-05-14 | 2024-05-14 | 1824 | 422d |  | 0,00% | 0,00% | 0,00% | 0,00% |
| 1826 | 1.5.67.10 | **REDES HIDRÁULICAS EXTERNAS** |  | 7d | 2024-01-15 | 2024-01-23 |  | 502d | 80d | 0,00% | 0,00% | 0,00% | 0,00% |
| 1827 | 1.5.67.10.1 | **RED DE ALCANTARILLADO** |  | 7d | 2024-01-15 | 2024-01-23 |  | 502d |  | 0,00% | 0,00% | 0,00% | 0,00% |
| 1828 | 1.5.67.10.1.1 | Excavación manual para redes y canal monolítico |  | 5d | 2024-01-15 | 2024-01-19 | 1791SS | 502d | 0d | 0,00% | 0,00% | 0,00% | 0,00% |
| 1829 | 1.5.67.10.1.2 | Instalación de tubería, incluye accesorios. |  | 2d | 2024-01-18 | 2024-01-19 | 1828SS+3d | 502d | 0d | 0,00% | 0,00% | 0,00% | 0,00% |
| 1830 | 1.5.67.10.1.3 | Rellenos para redes y canal |  | 3d | 2024-01-19 | 2024-01-23 | 1829SS+1d | 502d | 15d | 0,00% | 0,00% | 0,00% | 0,00% |
| 1831 | 1.5.67.10.1.4 | Instalación de canal monolítico |  | 2d | 2024-01-18 | 2024-01-19 | 1828SS+3d | 504d | 17d | 0,00% | 0,00% | 0,00% | 0,00% |
| 1832 | 1.5.67.11 | FIN TORRE 21 | milestone | 0d | 2024-02-12 | 2024-02-12 | 1785, 1786, 1792, 1793, 1830, 1831 | 487d |  | 0,00% | 0,00% | 0,00% | 0,00% |
| 1833 | 1.5.67.12 | Torre 21: Hito de Aprobación Para Pago Preliminares, Demoliones, Excavación y Cimentación | milestone | 0d | 2024-02-12 | 2024-02-12 | 1783, 1790, 1794, 1806, 1787 | 487d |  | 0,00% | 0,00% | 0,00% | 0,00% |
| 1834 | 1.5.67.13 | Torre 21: Hito de Aprobación Para Pago Redes | milestone | 0d | 2024-05-14 | 2024-05-14 | 1782, 1808, 1816, 1822, 1826 | 422d |  | 0,00% | 0,00% | 0,00% | 0,00% |
| 1835 | 1.5.67.14 | Torre 21: Hito de Aprobación Para Pago Electromecánico | milestone | 0d | 2024-03-05 | 2024-03-05 | 1812 | 470d |  | 0,00% | 0,00% | 0,00% | 0,00% |
| 1836 | 1.5.68 | Entrega de predios por parte de IDU al constructor |  | 1d | 2023-07-14 | 2023-07-14 | 47 | 366d | 0d | 0,00% | 0,00% | 0,00% | 0,00% |

| ID | WBS | Task | Type | Duration | Start | Finish | Predecessors | Total slack | Free slack | % Avance Planeado | % avance planeado en costo (texto) | % Completado (décimales) | % Completado en Costo |
| --- | --- | --- | --- | --- | --- | --- | --- | --- | --- | --- | --- | --- | --- |
| 1837 | 1.5.69 | **PERMISOS** |  | 1d | 2023-07-15 | 2023-07-17 |  | 433d |  | 0,00% | 0,00% | 0,00% | 0,00% |
| 1838 | 1.5.69.1 | Trabajo Nocturno |  | 1d | 2023-07-15 | 2023-07-17 | 1836 | 433d | 0d | 0,00% | 0,00% | 0,00% | 0,00% |
| 1839 | 1.5.69.2 | Silviculturales |  | 1d | 2023-07-15 | 2023-07-17 | 1836 | 433d | 0d | 0,00% | 0,00% | 0,00% | 0,00% |
| 1840 | 1.5.69.3 | Coordinación Acueducto y Alcantarillado |  | 1d | 2023-07-15 | 2023-07-17 | 1836 | 433d | 0d | 0,00% | 0,00% | 0,00% | 0,00% |
| 1841 | 1.5.69.4 | Aprobación PMRRA |  | 1d | 2023-07-15 | 2023-07-17 | 1836 | 433d | 0d | 0,00% | 0,00% | 0,00% | 0,00% |
| 1842 | 1.5.69.5 | Permiso de Uso (Accesibilidad) |  | 1d | 2023-07-15 | 2023-07-17 | 1836 | 433d | 0d | 0,00% | 0,00% | 0,00% | 0,00% |
| 1843 | 1.5.69.6 | Fin de Permisos | milestone | 0d | 2023-07-17 | 2023-07-17 | 1838, 1839, 1840, 1841, 1842 | 637d |  | 0,00% | 0,00% | 0,00% | 0,00% |
| 1844 | 1.5.70 | **TORRE 22** |  | 243d | 2023-11-02 | 2024-10-08 |  | 244d |  | 0,00% | 0,00% | 0,00% | 0,00% |
| 1845 | 1.5.70.1 | TRASLADO DE REDES |  | 45d | 2023-11-02 | 2024-01-09 | 1836FS+80d, 1838, 1839, 1840, 1841, 1842 | 366d | 0d | 0,00% | 0,00% | 0,00% | 0,00% |
| 1846 | 1.5.70.2 | **PRELIMINARES DE OBRA, MOVIMIENTO DE TIERRAS Y RELLENOS** |  | 32d | 2024-01-09 | 2024-02-20 |  | 481d | 166d | 0,00% | 0,00% | 0,00% | 0,00% |
| 1847 | 1.5.70.2.1 | Replanteo General |  | 4d | 2024-01-09 | 2024-01-13 | 1845 | 481d | 0d | 0,00% | 0,00% | 0,00% | 0,00% |
| 1848 | 1.5.70.2.2 | Cerramiento y Señalización |  | 4d | 2024-01-15 | 2024-01-18 | 1847 | 505d | 23d | 0,00% | 0,00% | 0,00% | 0,00% |
| 1849 | 1.5.70.2.3 | Tala de Especies |  | 4d | 2024-01-15 | 2024-01-18 | 1847 | 481d | 0d | 0,00% | 0,00% | 0,00% | 0,00% |
| 1850 | 1.5.70.2.4 | **DEMOLICIONES** |  | 24d | 2024-01-19 | 2024-02-20 |  | 481d | 166d | 0,00% | 0,00% | 0,00% | 0,00% |
| 1851 | 1.5.70.2.4.1 | Demoliciones de construcciones existentes |  | 24d | 2024-01-19 | 2024-02-20 | 1849 | 481d | 0d | 0,00% | 0,00% | 0,00% | 0,00% |
| 1852 | 1.5.70.2.4.2 | Fin demoliciones | milestone | 0d | 2024-02-20 | 2024-02-20 | 1851 | 481d |  | 0,00% | 0,00% | 0,00% | 0,00% |
| 1853 | 1.5.70.3 | **MOVIMIENTO DE TIERRAS** |  | 22d | 2024-01-20 | 2024-02-19 |  | 482d | 167d | 0,00% | 0,00% | 0,00% | 0,00% |
| 1854 | 1.5.70.3.1 | Excavación Mecánica En Material Comen |  | 20d | 2024-01-20 | 2024-02-15 | 1847FS+5d | 482d | 0d | 0,00% | 0,00% | 0,00% | 0,00% |
| 1855 | 1.5.70.3.2 | Nivelación y Compactación de Subrasante |  | 2d | 2024-02-15 | 2024-02-19 | 1854 | 482d | 0d | 0,00% | 0,00% | 0,00% | 0,00% |
| 1856 | 1.5.70.3.3 | Transporte 'I Disposición Final de escombros |  | 20d | 2024-01-20 | 2024-02-15 | 1854SS | 484d | 2d | 0,00% | 0,00% | 0,00% | 0,00% |
| 1857 | 1.5.70.4 | **CIMENTACIÓN** |  | 25d | 2023-11-08 | 2023-12-13 |  | 241d | 215d | 0,00% | 0,00% | 0,00% | 0,00% |
| 1858 | 1.5.70.4.1 | **CONSTRUCCIÓN PILOTES** |  | 7d | 2023-11-08 | 2023-11-17 |  | 241d |  | 0,00% | 0,00% | 0,00% | 0,00% |
| 1859 | 1.5.70.4.1.1 | Excavación para Pilotes |  | 5d | 2023-11-08 | 2023-11-15 | 1796FS+1d | 241d | 0d | 0,00% | 0,00% | 0,00% | 0,00% |
| 1860 | 1.5.70.4.1.2 | Acero de Refuerzo |  | 3d | 2023-11-14 | 2023-11-16 | 1859FS-2d | 241d | 0d | 0,00% | 0,00% | 0,00% | 0,00% |
| 1861 | 1.5.70.4.1.3 | Concreto |  | 3d | 2023-11-15 | 2023-11-17 | 1860FS-2d | 241d | 0d | 0,00% | 0,00% | 0,00% | 0,00% |
| 1862 | 1.5.70.4.2 | Descabece de Pilotes |  | 2d | 2023-11-18 | 2023-11-21 | 1861 | 241d | 0d | 0,00% | 0,00% | 0,00% | 0,00% |

| ID | WBS | Task | Type | Duration | Start | Finish | Predecessors | Total slack | Free slack | % Avance Planeado | % avance planeado en costo (texto) | % Completado (décimales) | % Completado en Costo |
| --- | --- | --- | --- | --- | --- | --- | --- | --- | --- | --- | --- | --- | --- |
| 1863 | 1.5.70.4.3 | **CONSTRUCCIÓN DADOS DE CIMENTACIÓN** |  | 6d | 2023-11-21 | 2023-11-29 |  | 241d |  | 0,00% | 0,00% | 0,00% | 0,00% |
| 1864 | 1.5.70.4.3.1 | Acero de Refuerzo |  | 3d | 2023-11-21 | 2023-11-24 | 1862 | 241d | 0d | 0,00% | 0,00% | 0,00% | 0,00% |
| 1865 | 1.5.70.4.3.2 | Concreto |  | 3d | 2023-11-24 | 2023-11-29 | 1864 | 241d | 0d | 0,00% | 0,00% | 0,00% | 0,00% |
| 1866 | 1.5.70.4.4 | **PEDESTAL** |  | 10d | 2023-11-29 | 2023-12-13 |  | 241d |  | 0,00% | 0,00% | 0,00% | 0,00% |
| 1867 | 1.5.70.4.4.1 | Acero de Refuerzo |  | 5d | 2023-11-29 | 2023-12-05 | 1865 | 241d | 0d | 0,00% | 0,00% | 0,00% | 0,00% |
| 1868 | 1.5.70.4.4.2 | Concreto |  | 5d | 2023-12-06 | 2023-12-13 | 1867 | 241d | 0d | 0,00% | 0,00% | 0,00% | 0,00% |
| 1869 | 1.5.70.5 | **RELLENOS** |  | 4d | 2023-12-13 | 2023-12-19 |  | 376d | 211d | 0,00% | 0,00% | 0,00% | 0,00% |
| 1870 | 1.5.70.5.1 | Relleno De Material Seleccionado |  | 4d | 2023-12-13 | 2023-12-19 | 1868 | 376d | 0d | 0,00% | 0,00% | 0,00% | 0,00% |
| 1871 | 1.5.70.6 | **PUESTA A TIERRA** |  | 2d | 2023-12-19 | 2023-12-21 |  | 377d | 107d | 0,00% | 0,00% | 0,00% | 0,00% |
| 1872 | 1.5.70.6.1 | Instalación Cable de Cobre |  | 1d | 2023-12-19 | 2023-12-20 | 1870 | 377d | 0d | 0,00% | 0,00% | 0,00% | 0,00% |
| 1873 | 1.5.70.6.2 | Varilla COOPER WELD 5/8" x 2.44m. |  | 1d | 2023-12-20 | 2023-12-21 | 1872 | 377d | 0d | 0,00% | 0,00% | 0,00% | 0,00% |
| 1874 | 1.5.70.6.3 | Fin Puesta a Tierra | milestone | 0d | 2023-12-21 | 2023-12-21 | 1872, 1873 | 377d | 62d | 0,00% | 0,00% | 0,00% | 0,00% |
| 1875 | 1.5.70.7 | **MONTAJE ELECTROMECÁNICO** |  | 10d | 2024-02-28 | 2024-03-12 |  | 186d | 0d | 0,00% | 0,00% | 0,00% | 0,00% |
| 1876 | 1.5.70.7.1 | Montaje Mecánico |  | 5d | 2024-02-28 | 2024-03-05 | 1813, 1868 | 186d | 0d | 0,00% | 0,00% | 0,00% | 0,00% |
| 1877 | 1.5.70.7.2 | Montaje Eléctrico |  | 5d | 2024-03-05 | 2024-03-12 | 1876 | 186d | 0d | 0,00% | 0,00% | 0,00% | 0,00% |
| 1878 | 1.5.70.7.3 | Fin montaje Electromecánico | milestone | 0d | 2024-03-12 | 2024-03-12 | 1876, 1877 | 186d | 0d | 0,00% | 0,00% | 0,00% | 0,00% |
| 1879 | 1.5.70.8 | **ALUMBRADO PÚBLICO DE TORRE** |  | 5d | 2024-03-12 | 2024-03-18 |  | 315d | 43d | 0,00% | 0,00% | 0,00% | 0,00% |
| 1880 | 1.5.70.8.1 | Tubería Eléctrica PVC |  | 5d | 2024-03-12 | 2024-03-18 | 1878, 1870, 1868 | 315d | 0d | 0,00% | 0,00% | 0,00% | 0,00% |
| 1881 | 1.5.70.8.2 | Accesorios |  | 1d | 2024-03-12 | 2024-03-13 | 1880SS | 315d | 0d | 0,00% | 0,00% | 0,00% | 0,00% |
| 1882 | 1.5.70.8.3 | Cableado |  | 1d | 2024-03-13 | 2024-03-14 | 1881 | 315d | 0d | 0,00% | 0,00% | 0,00% | 0,00% |
| 1883 | 1.5.70.8.4 | Instalación de A.P. |  | 1d | 2024-03-14 | 2024-03-15 | 1882 | 315d | 0d | 0,00% | 0,00% | 0,00% | 0,00% |
| 1884 | 1.5.70.8.5 | Fin Alumbrado Público de Torre | milestone | 0d | 2024-03-15 | 2024-03-15 | 1883 | 315d | 0d | 0,00% | 0,00% | 0,00% | 0,00% |
| 1885 | 1.5.70.9 | **CERTIFICACIONES RETIE Y RETILAP** |  | 45d | 2024-03-15 | 2024-05-20 |  | 315d | 0d | 0,00% | 0,00% | 0,00% | 0,00% |
| 1886 | 1.5.70.9.1 | Certificación RETIE |  | 45d | 2024-03-15 | 2024-05-20 | 1884, 1874, 1845 | 315d | 0d | 0,00% | 0,00% | 0,00% | 0,00% |
| 1887 | 1.5.70.9.2 | Certificación RETILAP |  | 45d | 2024-03-15 | 2024-05-20 | 1886SS | 315d | 0d | 0,00% | 0,00% | 0,00% | 0,00% |
| 1888 | 1.5.70.9.3 | Fin Certificaciones RETIE Y RETILAP | milestone | 0d | 2024-05-20 | 2024-05-20 | 1887 | 315d | 0d | 0,00% | 0,00% | 0,00% | 0,00% |

| ID | WBS | Task | Type | Duration | Start | Finish | Predecessors | Total slack | Free slack | % Avance Planeado | % avance planeado en costo (texto) | % Completado (décimales) | % Completado en Costo |
| --- | --- | --- | --- | --- | --- | --- | --- | --- | --- | --- | --- | --- | --- |
| 1889 | 1.5.70.10 | **URBANISMO Y PAISAJISMO - PILONAS 21 Y 22** |  | 215d | 2023-12-13 | 2024-10-08 |  | 315d | 0d | 0,00% | 0,00% | 0,00% | 0,00% |
| 1890 | 1.5.70.10.1 | **ESTRUCTURAS DE CONTENCIÓN PARA URBANISMO PILONAS 21 y 22** |  | 102d | 2024-05-21 | 2024-10-08 |  | 315d | 0d | 0,00% | 0,00% | 0,00% | 0,00% |
| 1891 | 1.5.70.10.1.1 | Construcción de muros en concreto reforzado y mampostería estructural. Incluye otros elementos y construcción de filtro de drenaje tras muro. |  | 48d | 2024-05-21 | 2024-07-26 | 1888 | 315d | 0d | 0,00% | 0,00% | 0,00% | 0,00% |
| 1892 | 1.5.70.10.1.2 | Construcción de escaleras y rampas. |  | 40d | 2024-08-15 | 2024-10-08 | 1891FS+14d | 315d | 0d | 0,00% | 0,00% | 0,00% | 0,00% |
| 1893 | 1.5.70.10.1.3 | Fin Estructuras de contención para urbanismo | milestone | 0d | 2024-10-08 | 2024-10-08 | 1892 | 315d |  | 0,00% | 0,00% | 0,00% | 0,00% |
| 1894 | 1.5.70.10.2 | **PAISAJISMO - PILONAS 21 Y 22** |  | 16d | 2023-12-13 | 2024-01-05 |  | 495d |  | 0,00% | 0,00% | 0,00% | 0,00% |
| 1895 | 1.5.70.10.2.1 | Contenedores de raices, Instalación de grama y hiedras. Incluye tierra negra. |  | 1d | 2023-12-13 | 2023-12-14 | 1807, 1868 | 495d | 0d | 0,00% | 0,00% | 0,00% | 0,00% |
| 1896 | 1.5.70.10.2.2 | Jardines horizontales y/o verticales |  | 15d | 2023-12-14 | 2024-01-05 | 1895 | 514d | 32d | 0,00% | 0,00% | 0,00% | 0,00% |
| 1897 | 1.5.70.10.3 | **URBANISMO - PILONAS 21 Y 22** |  | 35d | 2023-12-13 | 2024-02-01 |  | 495d |  | 0,00% | 0,00% | 0,00% | 0,00% |
| 1898 | 1.5.70.10.3.1 | Instalación de prefabricados. Incluye cañuelas, sardineles, bordillos, pisos en adoquín, tabletas y concreto escobeado. |  | 20d | 2023-12-13 | 2024-01-12 | 1895SS | 495d | 0d | 0,00% | 0,00% | 0,00% | 0,00% |
| 1899 | 1.5.70.10.3.2 | Mobiliario y elementos independientes |  | 15d | 2024-01-12 | 2024-02-01 | 1898 | 495d | 13d | 0,00% | 0,00% | 0,00% | 0,00% |
| 1900 | 1.5.70.11 | FIN TORRE 22 | milestone | 0d | 2024-02-19 | 2024-02-19 | 1848, 1849, 1855, 1856, 1896, 1899 | 482d |  | 0,00% | 0,00% | 0,00% | 0,00% |
| 1901 | 1.5.70.12 | Torre 22: Hito de Aprobación Para Pago Preliminares, Demoliones, Excavación y Cimentación | milestone | 0d | 2024-10-08 | 2024-10-08 | 1846, 1853, 1857, 1869, 1889, 1850, 1890 | 315d |  | 0,00% | 0,00% | 0,00% | 0,00% |
| 1902 | 1.5.70.13 | Torre 22: Hito de Aprobación Para Pago Redes | milestone | 0d | 2024-05-20 | 2024-05-20 | 1845, 1871, 1885, 1879 | 417d |  | 0,00% | 0,00% | 0,00% | 0,00% |
| 1903 | 1.5.70.14 | Torre 22: Hito de Aprobación Para Pago Electromecánico | milestone | 0d | 2024-03-12 | 2024-03-12 | 1875 | 465d |  | 0,00% | 0,00% | 0,00% | 0,00% |
| 1904 | 1.5.71 | Entrega de predios por parte de IDU al constructor - Estación Altamira |  | 1d | 2023-07-14 | 2023-07-14 | 47 | 9d | 0d | 0,00% | 0,00% | 0,00% | 0,00% |
| 1905 | 1.5.72 | **PERMISOS** |  | 1d | 2023-07-15 | 2023-07-17 |  | 9d |  | 0,00% | 0,00% | 0,00% | 0,00% |
| 1906 | 1.5.72.1 | Trabajo Nocturno |  | 1d | 2023-07-15 | 2023-07-17 | 1904 | 9d | 0d | 0,00% | 0,00% | 0,00% | 0,00% |
| 1907 | 1.5.72.2 | Silviculturales |  | 1d | 2023-07-15 | 2023-07-17 | 1904 | 9d | 0d | 0,00% | 0,00% | 0,00% | 0,00% |
| 1908 | 1.5.72.3 | Coordinación Acueducto y Alcantarillado |  | 1d | 2023-07-15 | 2023-07-17 | 1904 | 9d | 0d | 0,00% | 0,00% | 0,00% | 0,00% |
| 1909 | 1.5.72.4 | Aprobación PMRRA |  | 1d | 2023-07-15 | 2023-07-17 | 1904 | 9d | 0d | 0,00% | 0,00% | 0,00% | 0,00% |
| 1910 | 1.5.72.5 | Permiso de Uso (Accesibilidad) |  | 1d | 2023-07-15 | 2023-07-17 | 1904 | 9d | 0d | 0,00% | 0,00% | 0,00% | 0,00% |
| 1911 | 1.5.72.6 | Fin Permisos | milestone | 0d | 2023-07-17 | 2023-07-17 | 1906, 1907, 1908, 1909, 1910 | 9d | 0d | 0,00% | 0,00% | 0,00% | 0,00% |
| 1912 | 1.5.73 | **3. ESTACIÓN DE RETORNO Y PARKING - ALTAMIRA** |  | 398d | 2023-07-17 | 2025-01-23 |  | 9d |  | 0,00% | 0,00% | 0,00% | 0,00% |
| 1913 | 1.5.73.1 | **PRELIMINARES DE OBRA, MOVIMIENTO DE TIERRAS** |  | 15d | 2023-07-17 | 2023-08-08 |  | 9d |  | 0,00% | 0,00% | 0,00% | 0,00% |
| 1914 | 1.5.73.1.1 | Replanteo General |  | 3d | 2023-07-17 | 2023-07-21 | 1904, 1911 | 9d | 0d | 0,00% | 0,00% | 0,00% | 0,00% |
| 1915 | 1.5.73.1.2 | Cerramiento y Señalización |  | 2d | 2023-07-21 | 2023-07-25 | 1914 | 9d | 0d | 0,00% | 0,00% | 0,00% | 0,00% |
| 1916 | 1.5.73.1.3 | Tala de Especies |  | 3d | 2023-07-25 | 2023-07-28 | 1915 | 9d | 0d | 0,00% | 0,00% | 0,00% | 0,00% |
| 1917 | 1.5.73.1.4 | Campamento |  | 3d | 2023-07-28 | 2023-08-01 | 1916 | 9d | 0d | 0,00% | 0,00% | 0,00% | 0,00% |
| 1918 | 1.5.73.1.5 | Descapote a Maquina en Material Común, |  | 4d | 2023-08-02 | 2023-08-08 | 1917 | 9d | 0d | 0,00% | 0,00% | 0,00% | 0,00% |

| ID | WBS | Task | Duration | Start | Finish | Predecessors | Total slack | Free slack | % Avance Planeado | % avance planeado en costo (texto) | % Completado (décimales) | % Completado en Costo |
| --- | --- | --- | --- | --- | --- | --- | --- | --- | --- | --- | --- | --- |
| 1919 | 1.5.73.2 | **DEMOLICIONES** | 12d | 2023-08-08 | 2023-08-24 |  | 9d |  | 0,00% | 0,00% | 0,00% | 0,00% |
| 1920 | 1.5.73.2.1 | Demolición estructuras de concreto | 12d | 2023-08-08 | 2023-08-24 | 1918 | 9d | 0d | 0,00% | 0,00% | 0,00% | 0,00% |
| 1921 | 1.5.73.3 | **MOVIMIENTO DE TIERRAS** | 28d | 2023-08-08 | 2023-09-14 |  | 290d | 80d | 0,00% | 0,00% | 0,00% | 0,00% |
| 1922 | 1.5.73.3.1 | Excavación Mecánica En Material Común | 28d | 2023-08-08 | 2023-09-14 | 1920SS | 594d | 0d | 0,00% | 0,00% | 0,00% | 0,00% |
| 1923 | 1.5.73.3.2 | Nivelación y Compactación de Subrasante | 3d | 2023-08-25 | 2023-08-29 | 1920 | 278d | 250d | 0,00% | 0,00% | 0,00% | 0,00% |
| 1924 | 1.5.73.3.3 | Transporte y Disposición Final de Escombros en Sitio Autorizado | 28d | 2023-08-08 | 2023-09-14 | 1922SS | 594d | 355d | 0,00% | 0,00% | 0,00% | 0,00% |
| 1925 | 1.5.73.4 | **CIMENTACIÓN - MASTILES ESTACIÓN DE RETORNO ALTAMIRA** | 93d | 2023-08-08 | 2023-12-14 |  | 9d |  | 0,00% | 0,00% | 0,00% | 0,00% |
| 1926 | 1.5.73.4.1 | **CONSTRUCCIÓN PILOTES** | 52d | 2023-08-08 | 2023-10-18 |  | 9d |  | 0,00% | 0,00% | 0,00% | 0,00% |
| 1927 | 1.5.73.4.1.1 | Excavación mecánica para pilotes | 24d | 2023-08-08 | 2023-09-09 | 1920SS | 9d | 0d | 0,00% | 0,00% | 0,00% | 0,00% |
| 1928 | 1.5.73.4.1.2 | Transporte y Disposición Final de Escombros en Sitio Autorizado | 24d | 2023-08-08 | 2023-09-09 | 1927FF | 269d | 241d | 0,00% | 0,00% | 0,00% | 0,00% |
| 1929 | 1.5.73.4.1.3 | Acero de Refuerzo | 24d | 2023-09-12 | 2023-10-12 | 1927SS+1d, 1940SS+1d | 101d | 0d | 0,00% | 0,00% | 0,00% | 0,00% |
| 1930 | 1.5.73.4.1.4 | Concreto | 12d | 2023-09-27 | 2023-10-12 | 1929FF | 101d | 0d | 0,00% | 0,00% | 0,00% | 0,00% |
| 1931 | 1.5.73.4.1.5 | Descabece de Pilotes | 7d | 2023-10-07 | 2023-10-18 | 1930SS+8d | 241d | 213d | 0,00% | 0,00% | 0,00% | 0,00% |
| 1932 | 1.5.73.4.2 | **CONSTRUCCIÓN DADOS DE CIMENTACIÓN** | 14d | 2023-10-12 | 2023-11-01 |  | 101d |  | 0,00% | 0,00% | 0,00% | 0,00% |
| 1933 | 1.5.73.4.2.1 | Excavación mecánica para dados | 10d | 2023-10-12 | 2023-10-26 | 1930 | 101d | 0d | 0,00% | 0,00% | 0,00% | 0,00% |
| 1934 | 1.5.73.4.2.2 | Transporte y Disposición Final de Escombros en Sitio Autorizado | 10d | 2023-10-12 | 2023-10-26 | 1933FF | 234d | 206d | 0,00% | 0,00% | 0,00% | 0,00% |
| 1935 | 1.5.73.4.2.3 | Acero de Refuerzo | 10d | 2023-10-17 | 2023-10-30 | 1933SS+2d | 101d | 0d | 0,00% | 0,00% | 0,00% | 0,00% |
| 1936 | 1.5.73.4.2.4 | Concreto | 10d | 2023-10-19 | 2023-11-01 | 1935SS+2d | 101d | 0d | 0,00% | 0,00% | 0,00% | 0,00% |
| 1937 | 1.5.73.4.3 | Vigas de Cimentación en Concreto | 24d | 2023-11-10 | 2023-12-14 | 1936SS+16d | 101d | 9d | 0,00% | 0,00% | 0,00% | 0,00% |
| 1938 | 1.5.73.5 | **CIMENTACIÓN - ESTACIÓN DE RETORNO Y PARKING ALTAMIRA** | 80d | 2023-09-07 | 2023-12-27 |  | 11d | 6d | 0,00% | 0,00% | 0,00% | 0,00% |
| 1939 | 1.5.73.5.1 | **CONSTRUCCIÓN PILOTES** | 75d | 2023-09-07 | 2023-12-20 |  | 11d |  | 0,00% | 0,00% | 0,00% | 0,00% |
| 1940 | 1.5.73.5.1.1 | Excavación mecánica para pilotes | 54d | 2023-09-11 | 2023-11-23 | 1927 | 9d | 0d | 0,00% | 0,00% | 0,00% | 0,00% |
| 1941 | 1.5.73.5.1.2 | Transporte y Disposición Final de Escombros en Sitio Autorizado | 56d | 2023-09-07 | 2023-11-23 | 1940FF | 215d | 187d | 0,00% | 0,00% | 0,00% | 0,00% |
| 1942 | 1.5.73.5.1.3 | Acero de Refuerzo | 56d | 2023-09-13 | 2023-11-29 | 1940SS+2d | 9d | 0d | 0,00% | 0,00% | 0,00% | 0,00% |
| 1943 | 1.5.73.5.1.4 | Concreto | 56d | 2023-09-13 | 2023-11-29 | 1942SS | 196d | 0d | 0,00% | 0,00% | 0,00% | 0,00% |
| 1944 | 1.5.73.5.1.5 | Descabece de Pilotes | 7d | 2023-12-11 | 2023-12-20 | 1943FS+8d | 196d | 168d | 0,00% | 0,00% | 0,00% | 0,00% |

| ID | WBS | Task | Duration | Start | Finish | Predecessors | Total slack | Free slack | % Avance Planeado | % avance planeado en costo (texto) | % Completado (décimales) | % Completado en Costo |
| --- | --- | --- | --- | --- | --- | --- | --- | --- | --- | --- | --- | --- |
| 1945 | 1.5.73.5.2 | **CONSTRUCCIÓN MURO PANTALLA PRE-EXCAVADO** | 21d | 2023-10-11 | 2023-11-10 |  | 224d |  | 0,00% | 0,00% | 0,00% | 0,00% |
| 1946 | 1.5.73.5.2.1 | Excavación mecánica para muro | 15d | 2023-10-11 | 2023-11-01 | 985 | 224d | 0d | 0,00% | 0,00% | 0,00% | 0,00% |
| 1947 | 1.5.73.5.2.2 | Transporte y Disposición Final de Escombros en Sitio Autorizado | 15d | 2023-10-11 | 2023-11-01 | 1946FF | 230d | 202d | 0,00% | 0,00% | 0,00% | 0,00% |
| 1948 | 1.5.73.5.2.3 | Acero de Refuerzo | 15d | 2023-10-20 | 2023-11-10 | 1946SS+6d | 224d | 0d | 0,00% | 0,00% | 0,00% | 0,00% |
| 1949 | 1.5.73.5.2.4 | Concreto | 15d | 2023-10-20 | 2023-11-10 | 1948SS | 224d | 196d | 0,00% | 0,00% | 0,00% | 0,00% |
| 1950 | 1.5.73.5.3 | **CONSTRUCCIÓN DADOS DE CIMENTACIÓN** | 28d | 2023-11-18 | 2023-12-27 |  | 9d |  | 0,00% | 0,00% | 0,00% | 0,00% |
| 1951 | 1.5.73.5.3.1 | Excavación mecánica para dados | 7d | 2023-11-20 | 2023-11-29 | 1943FF | 204d | 0d | 0,00% | 0,00% | 0,00% | 0,00% |
| 1952 | 1.5.73.5.3.2 | Transporte y Disposición Final de Escombros en Sitio Autorizado | 7d | 2023-11-29 | 2023-12-07 | 1951 | 204d | 176d | 0,00% | 0,00% | 0,00% | 0,00% |
| 1953 | 1.5.73.5.3.3 | Acero de Refuerzo | 7d | 2023-11-18 | 2023-11-28 | 1942FS-8d | 9d | 0d | 0,00% | 0,00% | 0,00% | 0,00% |
| 1954 | 1.5.73.5.3.4 | Concreto | 7d | 2023-11-18 | 2023-11-28 | 1953SS | 9d | 0d | 0,00% | 0,00% | 0,00% | 0,00% |
| 1955 | 1.5.73.5.3.5 | Vigas de Cimentación en Concreto | 21d | 2023-11-28 | 2023-12-27 | 1954 | 9d | 0d | 0,00% | 0,00% | 0,00% | 0,00% |
| 1956 | 1.5.73.6 | **RELLENOS** | 12d | 2023-12-19 | 2024-01-05 |  | 9d | 0d | 0,00% | 0,00% | 0,00% | 0,00% |
| 1957 | 1.5.73.6.1 | Relleno de Material Seleccionado | 12d | 2023-12-19 | 2024-01-05 | 1955SS+15d | 9d | 0d | 0,00% | 0,00% | 0,00% | 0,00% |
| 1958 | 1.5.73.7 | **PUESTA A TIERRA** | 12d | 2024-01-05 | 2024-01-23 |  | 502d | 223d | 0,00% | 0,00% | 0,00% | 0,00% |
| 1959 | 1.5.73.7.1 | Instalación Cable de Cobre | 12d | 2024-01-05 | 2024-01-23 | 1957, 1955, 1937 | 502d | 0d | 0,00% | 0,00% | 0,00% | 0,00% |
| 1960 | 1.5.73.7.2 | Varilla COOPER WELD 5/8" x 2.44m. | 12d | 2024-01-05 | 2024-01-23 | 1959SS | 502d | 263d | 0,00% | 0,00% | 0,00% | 0,00% |
| 1961 | 1.5.73.8 | **ESTRUCTURA ESTACIÓN DE RETORNO ALTAMIRA** | 184d | 2023-11-28 | 2024-08-13 |  | 28d |  | 0,00% | 0,00% | 0,00% | 0,00% |
| 1962 | 1.5.73.8.1 | **ESTRUCTURA MÁSTIL** | 41d | 2023-11-28 | 2024-01-25 |  | 171d |  | 0,00% | 0,00% | 0,00% | 0,00% |
| 1963 | 1.5.73.8.1.1 | Acero de Refuerzo Mástil | 36d | 2023-11-28 | 2024-01-18 | 1954 | 171d | 0d | 0,00% | 0,00% | 0,00% | 0,00% |
| 1964 | 1.5.73.8.1.2 | Concreto para Mástil | 36d | 2023-12-05 | 2024-01-25 | 1963SS+5d | 171d | 143d | 0,00% | 0,00% | 0,00% | 0,00% |
| 1965 | 1.5.73.8.2 | **ESTRUCTURA PLACA CONTRAPISO - NIVEL DE EQUIPOS Y NIVEL DE DISPONIBLE** | 14d | 2024-01-05 | 2024-01-25 |  | 9d |  | 0,00% | 0,00% | 0,00% | 0,00% |
| 1966 | 1.5.73.8.2.1 | Acero de Refuerzo | 12d | 2024-01-05 | 2024-01-23 | 1957 | 9d | 0d | 0,00% | 0,00% | 0,00% | 0,00% |
| 1967 | 1.5.73.8.2.2 | Concreto | 12d | 2024-01-10 | 2024-01-25 | 1966SS+2d | 9d | 0d | 0,00% | 0,00% | 0,00% | 0,00% |
| 1968 | 1.5.73.8.3 | **COLUMNAS NIVEL DE EQUIPOS** | 21d | 2024-01-19 | 2024-02-15 |  | 15d |  | 0,00% | 0,00% | 0,00% | 0,00% |
| 1969 | 1.5.73.8.3.1 | Acero de Refuerzo | 18d | 2024-01-19 | 2024-02-12 | 1967SS+7d | 15d | 0d | 0,00% | 0,00% | 0,00% | 0,00% |
| 1970 | 1.5.73.8.3.2 | Concreto para Columnas | 18d | 2024-01-23 | 2024-02-15 | 1969SS+3d | 15d | 0d | 0,00% | 0,00% | 0,00% | 0,00% |

| ID | WBS | Task | Duration | Start | Finish | Predecessors | Total slack | Free slack | % Avance Planeado | % avance planeado en costo (texto) | % Completado (décimales) | % Completado en Costo |
| --- | --- | --- | --- | --- | --- | --- | --- | --- | --- | --- | --- | --- |
| 1971 | 1.5.73.8.4 | **ESTRUCTURA PLACA ENTREPISO DEL DISPONIBLE** | 40d | 2024-01-25 | 2024-03-18 |  | 9d |  | 0,00% | 0,00% | 0,00% | 0,00% |
| 1972 | 1.5.73.8.4.1 | Encofrado y Acero de Refuerzo | 25d | 2024-01-25 | 2024-02-27 | 1967, 1957 | 9d | 0d | 0,00% | 0,00% | 0,00% | 0,00% |
| 1973 | 1.5.73.8.4.2 | Concreto | 18d | 2024-02-23 | 2024-03-18 | 1970, 1972FS-3d | 9d | 0d | 0,00% | 0,00% | 0,00% | 0,00% |
| 1974 | 1.5.73.8.5 | **COLUMNAS DEL DISPONBLE HASTA MEZANINE Y HASTA PLATAFORMA DE ABORDAJE** | 30d | 2024-03-05 | 2024-04-17 |  | 28d |  | 0,00% | 0,00% | 0,00% | 0,00% |
| 1975 | 1.5.73.8.5.1 | Encofrado y Acero de Refuerzo | 28d | 2024-03-05 | 2024-04-15 | 1973SS+8d | 28d | 0d | 0,00% | 0,00% | 0,00% | 0,00% |
| 1976 | 1.5.73.8.5.2 | Concreto para Columnas | 25d | 2024-03-12 | 2024-04-17 | 1975SS+5d | 28d | 0d | 0,00% | 0,00% | 0,00% | 0,00% |
| 1977 | 1.5.73.8.6 | **ESTRUCTURA PLACA ENTREPISO MEZANINE** | 21d | 2024-04-11 | 2024-05-09 |  | 9d |  | 0,00% | 0,00% | 0,00% | 0,00% |
| 1978 | 1.5.73.8.6.1 | Encofrado y Acero de Refuerzo | 12d | 2024-04-11 | 2024-04-26 | 1973FS+15d | 9d | 0d | 0,00% | 0,00% | 0,00% | 0,00% |
| 1979 | 1.5.73.8.6.2 | Concreto | 9d | 2024-04-26 | 2024-05-09 | 1978 | 9d | 0d | 0,00% | 0,00% | 0,00% | 0,00% |
| 1980 | 1.5.73.8.7 | **COLUMNAS MEZANINE** | 13d | 2024-04-04 | 2024-04-22 |  | 28d |  | 0,00% | 0,00% | 0,00% | 0,00% |
| 1981 | 1.5.73.8.7.1 | Acero de Refuerzo | 10d | 2024-04-04 | 2024-04-17 | 1976SS+15d | 28d | 0d | 0,00% | 0,00% | 0,00% | 0,00% |
| 1982 | 1.5.73.8.7.2 | Concreto para Columnas | 8d | 2024-04-11 | 2024-04-22 | 1981SS+5d | 28d | 0d | 0,00% | 0,00% | 0,00% | 0,00% |
| 1983 | 1.5.73.8.8 | **ESTRUCTURA PLACA ENTREPISO PLATAFORMA DE ABORDAJE Y PARKING DE CABINAS** | 25d | 2024-04-22 | 2024-05-27 |  | 28d |  | 0,00% | 0,00% | 0,00% | 0,00% |
| 1984 | 1.5.73.8.8.1 | Acero de Refuerzo | 25d | 2024-04-22 | 2024-05-27 | 1976SS+8d, 1982SS+8d | 28d | 0d | 0,00% | 0,00% | 0,00% | 0,00% |
| 1985 | 1.5.73.8.8.2 | Concreto | 18d | 2024-04-29 | 2024-05-23 | 1984SS+5d | 28d | 0d | 0,00% | 0,00% | 0,00% | 0,00% |
| 1986 | 1.5.73.8.9 | **COLUMNAS PLATAFORMA DE ABORDAJE Y PARKING DE CABINAS A CUBIERTA** | 21d | 2024-05-21 | 2024-06-19 |  | 28d |  | 0,00% | 0,00% | 0,00% | 0,00% |
| 1987 | 1.5.73.8.9.1 | Acero de Refuerzo | 16d | 2024-05-21 | 2024-06-12 | 1985SS+15d | 28d | 0d | 0,00% | 0,00% | 0,00% | 0,00% |
| 1988 | 1.5.73.8.9.2 | Concreto para Columnas | 16d | 2024-05-27 | 2024-06-19 | 1987SS+5d | 28d | 0d | 0,00% | 0,00% | 0,00% | 0,00% |
| 1989 | 1.5.73.8.10 | **ESTRUCTURA VIGAS DE CUBIERTA** | 18d | 2024-06-12 | 2024-07-05 |  | 28d |  | 0,00% | 0,00% | 0,00% | 0,00% |
| 1990 | 1.5.73.8.10.1 | Acero de Refuerzo | 13d | 2024-06-12 | 2024-06-28 | 1988SS+10d | 28d | 0d | 0,00% | 0,00% | 0,00% | 0,00% |
| 1991 | 1.5.73.8.10.2 | Concreto | 13d | 2024-06-18 | 2024-07-05 | 1990SS+5d | 28d | 0d | 0,00% | 0,00% | 0,00% | 0,00% |
| 1992 | 1.5.73.8.11 | **ESCALERAS** | 18d | 2024-07-06 | 2024-07-30 |  | 37d |  | 0,00% | 0,00% | 0,00% | 0,00% |
| 1993 | 1.5.73.8.11.1 | Acero de Refuerzo | 13d | 2024-07-06 | 2024-07-24 | 1991 | 37d | 0d | 0,00% | 0,00% | 0,00% | 0,00% |
| 1994 | 1.5.73.8.11.2 | Concreto para Escaleras | 13d | 2024-07-12 | 2024-07-30 | 1993SS+5d | 37d | 9d | 0,00% | 0,00% | 0,00% | 0,00% |

| ID | WBS | Task | Type | Duration | Start | Finish | Predecessors | Total slack | Free slack | % Avance Planeado | % avance planeado en costo (texto) | % Completado (décimales) | % Completado en Costo |
| --- | --- | --- | --- | --- | --- | --- | --- | --- | --- | --- | --- | --- | --- |
| 1995 | 1.5.73.8.12 | **ACERO ESTRUCTURAL** |  | 27d | 2024-07-06 | 2024-08-13 |  | 28d |  | 0,00% | 0,00% | 0,00% | 0,00% |
| 1996 | 1.5.73.8.12.1 | **CUBIERTA** |  | 27d | 2024-07-06 | 2024-08-13 |  | 28d |  | 0,00% | 0,00% | 0,00% | 0,00% |
| 1997 | 1.5.73.8.12.1.1 | Acero ASTM |  | 27d | 2024-07-06 | 2024-08-13 | 1991 | 28d | 0d | 0,00% | 0,00% | 0,00% | 0,00% |
| 1998 | 1.5.73.8.13 | Fin Estructura Estación | milestone | 0d | 2024-08-13 | 2024-08-13 | 1997, 1994, 1923, 1941, 1944, 1947, 1949, 1951, 1952, 1964, 1928, 1931, 1934 | 28d | 0d | 0,00% | 0,00% | 0,00% | 0,00% |
| 1999 | 1.5.73.9 | **SUMINISTRO Y MONTAJE COMPONENTE ELECTROMECÁNICO** |  | 69d | 2024-08-13 | 2024-11-15 |  | 9d | 0d | 0,00% | 0,00% | 0,00% | 0,00% |
| 2000 | 1.5.73.9.1 | Montaje Mecánico |  | 50d | 2024-08-13 | 2024-10-19 | 15SS+60d, 1998 | 28d | 19d | 0,00% | 0,00% | 0,00% | 0,00% |
| 2001 | 1.5.73.9.2 | Montaje Eléctrico |  | 35d | 2024-09-27 | 2024-11-15 | 2000FS-35d, 2063, 2062 | 9d | 0d | 0,00% | 0,00% | 0,00% | 0,00% |
| 2002 | 1.5.73.9.3 | Fin de montaje Electromecánico | milestone | 0d | 2024-11-15 | 2024-11-15 | 2000, 2001 | 9d | 0d | 0,00% | 0,00% | 0,00% | 0,00% |
| 2003 | 1.5.73.10 | **CUBIERTA** |  | 39d | 2024-08-13 | 2024-10-03 |  | 247d | 0d | 0,00% | 0,00% | 0,00% | 0,00% |
| 2004 | 1.5.73.10.1 | **PLATAFORMA DE ABORDAJE** |  | 39d | 2024-08-13 | 2024-10-03 |  | 247d |  | 0,00% | 0,00% | 0,00% | 0,00% |
| 2005 | 1.5.73.10.1.1 | Cubierta Lisa Tipo Sándwich Deck en Aluzinc |  | 39d | 2024-08-13 | 2024-10-03 | 1997, 1988 | 247d | 0d | 0,00% | 0,00% | 0,00% | 0,00% |
| 2006 | 1.5.73.10.2 | Fin Instalación de Cubierta para Plataforma de Abordaje | milestone | 0d | 2024-10-03 | 2024-10-03 | 2005 | 247d | 0d | 0,00% | 0,00% | 0,00% | 0,00% |
| 2007 | 1.5.73.11 | **REDES HIDRÁULICAS Y SANITARIAS** |  | 117d | 2024-01-04 | 2024-06-17 |  | 337d | 119d | 0,00% | 0,00% | 0,00% | 0,00% |
| 2008 | 1.5.73.11.1 | **REDES INTERNAS** |  | 114d | 2024-01-10 | 2024-06-17 |  | 334d |  | 0,00% | 0,00% | 0,00% | 0,00% |
| 2009 | 1.5.73.11.1.1 | **SUBNIVEL S1** |  | 18d | 2024-01-10 | 2024-02-02 |  | 334d |  | 0,00% | 0,00% | 0,00% | 0,00% |
| 2010 | 1.5.73.11.1.1.1 | Tubería PVC Sanitaria |  | 18d | 2024-01-10 | 2024-02-02 | 1967SS | 334d | 0d | 0,00% | 0,00% | 0,00% | 0,00% |
| 2011 | 1.5.73.11.1.1.2 | Tubería PVC RDE |  | 18d | 2024-01-10 | 2024-02-02 | 2010SS | 494d | 96d | 0,00% | 0,00% | 0,00% | 0,00% |
| 2012 | 1.5.73.11.1.1.3 | Accesorios |  | 18d | 2024-01-10 | 2024-02-02 | 2010SS | 494d | 96d | 0,00% | 0,00% | 0,00% | 0,00% |
| 2013 | 1.5.73.11.1.2 | **PLATAFORMA DE ABORDAJE** |  | 13d | 2024-02-23 | 2024-03-12 |  | 367d |  | 0,00% | 0,00% | 0,00% | 0,00% |
| 2014 | 1.5.73.11.1.2.1 | Tubería PVC Sanitaria |  | 13d | 2024-02-23 | 2024-03-12 | 1973SS | 465d | 67d | 0,00% | 0,00% | 0,00% | 0,00% |
| 2015 | 1.5.73.11.1.2.2 | Tubería PVC RDE |  | 13d | 2024-02-23 | 2024-03-12 | 1973SS | 465d | 67d | 0,00% | 0,00% | 0,00% | 0,00% |
| 2016 | 1.5.73.11.1.2.3 | Accesorios |  | 13d | 2024-02-23 | 2024-03-12 | 1973SS | 367d | 0d | 0,00% | 0,00% | 0,00% | 0,00% |
| 2017 | 1.5.73.11.1.3 | **PARKING, CUARTOS OPERATIVOS Y TÉCNICOS** |  | 67d | 2024-03-12 | 2024-06-17 |  | 367d |  | 0,00% | 0,00% | 0,00% | 0,00% |
| 2018 | 1.5.73.11.1.3.1 | Tubería PVC Sanitaria |  | 62d | 2024-03-12 | 2024-06-08 | 2016 | 367d | 0d | 0,00% | 0,00% | 0,00% | 0,00% |
| 2019 | 1.5.73.11.1.3.2 | Tubería PVC RDE |  | 67d | 2024-03-12 | 2024-06-17 | 2018SS | 398d | 0d | 0,00% | 0,00% | 0,00% | 0,00% |
| 2020 | 1.5.73.11.1.3.3 | Accesorios |  | 62d | 2024-03-12 | 2024-06-08 | 2018SS | 367d | 46d | 0,00% | 0,00% | 0,00% | 0,00% |

| ID | WBS | Task | Type | Duration | Start | Finish | Predecessors | Total slack | Free slack | % Avance Planeado | % avance planeado en costo (texto) | % Completado (décimales) | % Completado en Costo |
| --- | --- | --- | --- | --- | --- | --- | --- | --- | --- | --- | --- | --- | --- |
| 2021 | 1.5.73.11.2 | **REDES EXTERNAS** |  | 99d | 2024-01-04 | 2024-05-21 |  | 416d |  | 0,00% | 0,00% | 0,00% | 0,00% |
| 2022 | 1.5.73.11.2.1 | **Redes de Acueducto** |  | 29d | 2024-01-04 | 2024-02-13 |  | 486d |  | 0,00% | 0,00% | 0,00% | 0,00% |
| 2023 | 1.5.73.11.2.1.1 | Excavación manual para redes |  | 25d | 2024-01-04 | 2024-02-07 | 2122SS+5d | 486d | 0d | 0,00% | 0,00% | 0,00% | 0,00% |
| 2024 | 1.5.73.11.2.1.2 | Instalación de Tubería, incluye accesorios. |  | 25d | 2024-01-09 | 2024-02-09 | 2023SS+2d | 486d | 0d | 0,00% | 0,00% | 0,00% | 0,00% |
| 2025 | 1.5.73.11.2.1.3 | Rellenos para redes |  | 25d | 2024-01-11 | 2024-02-13 | 2024SS+2d | 486d | 247d | 0,00% | 0,00% | 0,00% | 0,00% |
| 2026 | 1.5.73.11.2.2 | **Redes de Alcantarillado** |  | 29d | 2024-04-11 | 2024-05-21 |  | 363d |  | 0,00% | 0,00% | 0,00% | 0,00% |
| 2027 | 1.5.73.11.2.2.1 | Excavación manual para redes |  | 25d | 2024-04-11 | 2024-05-16 | 2130SS | 363d | 0d | 0,00% | 0,00% | 0,00% | 0,00% |
| 2028 | 1.5.73.11.2.2.2 | Instalación de Tubería, incluye accesorios. |  | 25d | 2024-04-13 | 2024-05-18 | 2027SS+2d | 363d | 0d | 0,00% | 0,00% | 0,00% | 0,00% |
| 2029 | 1.5.73.11.2.2.3 | Rellenos para redes |  | 25d | 2024-04-16 | 2024-05-21 | 2028SS+2d | 363d | 0d | 0,00% | 0,00% | 0,00% | 0,00% |
| 2030 | 1.5.73.11.2.2.4 | Instalación de canal monolítico |  | 5d | 2024-05-10 | 2024-05-18 | 2028FF | 418d | 20d | 0,00% | 0,00% | 0,00% | 0,00% |
| 2031 | 1.5.73.11.3 | FIN REDES HIDRÁULICAS Y SANITARIAS | milestone | 0d | 2024-06-17 | 2024-06-17 | 2011, 2012, 2014, 2015, 2019, 2030 | 398d |  | 0,00% | 0,00% | 0,00% | 0,00% |
| 2032 | 1.5.73.12 | **REDES ELÉCTRICAS VOZ Y DATOS** |  | 221d | 2024-01-25 | 2024-11-28 |  | 66d | 0d | 0,00% | 0,00% | 0,00% | 0,00% |
| 2033 | 1.5.73.12.1 | **REDES INTERNAS** |  | 147d | 2024-01-25 | 2024-08-17 |  | 76d |  | 0,00% | 0,00% | 0,00% | 0,00% |
| 2034 | 1.5.73.12.1.1 | **SUBNIVEL S1** |  | 47d | 2024-01-25 | 2024-04-01 |  | 138d |  | 0,00% | 0,00% | 0,00% | 0,00% |
| 2035 | 1.5.73.12.1.1.1 | Tubería Conduit |  | 18d | 2024-01-25 | 2024-02-19 | 1967 | 138d | 0d | 0,00% | 0,00% | 0,00% | 0,00% |
| 2036 | 1.5.73.12.1.1.2 | Tubería Galvanizada |  | 18d | 2024-01-25 | 2024-02-19 | 2035SS | 138d | 0d | 0,00% | 0,00% | 0,00% | 0,00% |
| 2037 | 1.5.73.12.1.1.3 | Accesorios |  | 18d | 2024-01-25 | 2024-02-19 | 2035SS, 2036SS | 453d | 0d | 0,00% | 0,00% | 0,00% | 0,00% |
| 2038 | 1.5.73.12.1.1.4 | Cableado |  | 22d | 2024-02-19 | 2024-03-18 | 2037 | 453d | 0d | 0,00% | 0,00% | 0,00% | 0,00% |
| 2039 | 1.5.73.12.1.1.5 | Instalación de Aparatos Electricos |  | 7d | 2024-03-19 | 2024-04-01 | 2038 | 453d | 174d | 0,00% | 0,00% | 0,00% | 0,00% |
| 2040 | 1.5.73.12.1.2 | **PLATAFORMA DE ABORDAJE** |  | 42d | 2024-02-23 | 2024-04-23 |  | 121d |  | 0,00% | 0,00% | 0,00% | 0,00% |
| 2041 | 1.5.73.12.1.2.1 | Tubería Conduit |  | 13d | 2024-02-23 | 2024-03-12 | 1973SS | 121d | 0d | 0,00% | 0,00% | 0,00% | 0,00% |
| 2042 | 1.5.73.12.1.2.2 | Tubería Galvanizada |  | 13d | 2024-02-23 | 2024-03-12 | 2041SS | 121d | 0d | 0,00% | 0,00% | 0,00% | 0,00% |
| 2043 | 1.5.73.12.1.2.3 | Accesorios |  | 13d | 2024-02-23 | 2024-03-12 | 2041SS, 2042SS | 436d | 0d | 0,00% | 0,00% | 0,00% | 0,00% |
| 2044 | 1.5.73.12.1.2.4 | Cableado |  | 22d | 2024-03-12 | 2024-04-12 | 2043 | 436d | 0d | 0,00% | 0,00% | 0,00% | 0,00% |
| 2045 | 1.5.73.12.1.2.5 | Instalación de Aparatos Electricos |  | 7d | 2024-04-13 | 2024-04-23 | 2044 | 436d | 157d | 0,00% | 0,00% | 0,00% | 0,00% |

| ID | WBS | Task | Type | Duration | Start | Finish | Predecessors | Total slack | Free slack | % Avance Planeado | % avance planeado en costo (texto) | % Completado (décimales) | % Completado en Costo |
| --- | --- | --- | --- | --- | --- | --- | --- | --- | --- | --- | --- | --- | --- |
| 2046 | 1.5.73.12.1.3 | **PARKING, CUARTOS OPERATIVOS Y TÉCNICOS** |  | 80d | 2024-04-26 | 2024-08-17 |  | 9d |  | 0,00% | 0,00% | 0,00% | 0,00% |
| 2047 | 1.5.73.12.1.3.1 | Tubería Conduit |  | 80d | 2024-04-26 | 2024-08-17 | 1979SS | 9d | 0d | 0,00% | 0,00% | 0,00% | 0,00% |
| 2048 | 1.5.73.12.1.3.2 | Tubería Galvanizada |  | 80d | 2024-04-26 | 2024-08-17 | 2047SS | 9d | 0d | 0,00% | 0,00% | 0,00% | 0,00% |
| 2049 | 1.5.73.12.1.3.3 | Accesorios |  | 13d | 2024-04-26 | 2024-05-16 | 2047SS, 2048SS | 391d | 0d | 0,00% | 0,00% | 0,00% | 0,00% |
| 2050 | 1.5.73.12.1.3.4 | Cableado |  | 22d | 2024-05-16 | 2024-06-17 | 2049 | 391d | 0d | 0,00% | 0,00% | 0,00% | 0,00% |
| 2051 | 1.5.73.12.1.3.5 | Instalación de Aparatos Electricos |  | 7d | 2024-06-17 | 2024-06-26 | 2050 | 391d | 112d | 0,00% | 0,00% | 0,00% | 0,00% |
| 2052 | 1.5.73.12.2 | **APANTALLAMIENTO** |  | 39d | 2024-10-04 | 2024-11-28 |  | 279d |  | 0,00% | 0,00% | 0,00% | 0,00% |
| 2053 | 1.5.73.12.2.1 | Pararrayos Tipo Punta de Franklin |  | 39d | 2024-10-04 | 2024-11-28 | 2006 | 279d | 0d | 0,00% | 0,00% | 0,00% | 0,00% |
| 2054 | 1.5.73.12.2.2 | Cable De Cobra Desnudo |  | 39d | 2024-10-04 | 2024-11-28 | 2053SS | 279d | 0d | 0,00% | 0,00% | 0,00% | 0,00% |
| 2055 | 1.5.73.12.3 | **REDES EXTERNAS** |  | 170d | 2024-02-05 | 2024-09-27 |  | 59d |  | 0,00% | 0,00% | 0,00% | 0,00% |
| 2056 | 1.5.73.12.3.1 | **ILUMINACIÓN EXTERIOR** |  | 86d | 2024-02-05 | 2024-06-04 |  | 92d |  | 0,00% | 0,00% | 0,00% | 0,00% |
| 2057 | 1.5.73.12.3.1.1 | Tubería Eléctrica PVC |  | 57d | 2024-02-05 | 2024-04-23 | 2122 | 92d | 0d | 0,00% | 0,00% | 0,00% | 0,00% |
| 2058 | 1.5.73.12.3.1.2 | Accesorios |  | 57d | 2024-02-05 | 2024-04-23 | 2057SS | 407d | 0d | 0,00% | 0,00% | 0,00% | 0,00% |
| 2059 | 1.5.73.12.3.1.3 | Cableado |  | 22d | 2024-04-23 | 2024-05-23 | 2058 | 407d | 0d | 0,00% | 0,00% | 0,00% | 0,00% |
| 2060 | 1.5.73.12.3.1.4 | Instalación de A.P. |  | 7d | 2024-05-24 | 2024-06-04 | 2059 | 407d | 128d | 0,00% | 0,00% | 0,00% | 0,00% |
| 2061 | 1.5.73.12.3.2 | **SISTEMA DE ALIMENTACIÓN Y POTENCIA** |  | 166d | 2024-02-09 | 2024-09-27 |  | 9d |  | 0,00% | 0,00% | 0,00% | 0,00% |
| 2062 | 1.5.73.12.3.2.1 | Suministro de Subestación Eléctrica |  | 90d | 2024-02-09 | 2024-06-14 | 49FS+150d | 55d | 46d | 0,00% | 0,00% | 0,00% | 0,00% |
| 2063 | 1.5.73.12.3.2.2 | Montaje Subestación Eléctrica |  | 30d | 2024-08-20 | 2024-09-27 | 2057, 2048, 2100, 2042, 2036, 2062 | 9d | 0d | 0,00% | 0,00% | 0,00% | 0,00% |
| 2064 | 1.5.73.12.4 | FIN REDES ELÉCTRICAS VOZ Y DATOS | milestone | 0d | 2024-11-28 | 2024-11-28 | 2039, 2045, 2051, 2054, 2060 | 279d |  | 0,00% | 0,00% | 0,00% | 0,00% |
| 2065 | 1.5.73.13 | **ELEVADOR** |  | 367d | 2023-08-18 | 2025-01-13 |  | 247d | 0d | 0,00% | 0,00% | 0,00% | 0,00% |
| 2066 | 1.5.73.13.1 | Fabricación, Importación, Transporte y Nacionalización |  | 150d | 2023-08-18 | 2024-03-13 | 2FS+163d | 365d | 107d | 0,00% | 0,00% | 0,00% | 0,00% |
| 2067 | 1.5.73.13.2 | Obras Civiles y Trabajos Preparatorios |  | 3d | 2024-08-13 | 2024-08-16 | 2066, 1998 | 258d | 0d | 0,00% | 0,00% | 0,00% | 0,00% |
| 2068 | 1.5.73.13.3 | Toma de las Medidas del Pozo. Estudio y Análisis de las Medidas. Organización de Almacén y Traslado de Materiales |  | 5d | 2024-08-09 | 2024-08-16 | 2067FF | 258d | 11d | 0,00% | 0,00% | 0,00% | 0,00% |
| 2069 | 1.5.73.13.4 | Izaje de Guías de Carro y CWT. Instalación de Brackets y Primer Tramo de Guías. Instalación de Amortiguadores y Elementos de PIT |  | 25d | 2024-09-02 | 2024-10-03 | 2068, 2006FF, 1998 | 247d | 0d | 0,00% | 0,00% | 0,00% | 0,00% |
| 2070 | 1.5.73.13.5 | Ensamble de Chasis de Cabina, CWT, Armado de Cabina e Izaje de Última Parada, Puesta en MSK |  | 10d | 2024-10-04 | 2024-10-18 | 2069 | 247d | 0d | 0,00% | 0,00% | 0,00% | 0,00% |
| 2071 | 1.5.73.13.6 | Instalación de Soportes de Guías, Rectificación y Alineación |  | 13d | 2024-10-18 | 2024-11-06 | 2070 | 247d | 0d | 0,00% | 0,00% | 0,00% | 0,00% |
| 2072 | 1.5.73.13.7 | Ensamble e Instalación de los Marcos y Puertas de Entrada de Piso |  | 13d | 2024-11-06 | 2024-11-25 | 2071 | 247d | 0d | 0,00% | 0,00% | 0,00% | 0,00% |
| 2073 | 1.5.73.13.8 | Elaboración de Remates Frontales y Acabados de los Mismos, Instalación de Cajas para Botoneras e Indicadores. |  | 15d | 2024-11-06 | 2024-11-27 | 2072SS | 247d | 0d | 0,00% | 0,00% | 0,00% | 0,00% |
| 2074 | 1.5.73.13.9 | Instalación de Cableado de Pozo y Botoneras, Conexiones e Instalación de Cable Viajero |  | 13d | 2024-11-27 | 2024-12-13 | 2073, 2063, 2062 | 247d | 0d | 0,00% | 0,00% | 0,00% | 0,00% |
| 2075 | 1.5.73.13.10 | Ensamble de Cabina, Instalación de Accesorios y Conexiones |  | 10d | 2024-12-13 | 2024-12-27 | 2074 | 247d | 0d | 0,00% | 0,00% | 0,00% | 0,00% |
| 2076 | 1.5.73.13.11 | Inspeccion Mecánica y de Calidad |  | 3d | 2024-12-28 | 2025-01-02 | 2075 | 247d | 0d | 0,00% | 0,00% | 0,00% | 0,00% |
| 2077 | 1.5.73.13.12 | Ajuste y Configuración |  | 7d | 2024-12-28 | 2025-01-09 | 2076SS | 247d | 0d | 0,00% | 0,00% | 0,00% | 0,00% |
| 2078 | 1.5.73.13.13 | Certificación NTC 5926-1 |  | 3d | 2025-01-09 | 2025-01-13 | 2077 | 247d | 0d | 0,00% | 0,00% | 0,00% | 0,00% |
| 2079 | 1.5.73.13.14 | Protocolos, Limpieza, Entrega |  | 3d | 2025-01-09 | 2025-01-13 | 2077 | 247d | 0d | 0,00% | 0,00% | 0,00% | 0,00% |
| 2080 | 1.5.73.13.15 | Fin de Fabricación, Instlación de Elevador | milestone | 0d | 2025-01-13 | 2025-01-13 | 2079, 2078 | 247d | 8d | 0,00% | 0,00% | 0,00% | 0,00% |

| ID | WBS | Task | Type | Duration | Start | Finish | Predecessors | Total slack | Free slack | % Avance Planeado | % avance planeado en costo (texto) | % Completado (décimales) | % Completado en Costo |
| --- | --- | --- | --- | --- | --- | --- | --- | --- | --- | --- | --- | --- | --- |
| 2081 | 1.5.73.14 | **MAMPOSTERÍA, PAÑETES Y ACABADOS** |  | 63d | 2024-01-23 | 2024-04-18 |  | 342d | 192d | 0,00% | 0,00% | 0,00% | 0,00% |
| 2082 | 1.5.73.14.1 | **SUBNIVEL S1** |  | 23d | 2024-02-02 | 2024-03-04 |  | 334d |  | 0,00% | 0,00% | 0,00% | 0,00% |
| 2083 | 1.5.73.14.1.1 | Mampostería En Bloque De Concreto 15120340 |  | 23d | 2024-02-02 | 2024-03-04 | 2010 | 334d | 0d | 0,00% | 0,00% | 0,00% | 0,00% |
| 2084 | 1.5.73.14.1.2 | Muro en ladrillo tolete |  | 23d | 2024-02-02 | 2024-03-04 | 2083SS | 471d | 232d | 0,00% | 0,00% | 0,00% | 0,00% |
| 2085 | 1.5.73.14.2 | **NIVEL A** |  | 15d | 2024-02-22 | 2024-03-13 |  | 334d |  | 0,00% | 0,00% | 0,00% | 0,00% |
| 2086 | 1.5.73.14.2.1 | Mampostería En Bloque De Concreto 15x20x40 De Dos Perforaciones |  | 15d | 2024-02-22 | 2024-03-13 | 2083SS+15d | 334d | 0d | 0,00% | 0,00% | 0,00% | 0,00% |
| 2087 | 1.5.73.14.2.2 | Muro en ladrillo tolete |  | 15d | 2024-02-22 | 2024-03-13 | 2086SS | 464d | 225d | 0,00% | 0,00% | 0,00% | 0,00% |
| 2088 | 1.5.73.14.3 | **PARKING** |  | 40d | 2024-01-23 | 2024-03-15 |  | 412d |  | 0,00% | 0,00% | 0,00% | 0,00% |
| 2089 | 1.5.73.14.3.1 | Mampostería En Bloque De Concreto 15X20X40 De Dos Perforaciones |  | 40d | 2024-01-23 | 2024-03-15 | 1970SS | 412d | 0d | 0,00% | 0,00% | 0,00% | 0,00% |
| 2090 | 1.5.73.14.4 | PAÑETES, ESTUCO, PINTURA Y ENCHAPES |  | 23d | 2024-03-15 | 2024-04-18 | 2083, 2089 | 412d | 0d | 0,00% | 0,00% | 0,00% | 0,00% |
| 2091 | 1.5.73.15 | **ACCESORIOS Y ADECUACIÓN** |  | 15d | 2023-10-13 | 2023-11-03 |  | 545d | 310d | 0,00% | 0,00% | 0,00% | 0,00% |
| 2092 | 1.5.73.15.1 | Sanitarios |  | 15d | 2023-10-13 | 2023-11-03 | 2097 | 545d | 0d | 0,00% | 0,00% | 0,00% | 0,00% |
| 2093 | 1.5.73.15.2 | Lavamanos |  | 15d | 2023-10-13 | 2023-11-03 | 2092SS | 557d | 318d | 0,00% | 0,00% | 0,00% | 0,00% |
| 2094 | 1.5.73.15.3 | Gabinetes |  | 15d | 2023-10-13 | 2023-11-03 | 2097 | 557d | 318d | 0,00% | 0,00% | 0,00% | 0,00% |
| 2095 | 1.5.73.15.4 | Mesones |  | 15d | 2023-10-13 | 2023-11-03 | 2097 | 557d | 318d | 0,00% | 0,00% | 0,00% | 0,00% |
| 2096 | 1.5.73.16 | **PISOS** |  | 22d | 2023-09-15 | 2023-10-13 |  | 228d |  | 0,00% | 0,00% | 0,00% | 0,00% |
| 2097 | 1.5.73.16.1 | Piso en Concrete de 3.000 PSI |  | 22d | 2023-09-15 | 2023-10-13 | 1276 | 228d | 0d | 0,00% | 0,00% | 0,00% | 0,00% |
| 2098 | 1.5.73.16.2 | Baldosa en Granito Pulido |  | 22d | 2023-09-15 | 2023-10-13 | 2097SS | 228d | 0d | 0,00% | 0,00% | 0,00% | 0,00% |
| 2099 | 1.5.73.16.3 | Piso en Granito |  | 22d | 2023-09-15 | 2023-10-13 | 2097SS | 228d | 0d | 0,00% | 0,00% | 0,00% | 0,00% |
| 2100 | 1.5.73.16.4 | Fin Pisos | milestone | 0d | 2023-10-13 | 2023-10-13 | 2097, 2098, 2099 | 228d | 219d | 0,00% | 0,00% | 0,00% | 0,00% |
| 2101 | 1.5.73.17 | **EQUIPOS ESPECIALES** |  | 27d | 2024-04-18 | 2024-05-27 |  | 412d | 133d | 0,00% | 0,00% | 0,00% | 0,00% |
| 2102 | 1.5.73.17.1 | Sistema de Aire Acondicionado |  | 27d | 2024-04-18 | 2024-05-27 | 2090 | 412d | 173d | 0,00% | 0,00% | 0,00% | 0,00% |
| 2103 | 1.5.73.17.2 | Insonorización Espacios |  | 27d | 2024-04-18 | 2024-05-27 | 2090 | 412d | 173d | 0,00% | 0,00% | 0,00% | 0,00% |
| 2104 | 1.5.73.18 | **CARPINTERÍA METÁLICA** |  | 149d | 2023-10-13 | 2024-05-10 |  | 423d | 176d | 0,00% | 0,00% | 0,00% | 0,00% |
| 2105 | 1.5.73.18.1 | Ventanas en Aluminio |  | 15d | 2024-03-13 | 2024-04-05 | 2086 | 449d | 210d | 0,00% | 0,00% | 0,00% | 0,00% |
| 2106 | 1.5.73.18.2 | Cerramiento en Vidrio |  | 15d | 2023-10-13 | 2023-11-03 | 2097 | 557d | 318d | 0,00% | 0,00% | 0,00% | 0,00% |
| 2107 | 1.5.73.18.3 | Puertas |  | 16d | 2024-04-18 | 2024-05-10 | 2090 | 423d | 184d | 0,00% | 0,00% | 0,00% | 0,00% |
| 2108 | 1.5.73.18.4 | Pasamanos |  | 16d | 2024-04-18 | 2024-05-10 | 2090 | 423d | 184d | 0,00% | 0,00% | 0,00% | 0,00% |
| 2109 | 1.5.73.18.5 | Divisiones |  | 12d | 2023-11-03 | 2023-11-22 | 2092 | 545d | 306d | 0,00% | 0,00% | 0,00% | 0,00% |

| ID | WBS | Task | Type | Duration | Start | Finish | Predecessors | Total slack | Free slack | % Avance Planeado | % avance planeado en costo (texto) | % Completado (décimales) | % Completado en Costo |
| --- | --- | --- | --- | --- | --- | --- | --- | --- | --- | --- | --- | --- | --- |
| 2110 | 1.5.73.19 | **FACHADAS** |  | 192d | 2024-03-13 | 2024-12-06 |  | 272d | 25d | 0,00% | 0,00% | 0,00% | 0,00% |
| 2111 | 1.5.73.19.1 | Estructura Manila de Montaje |  | 23d | 2024-10-04 | 2024-11-06 | 2005 | 272d | 0d | 0,00% | 0,00% | 0,00% | 0,00% |
| 2112 | 1.5.73.19.2 | Cortasol Tipo Celoscreen |  | 23d | 2024-11-06 | 2024-12-06 | 2111 | 272d | 0d | 0,00% | 0,00% | 0,00% | 0,00% |
| 2113 | 1.5.73.19.3 | Accesorios |  | 23d | 2024-11-06 | 2024-12-06 | 2112SS | 272d | 33d | 0,00% | 0,00% | 0,00% | 0,00% |
| 2114 | 1.5.73.19.4 | Fachaleta Flotante |  | 19d | 2024-03-13 | 2024-04-10 | 2086 | 334d | 0d | 0,00% | 0,00% | 0,00% | 0,00% |
| 2115 | 1.5.73.20 | **RED CONTRA INCENDIOS** |  | 27d | 2024-03-13 | 2024-04-22 |  | 437d | 158d | 0,00% | 0,00% | 0,00% | 0,00% |
| 2116 | 1.5.73.20.1 | Tubería |  | 15d | 2024-03-13 | 2024-04-05 | 2086 | 437d | 0d | 0,00% | 0,00% | 0,00% | 0,00% |
| 2117 | 1.5.73.20.2 | Cableado |  | 8d | 2024-03-22 | 2024-04-05 | 2116SS+7d | 437d | 0d | 0,00% | 0,00% | 0,00% | 0,00% |
| 2118 | 1.5.73.20.3 | Bombas |  | 10d | 2024-04-05 | 2024-04-18 | 2116, 2117 | 437d | 0d | 0,00% | 0,00% | 0,00% | 0,00% |
| 2119 | 1.5.73.20.4 | Sensor y accesorios |  | 1d | 2024-04-18 | 2024-04-19 | 2118 | 437d | 0d | 0,00% | 0,00% | 0,00% | 0,00% |
| 2120 | 1.5.73.20.5 | Pruebas |  | 1d | 2024-04-19 | 2024-04-22 | 2119 | 437d | 198d | 0,00% | 0,00% | 0,00% | 0,00% |
| 2121 | 1.5.73.21 | **URBANISMO Y ESPACIO PUBLICO** |  | 55d | 2023-12-28 | 2024-03-12 |  | 92d |  | 0,00% | 0,00% | 0,00% | 0,00% |
| 2122 | 1.5.73.21.1 | Rellenos y Bases |  | 27d | 2023-12-28 | 2024-02-03 | 1955, 1937 | 92d | 0d | 0,00% | 0,00% | 0,00% | 0,00% |
| 2123 | 1.5.73.21.2 | Áreas en adoquín y concreto estampado |  | 16d | 2024-02-05 | 2024-02-24 | 2122 | 477d | 238d | 0,00% | 0,00% | 0,00% | 0,00% |
| 2124 | 1.5.73.21.3 | Áreas en Gramoquin |  | 16d | 2024-02-05 | 2024-02-24 | 2122 | 354d | 0d | 0,00% | 0,00% | 0,00% | 0,00% |
| 2125 | 1.5.73.21.4 | Mobiliario Urbano |  | 12d | 2024-02-26 | 2024-03-12 | 2124 | 354d | 20d | 0,00% | 0,00% | 0,00% | 0,00% |
| 2126 | 1.5.73.22 | **PAISAJISMO** |  | 23d | 2024-02-05 | 2024-03-05 |  | 470d | 107d | 0,00% | 0,00% | 0,00% | 0,00% |
| 2127 | 1.5.73.22.1 | Plantación de especies nativas |  | 23d | 2024-02-05 | 2024-03-05 | 2124SS | 470d | 0d | 0,00% | 0,00% | 0,00% | 0,00% |
| 2128 | 1.5.73.22.2 | Colocación Grama |  | 23d | 2024-02-05 | 2024-03-05 | 2127SS | 470d | 231d | 0,00% | 0,00% | 0,00% | 0,00% |
| 2129 | 1.5.73.23 | **PAVIMENTOS** |  | 32d | 2024-04-11 | 2024-05-24 |  | 334d | 50d | 0,00% | 0,00% | 0,00% | 0,00% |
| 2130 | 1.5.73.23.1 | Demoliciones y excavaciones |  | 24d | 2024-04-11 | 2024-05-15 | 2114, 2125 | 334d | 0d | 0,00% | 0,00% | 0,00% | 0,00% |
| 2131 | 1.5.73.23.2 | Estructura de vía |  | 24d | 2024-04-17 | 2024-05-21 | 2130SS+5d | 363d | 0d | 0,00% | 0,00% | 0,00% | 0,00% |
| 2132 | 1.5.73.23.3 | Capa de Rodadura |  | 10d | 2024-05-10 | 2024-05-24 | 2131FF+3d, 2029FF+3d | 363d | 0d | 0,00% | 0,00% | 0,00% | 0,00% |
| 2133 | 1.5.73.23.4 | Fin Pavimentos | milestone | 0d | 2024-05-24 | 2024-05-24 | 2132 | 363d | 0d | 0,00% | 0,00% | 0,00% | 0,00% |

| ID | WBS | Task | Type | Duration | Start | Finish | Predecessors | Total slack | Free slack | % Avance Planeado | % avance planeado en costo (texto) | % Completado (décimales) | % Completado en Costo |
| --- | --- | --- | --- | --- | --- | --- | --- | --- | --- | --- | --- | --- | --- |
| 2134 | 1.5.73.24 | **SEÑALIZACIÓN Y DEMARCACIÓN VIAL** |  | 49d | 2024-05-27 | 2024-08-02 |  | 363d | 0d | 0,00% | 0,00% | 0,00% | 0,00% |
| 2135 | 1.5.73.24.1 | Demarcación vial. Incluye líneas continuas, discontinuas, flechas y demás pictogramas. |  | 44d | 2024-05-27 | 2024-07-27 | 2133FS+1d | 363d | 0d | 0,00% | 0,00% | 0,00% | 0,00% |
| 2136 | 1.5.73.24.2 | Instalación de tachas y estoperoles |  | 20d | 2024-06-04 | 2024-07-02 | 2135SS+5d | 387d | 24d | 0,00% | 0,00% | 0,00% | 0,00% |
| 2137 | 1.5.73.24.3 | Instalación de señales definitivas |  | 5d | 2024-07-29 | 2024-08-02 | 2135 | 363d | 0d | 0,00% | 0,00% | 0,00% | 0,00% |
| 2138 | 1.5.73.24.4 | Fin señalización y Demarcación Vial | milestone | 0d | 2024-08-02 | 2024-08-02 | 2137, 2136 | 363d |  | 0,00% | 0,00% | 0,00% | 0,00% |
| 2139 | 1.5.73.25 | **ENSAMBLE Y MONTAJE DE CABINAS SOBRE EL CABLE** |  | 36d | 2024-08-13 | 2024-09-30 |  | 321d | 33d | 0,00% | 0,00% | 0,00% | 0,00% |
| 2140 | 1.5.73.25.1 | Ensamble de Cabinas (Incluye sistema de energía, video vigilancia y comunicación bidireccional. |  | 36d | 2024-08-13 | 2024-09-30 | 2020, 2089, 1998 | 321d | 0d | 0,00% | 0,00% | 0,00% | 0,00% |
| 2141 | 1.5.73.25.2 | Montaje de Vehículos sobre el cable |  | 31d | 2024-08-21 | 2024-09-30 | 2140SS+5d | 321d | 0d | 0,00% | 0,00% | 0,00% | 0,00% |
| 2142 | 1.5.73.25.3 | Fin de Ensamble y Montaje de Caninas Sobre el Cable | milestone | 0d | 2024-09-30 | 2024-09-30 | 2140, 2141 | 321d | 82d | 0,00% | 0,00% | 0,00% | 0,00% |
| 2143 | 1.5.73.26 | Fin Estación de Retorno La Victoria | milestone | 0d | 2025-01-23 | 2025-01-23 | 2080, 1924, 1957, 1960, 2006, 2002, 2025, 2063, 2089, 2090, 2095, 2099, 2103, 2109, 2114, 2120, 2125, 2128, 2142, 2062, 1998, 2029, 1098, 190, 2084, 2087, 2093, 2094, 2102, 2105, 2106, 2107, 2108, 2113, 2123, 1937 | 239d |  | 0,00% | 0,00% | 0,00% | 0,00% |
| 2144 | 1.5.73.27 | Estación Altamira: Hito de Aprobació Para Pago Preliminares y Cimentación | milestone | 0d | 2024-01-05 | 2024-01-05 | 1913, 1919, 1921, 1938, 1956, 1925 | 514d |  | 0,00% | 0,00% | 0,00% | 0,00% |
| 2145 | 1.5.73.28 | Estación Altamira: Hito de Aprobación Para Pago Superestructura | milestone | 0d | 2024-10-03 | 2024-10-03 | 1961, 2003 | 318d |  | 0,00% | 0,00% | 0,00% | 0,00% |
| 2146 | 1.5.73.29 | Estación Altamira: Hito de Aprobación Para Pago Arquitectura, Acabados y Elevadores | milestone | 0d | 2025-01-13 | 2025-01-13 | 2065, 2081, 2091, 2096, 2104, 2110 | 247d |  | 0,00% | 0,00% | 0,00% | 0,00% |
| 2147 | 1.5.73.30 | Estación Altamira: Hito de Aprobación Para Pago Redes | milestone | 0d | 2024-11-28 | 2024-11-28 | 1958, 2007, 2032, 2101, 2115 | 279d |  | 0,00% | 0,00% | 0,00% | 0,00% |
| 2148 | 1.5.73.31 | Estación Altamira: Hito de Aprobación Para Pago Urbanismo, Paisajismo y Pavimentos | milestone | 0d | 2024-08-02 | 2024-08-02 | 2121, 2126, 2129, 2134 | 363d |  | 0,00% | 0,00% | 0,00% | 0,00% |
| 2149 | 1.5.73.32 | Estación Altamira: Hito de Aprobación Para Pago Componente Electromecánico | milestone | 0d | 2024-11-15 | 2024-11-15 | 2139, 1999 | 288d |  | 0,00% | 0,00% | 0,00% | 0,00% |
| 2150 | 1.5.74 | **EMPALME No 2 BUCLE LA VICTORIA - ALTAMIRA. HALADO -AJUSTE MECÁNICO - HALADO Y EMPALME - AJUSTE ELÉCTRICO** |  | 81d | 2024-11-16 | 2025-03-06 |  | 9d | 0d | 0,00% | 0,00% | 0,00% | 0,00% |
| 2151 | 1.5.74.1 | Cable Piloto |  | 33d | 2024-11-16 | 2024-12-31 | 2002, 1878 | 9d | 0d | 0,00% | 0,00% | 0,00% | 0,00% |
| 2152 | 1.5.74.2 | Cable Portador de la Línea de Seguridad |  | 16d | 2024-12-31 | 2025-01-23 | 2151 | 9d | 0d | 0,00% | 0,00% | 0,00% | 0,00% |
| 2153 | 1.5.74.3 | Cable Portador Tractor |  | 16d | 2025-01-23 | 2025-02-13 | 2152 | 207d | 0d | 0,00% | 0,00% | 0,00% | 0,00% |
| 2154 | 1.5.74.4 | Multiconductores de la Línea de Seguridad |  | 16d | 2025-02-13 | 2025-03-06 | 2153 | 207d | 0d | 0,00% | 0,00% | 0,00% | 0,00% |
| 2155 | 1.5.74.5 | Fin Empalme No. 2 Bucle La Victoria - Altamira | milestone | 0d | 2025-03-06 | 2025-03-06 | 2154 | 207d |  | 0,00% | 0,00% | 0,00% | 0,00% |
| 2156 | 1.5.75 | Bucle La Victoria - Altamira: Hito de Aprobación Para Pago Empalme No.2 | milestone | 0d | 2025-03-06 | 2025-03-06 | 2150 | 207d |  | 0,00% | 0,00% | 0,00% | 0,00% |
| 2157 | 1.5.76 | Manejo, Recuperación o Restauración Ambiental - PMRRA |  | 204d | 2023-07-17 | 2024-04-26 | 1836, 1838, 1839, 1840, 1841, 1842, 1904, 1906, 1907, 1908, 1909, 1910 | 433d |  | 0,00% | 0,00% | 0,00% | 0,00% |

| ID | WBS | Task | Type | Duration | Start | Finish | Predecessors | Total slack | Free slack | % Avance Planeado | % avance planeado en costo (texto) | % Completado (décimales) | % Completado en Costo |
| --- | --- | --- | --- | --- | --- | --- | --- | --- | --- | --- | --- | --- | --- |
| 2158 | 1.5.77 | **PRUEBAS Y PUESTA EN MARCHA, Ajuste Mecánico Estación + línea, Puesta en Marcha, Configuración final - Sincronización Estación y Parking, Pruebas Oficiales con el Cliente y Operación No Comercial** |  | 92d | 2025-02-05 | 2025-06-11 |  | 0d |  | 0,00% | 0,00% | 0,00% | 0,00% |
| 2159 | 1.5.77.1 | Línea de seguridad operativa, reglajes, rodaje y pruebas |  | 60d | 2025-02-05 | 2025-04-28 | 1220, 2152 | 0d |  | 0,00% | 0,00% | 0,00% | 0,00% |
| 2160 | 1.5.77.2 | Recepción por parte del Constructor (Recibo interno) |  | 16d | 2025-04-29 | 2025-05-20 | 2159 | 0d |  | 0,00% | 0,00% | 0,00% | 0,00% |
| 2161 | 1.5.77.3 | Recibo por parte del Cliente (Entidad de control TM) |  | 12d | 2025-05-21 | 2025-06-06 | 2160 | 0d |  | 0,00% | 0,00% | 0,00% | 0,00% |
| 2162 | 1.5.77.4 | Puesta en Marcha. Operación No Comercial (50 horas según la UNE-EN 1709:2020) |  | 4d | 2025-06-06 | 2025-06-11 | 2160, 2161 | 0d |  | 0,00% | 0,00% | 0,00% | 0,00% |
| 2163 | 1.5.77.5 | Fin de Pruebas y Puesta en Marcha | milestone | 0d | 2025-06-11 | 2025-06-11 | 2160, 2161, 2162, 2159 | 0d |  | 0,00% | 0,00% | 0,00% | 0,00% |
| 2164 | 1.5.78 | Pruebas y Puesta en Marcha: Hito de Aprobación Para Pago Pruebas con Cliente y Operación | milestone | 0d | 2025-06-11 | 2025-06-11 | 2158 | 138d | 0d | 0,00% | 0,00% | 0,00% | 0,00% |
| 2165 | 1.5.79 | FIN ETAPA DE CONSTRUCCIÓN | milestone | 0d | 2025-06-11 | 2025-06-11 | 2164 | 138d |  | 0,00% | 0,00% | 0,00% | 0,00% |
| 2166 | 1.5.80 | **GESTIÓN SOCIAL, GESTIÓN AMBIENTAL, PMT Y AJUSTES** |  | 320d | 2023-07-14 | 2024-10-02 |  | 319d |  | 0,00% | 0,00% | 0,00% | 0,00% |
| 2167 | 1.5.80.1 | Gestión Social |  | 320d | 2023-07-14 | 2024-10-02 | 47 | 319d | 0d | 0,00% | 0,00% | 0,00% | 0,00% |
| 2168 | 1.5.80.2 | Gestión Ambiental |  | 320d | 2023-07-14 | 2024-10-02 | 47 | 319d | 0d | 0,00% | 0,00% | 0,00% | 0,00% |
| 2169 | 1.5.80.3 | PMT |  | 320d | 2023-07-14 | 2024-10-02 | 47 | 319d | 0d | 0,00% | 0,00% | 0,00% | 0,00% |
| 2170 | 1.5.80.4 | Fin Gestión Social, Ambiental, PMT y Ajustes | milestone | 0d | 2024-10-02 | 2024-10-02 | 2167, 2168, 2169 | 319d |  | 0,00% | 0,00% | 0,00% | 0,00% |
| 2171 | 1.6 | **ENTRENAMIENTO Y ACOMPAÑAMIENTO EN LA ETAPA DE OPERACIÓN Y MANTENIMIENTO.** |  | 153d | 2025-05-22 | 2025-12-19 |  | 0d |  | 0,00% | 0,00% | 0,00% | 0,00% |
| 2172 | 1.6.1 | Inicio de la Etapa de Operación y Mantenimiento | milestone | 0d | 2025-06-11 | 2025-06-11 | 2163 | 0d |  | 0,00% | 0,00% | 0,00% | 0,00% |
| 2173 | 1.6.2 | Acompañamiento |  | 138d | 2025-06-12 | 2025-12-19 | 2172 | 0d |  | 0,00% | 0,00% | 0,00% | 0,00% |
| 2174 | 1.6.3 | Capacitación para Operación |  | 15d | 2025-05-22 | 2025-06-11 | 2172FS-15d | 123d | 0d | 0,00% | 0,00% | 0,00% | 0,00% |
| 2175 | 1.6.4 | Capacitación para Mantenimiento |  | 30d | 2025-05-22 | 2025-07-03 | 2172FS-30d, 2174SS | 123d |  | 0,00% | 0,00% | 0,00% | 0,00% |
| 2176 | 1.6.5 | Fin de la Etapa de Operación y Mantenimiento | milestone | 0d | 2025-12-19 | 2025-12-19 | 2173, 2174, 2175 | 0d |  | 0,00% | 0,00% | 0,00% | 0,00% |
| 2177 | 1.7 | FIN DEL PROYECTO | milestone | 0d | 2025-12-19 | 2025-12-19 | 2176, 274, 1211, 2143, 9 | 0d |  | 0,00% | 0,00% | 0,00% | 0,00% |
